# BOOM I & T

Schedule from MS Project, 2002-07-01 to 2004-08-13, status date 2003-10-31, A marks actual dates.
BOOM Suite I & T
NASA GSFC
Status Date: 10/31/2003 / Baseline Date: 01/31/2003 R1

## Calendars

- Standard w/ 10 Gov't Holidays: Mon-Fri 08:00-12:00, 13:00-17:00; Sat-Sun off. Exceptions (off unless hours are given): 2002-07-04, 2002-09-02, 2002-10-07, 2002-11-11, 2002-11-28, 2002-12-25, 2003-01-01, 2003-01-13, 2003-02-17, 2003-05-26, 2003-07-04, 2003-09-01, 2003-10-06, 2003-11-10, 2003-11-27, 2003-12-25, 2004-01-01, 2004-01-12, 2004-02-16, 2004-05-31, 2004-07-05.

## Resources

| Resource |
| --- |
| UCB-BOOM |

## Schedule

| ID | WBS | Task | Type | Duration | Start | Finish | Predecessors | Complete | Remaining | Baseline start | Baseline finish | Baseline duration | Total slack | Free slack | Constraint | Text11 | Text12 | Text13 | Text14 | Text16 | Text28 | Text20 | Text22 | Text23 | Text17 |
| --- | --- | --- | --- | --- | --- | --- | --- | --- | --- | --- | --- | --- | --- | --- | --- | --- | --- | --- | --- | --- | --- | --- | --- | --- | --- |
| 1 | 1 | **Management** |  | 534d | 2002-07-01 A | 2004-08-13 |  | 99% | 0d | 2002-07-01 | 2004-07-27 | 521d | 0d |  |  | STEREO | IMPACT | Boom Suite | Boom | Boom | UC-B |  |  |  |  |
| 2 | 1.1 | **Contingency Blocks** |  | 76d | 2004-04-27 | 2004-08-13 |  |  |  | 2004-04-01 | 2004-07-27 | 81d | 0d |  |  | STEREO | IMPACT | Boom Suite | Boom | Boom | UC-B |  |  |  |  |
| 3 | 1.1.1 | BOOM Suite FM 1 Contingency Prior to IMPACT Suite EMC Testing | milestone | 0d | 2004-04-27 | 2004-04-27 | 68 |  |  | 2004-04-01 | 2004-04-01 | 0d | 12d | 0d |  | STEREO | IMPACT | Boom Suite | Boom | Boom | UC-B |  |  |  |  |
| 4 | 1.1.2 | Boom Suite FM 1 Contingency Prior to Ready for Delivery | milestone | 0d | 2004-07-20 | 2004-07-20 | 71 |  |  | 2004-06-09 | 2004-07-14 | 25d | 18d | 0d |  | STEREO | IMPACT | Boom Suite | Boom | Boom | UC-B |  |  |  |  |
| 5 | 1.1.3 | BOOM Suite FM 2 Contingency Prior to IMPACT Suite EMC Testing | milestone | 0d | 2004-06-21 | 2004-06-21 | 74 |  |  | 2004-06-08 | 2004-06-08 | 0d | 13d | 0d |  | STEREO | IMPACT | Boom Suite | Boom | Boom | UC-B |  |  |  |  |
| 6 | 1.1.4 | Boom Suite FM 2 Contingency Prior to Ready for Delivery | milestone | 0d | 2004-08-13 | 2004-08-13 | 76 |  |  | 2004-07-15 | 2004-07-27 | 9d | 0d |  |  | STEREO | IMPACT | Boom Suite | Boom | Boom | UC-B |  |  |  |  |
| 7 | 1.2 | **Milestones** |  | 534d | 2002-07-01 A | 2004-08-13 |  |  | 534d | 2002-07-01 | 2004-07-27 | 521d | 0d |  |  | STEREO | IMPACT | Boom Suite | Boom | Boom | UC-B |  |  |  |  |
| 8 | 1.2.1 | FM 1 Boom Suite I & T Complete | milestone | 0d | 2004-04-27 | 2004-04-27 | 68 |  |  | 2004-04-01 | 2004-04-01 | 0d | 12d | 0d |  | STEREO | IMPACT | Boom Suite | Boom | Boom | UC-B | FM 1 I & T | Boom Suite - FM 1 I & T Complete | FM 1 Boom Suite I & T Complete |  |
| 9 | 1.2.2 | FM 1 Boom Suite Environmental Testing Complete | milestone | 0d | 2004-06-07 | 2004-06-07 | 28 |  |  | 2004-05-18 | 2004-05-18 | 0d | 34d | 16d |  | STEREO | IMPACT | Boom Suite | Boom | Boom | UC-B | FM1 Envt | Boom Suite - FM 1 Environmental Testing Complete | FM 1 Boom Suite Environmental Testing Complete |  |
| 10 | 1.2.3 | FM 2 Boom Suite I & T Complete | milestone | 0d | 2004-06-21 | 2004-06-21 | 74 |  |  | 2004-06-04 | 2004-06-04 | 0d | 13d | 0d |  | STEREO | IMPACT | Boom Suite | Boom | Boom | UC-B | FM 2 I & T | Boom Suite - FM 2 I & T Complete | FM 2 Boom Suite I & T Complete |  |
| 11 | 1.2.4 | FM 2 Boom Suite Environmental Testing Complete | milestone | 0d | 2004-07-06 | 2004-07-06 | 41 |  |  | 2004-06-08 | 2004-06-08 | 0d | 13d |  |  | STEREO | IMPACT | Boom Suite | Boom | Boom | UC-B | FM 2 Envt | Boom Suite - FM 2 Environmental Testing Complete | FM 2 Boom Suite Environmental Testing Complete |  |
| 12 | 1.2.5 | **Receivables** |  | 332d | 2003-03-31 A | 2004-07-23 |  |  | 332d | 2003-02-01 | 2004-07-06 | 359d | 6d |  |  | STEREO | IMPACT | Boom Suite | Boom | Boom | UC-B |  |  |  |  |
| 13 | 1.2.5.1 | Receive RFAs From Instrument CDR | milestone | 0d | 2003-03-31 A | 2003-06-30 A | 46FS+10d | 100% |  | 2003-02-01 | 2003-02-01 | 0d |  |  | start no earlier than 2003-03-31 | STEREO | IMPACT | Boom Suite | Boom | Boom | UC-B |  |  |  |  |
| 14 | 1.2.5.2 | **FM 1** |  | 158d | 2003-11-12 | 2004-06-29 |  |  |  | 2003-02-01 | 2004-06-07 | 339d | 23d |  |  | STEREO | IMPACT | Boom Suite | Boom | Boom | UC-B |  |  |  |  |
| 15 | 1.1.7.6 | Delivery FM 1 Boom Structure | milestone | 0d | 2004-06-29 | 2004-06-29 |  |  |  | 2004-06-07 | 2004-06-07 | 0d | 17d | 0d |  | STEREO | IMPACT | Boom Suite | Boom | Boom | UC-B |  |  |  |  |
| 16 | 1.2.5.2.2 | Receive BOOM FM 1 For BOOM Suite I & T | milestone | 0d | 2004-06-29 | 2004-06-29 | 15 |  |  | 2004-06-07 | 2004-06-07 | 0d | 18d | 0d |  | STEREO | IMPACT | Boom Suite | Boom | Boom | UC-B |  |  |  |  |
| 17 | 1.1.7.3 | Deliver Protoflight Boom for I & T | milestone | 0d | 2003-11-04 | 2003-11-04 |  |  |  | 2003-12-30 | 2003-12-30 | 0d | 110d | 0d |  | STEREO | IMPACT | Boom Suite | Boom | Boom | UC-B |  |  |  |  |
| 18 | 1.2.5.2.4 | Receive Protoflight BOOM for FM 1 BOOM Suite I & T | milestone | 0d | 2003-11-12 | 2003-11-12 | 17FS+5d |  |  | 2004-01-07 | 2004-01-07 | 0d | 110d | 98d |  | STEREO | IMPACT | Boom Suite | Boom | Boom | UC-B |  |  |  |  |
| 19 | 1.1.8.3 | Deliver STE-U FM 1 For STE-U BOOM Suite I & T | milestone | 0d | 2004-03-29 | 2004-03-29 |  |  |  | 2004-01-07 | 2004-01-07 | 0d | 0d |  |  | STEREO | IMPACT | Boom Suite | Boom | Boom | UC-B |  |  |  | Boom |
| 20 | 1.2.5.2.6 | Receive STE-U FM 1 For BOOM Suite I & T | milestone | 0d | 2004-04-05 | 2004-04-05 | 19FF+5d |  |  | 2004-01-15 | 2004-01-15 | 0d | 12d | 0d |  | STEREO | IMPACT | Boom Suite | Boom | Boom | UC-B |  |  |  |  |
| 21 | 1.1.3.3 | Deliver SWEA/STE-D FM 1 For FM 1 BOOM Suite I & T | milestone | 0d | 2004-04-02 | 2004-04-02 |  |  |  | 2004-01-28 | 2004-01-28 | 0d | 18d | 0d |  | STEREO | IMPACT | Boom Suite | Boom | Boom | UC-B |  |  |  | Boom |
| 22 | 1.2.5.2.8 | Receive SWEA/STE-D FM 1 For BOOM Suite I & T | milestone | 0d | 2004-04-05 | 2004-04-05 | 21FS+1d |  |  | 2004-02-04 | 2004-02-04 | 0d | 18d | 0d |  | STEREO | IMPACT | Boom Suite | Boom | Boom | UC-B |  |  |  |  |
| 23 | 1.1.5.41 | Deliver FM 1 MAG For FM 1 Boom Suite I & T | milestone | 0d | 2004-02-19 | 2004-02-19 |  |  |  | 2003-11-05 | 2003-11-05 | 0d | 44d | 0d |  | STEREO | IMPACT | Boom Suite | Boom | Boom | UC-B |  |  |  |  |
| 24 | 1.2.5.2.10 | Receive MAG FM 1 For BOOM Suite I & T | milestone | 0d | 2004-02-19 | 2004-02-19 | 23 |  |  | 2003-11-05 | 2003-11-05 | 0d | 44d | 32d |  | STEREO | IMPACT | Boom Suite | Boom | Boom | UC-B |  |  |  |  |
| 25 | 1.1.5.27 | Deliver IDPU FM 1 For BOOM Suite I & T | milestone | 0d | 2004-03-24 | 2004-03-24 |  |  |  | 2004-02-10 | 2004-02-10 | 0d | 28d | 0d |  | STEREO | IMPACT | Boom Suite | Boom | Boom | UC-B |  |  |  |  |
| 26 | 1.2.5.2.12 | Receive IDPU FM 1 For BOOM Suite/IDPU I & T | milestone | 0d | 2004-03-24 | 2004-03-24 | 25 |  |  | 2004-02-18 | 2004-02-18 | 0d | 28d | 16d |  | STEREO | IMPACT | Boom Suite | Boom | Boom | UC-B |  |  |  |  |
| 27 | 1.1.49.1 | Deliver BOOM Suite FM 1 After EMC Testing | milestone | 0d | 2004-05-28 | 2004-05-28 |  |  |  | 2004-05-07 | 2004-05-07 | 0d | 34d | 0d |  | STEREO | IMPACT | Boom Suite | Boom | Boom | UC-B |  |  |  | Boom |
| 28 | 1.2.5.2.14 | Receive BOOM Suite FM 1 From IMPACT Suite EMC Testing | milestone | 0d | 2004-06-07 | 2004-06-07 | 27FS+5d |  |  | 2004-05-14 | 2004-05-14 | 0d | 34d | 0d |  | STEREO | IMPACT | Boom Suite | Boom | Boom | UC-B |  |  |  |  |
| 29 | 1.1.5.33 | Deliver IDPU FM 1 For Final BOOM Suite I & T | milestone | 0d | 2004-06-07 | 2004-06-07 |  |  |  | 2000-01-01 | 2000-01-01 | 0d | 37d | 0d |  | STEREO | IMPACT | Boom Suite | Boom | Boom | UC-B |  |  |  |  |
| 30 | 1.2.5.2.16 | Receive IDPU FM 1 For Final BOOM Suite I & T | milestone | 0d | 2004-06-07 | 2004-06-07 | 29 |  |  | 2003-02-01 | 2003-02-01 | 0d | 39d | 21d |  | STEREO | IMPACT | Boom Suite | Boom | Boom | UC-B |  |  |  |  |

Notes:
- 4: March 03 Status - Removed 7 days of contingency. Dropped to 10 days from 17 days.

| ID | WBS | Task | Type | Duration | Start | Finish | Predecessors | Complete | Remaining | Baseline start | Baseline finish | Baseline duration | Total slack | Free slack | Constraint | Text11 | Text12 | Text13 | Text14 | Text16 | Text28 | Text17 | Text20 | Text22 | Text23 |
| --- | --- | --- | --- | --- | --- | --- | --- | --- | --- | --- | --- | --- | --- | --- | --- | --- | --- | --- | --- | --- | --- | --- | --- | --- | --- |
| 31 | 1.2.5.3 | **FM 2** |  | 86d | 2004-03-23 | 2004-07-23 |  |  |  | 2003-02-01 | 2004-07-06 | 359d | 0d |  |  | STEREO | IMPACT | Boom Suite | Boom | Boom | UC-B |  |  |  |  |
| 32 | 1.1.7.9 | Delivery FM 2 Boom Structure | milestone | 0d | 2004-07-23 | 2004-07-23 |  |  |  | 2004-07-06 | 2004-07-06 | 0d | 0d |  |  | STEREO | IMPACT | Boom Suite | Boom | Boom | UC-B |  |  |  |  |
| 33 | 1.2.5.3.2 | Receive BOOM FM 2 For BOOM Suite I & T | milestone | 0d | 2004-07-23 | 2004-07-23 | 32 |  |  | 2004-07-06 | 2004-07-06 | 0d | 0d |  |  | STEREO | IMPACT | Boom Suite | Boom | Boom | UC-B |  |  |  |  |
| 34 | 1.1.8.5 | Deliver STE-U FM 2 For STE-U BOOM Suite I & T | milestone | 0d | 2004-03-23 | 2004-03-23 |  |  |  | 2004-04-19 | 2004-04-19 | 0d | 4d | 0d |  | STEREO | IMPACT | Boom Suite | Boom | Boom | UC-B | Boom |  |  |  |
| 35 | 1.2.5.3.4 | Receive STE-U FM 2 For BOOM Suite I & T | milestone | 0d | 2004-03-23 | 2004-03-23 | 34FF |  |  | 2004-04-19 | 2004-04-19 | 0d | 60d | 47d |  | STEREO | IMPACT | Boom Suite | Boom | Boom | UC-B |  |  |  |  |
| 36 | 1.1.5.43 | Deliver FM 2 MAG For FM 2 Boom Suite I & T | milestone | 0d | 2004-04-15 | 2004-04-15 |  |  |  | 2004-01-19 | 2004-01-19 | 0d | 43d | 0d |  | STEREO | IMPACT | Boom Suite | Boom | Boom | UC-B |  |  |  |  |
| 37 | 1.2.5.3.6 | Receive MAG FM 2 For BOOM Suite I & T | milestone | 0d | 2004-04-15 | 2004-04-15 | 36 |  |  | 2004-01-19 | 2004-01-19 | 0d | 43d | 30d |  | STEREO | IMPACT | Boom Suite | Boom | Boom | UC-B |  |  |  |  |
| 38 | 1.1.5.29 | Deliver IDPU FM 2 For BOOM Suite I & T | milestone | 0d | 2004-05-04 | 2004-05-04 |  |  |  | 2004-04-08 | 2004-04-08 | 0d | 38d | 0d |  | STEREO | IMPACT | Boom Suite | Boom | Boom | UC-B |  |  |  |  |
| 39 | 1.2.5.3.8 | Receive IDPU FM 2 For BOOM Suite/IDPU I & T | milestone | 0d | 2004-05-04 | 2004-05-04 | 38 |  |  | 2004-04-08 | 2004-04-08 | 0d | 38d | 25d |  | STEREO | IMPACT | Boom Suite | Boom | Boom | UC-B |  |  |  |  |
| 40 | 1.1.49.3 | Deliver BOOM Suite FM 2 After EMC Testing | milestone | 0d | 2004-06-28 | 2004-06-28 |  |  |  | 2004-06-09 | 2004-06-09 | 0d | 13d | 0d |  | STEREO | IMPACT | Boom Suite | Boom | Boom | UC-B | Boom |  |  |  |
| 41 | 1.2.5.3.10 | Receive BOOM Suite FM 2 From IMPACT Suite EMC Testing | milestone | 0d | 2004-07-06 | 2004-07-06 | 40FS+5d |  |  | 2004-06-22 | 2004-06-22 | 0d | 13d | 0d |  | STEREO | IMPACT | Boom Suite | Boom | Boom | UC-B |  |  |  |  |
| 42 | 1.1.5.35 | Deliver IDPU FM 2 For Final BOOM Suite I & T | milestone | 0d | 2004-05-27 | 2004-05-27 |  |  |  | 2000-01-01 | 2000-01-01 | 0d | 39d | 0d |  | STEREO | IMPACT | Boom Suite | Boom | Boom | UC-B |  |  |  |  |
| 43 | 1.2.5.3.12 | Receive IDPU FM 2 For Final BOOM Suite I & T | milestone | 0d | 2004-05-27 | 2004-05-27 | 42 |  |  | 2003-02-01 | 2003-02-01 | 0d | 39d |  |  | STEREO | IMPACT | Boom Suite | Boom | Boom | UC-B |  |  |  |  |
| 44 | 1.1.3.7 | Deliver SWEA/STE-D FM 2 For FM 2 BOOM Suite I & T | milestone | 0d | 2004-06-21 | 2004-06-21 |  |  |  | 2004-05-04 | 2004-05-04 | 0d | 0d |  |  | STEREO | IMPACT | Boom Suite | Boom | Boom | UC-B | Boom |  |  |  |
| 45 | 1.2.5.3.14 | Receive SWEA/STE-D FM 2 For BOOM Suite I & T | milestone | 0d | 2004-06-21 | 2004-06-21 | 44FF |  |  | 2004-05-04 | 2004-05-04 | 0d | 13d | 0d |  | STEREO | IMPACT | Boom Suite | Boom | Boom | UC-B |  |  |  |  |
| 46 | 1.1.11 | Instrument CDR | milestone | 3d | 2002-11-20 A | 2002-11-22 A |  | 100% |  | 2002-11-20 | 2002-11-22 | 3d |  |  | finish no earlier than 2002-11-22 | STEREO | IMPACT | Boom Suite | Boom | Boom | UC-B | Boom |  |  |  |
| 47 | 1.2.6 | **Deliverables** |  | 534d | 2002-07-01 A | 2004-08-13 |  |  | 534d | 2002-07-01 | 2004-07-27 | 521d | 0d |  |  | STEREO | IMPACT | Boom Suite | Boom | Boom | UC-B |  |  |  |  |
| 48 | 1.2.6.1 | Deliver Thermal Models | milestone | 0d | 2002-07-01 A | 2002-07-01 A |  | 100% |  | 2002-07-01 | 2002-07-01 | 0d |  |  | start no earlier than 2002-07-01 | STEREO | IMPACT | Boom Suite | Boom | Boom | UC-B |  |  |  |  |
| 49 | 1.2.6.2 | **FM 1** |  | 58d | 2004-04-27 | 2004-07-20 |  |  |  | 2004-04-01 | 2004-07-14 | 72d | 12d |  |  | STEREO | IMPACT | Boom Suite | Boom | Boom | UC-B |  |  |  |  |
| 50 | 1.2.6.2.1 | Deliver IDPU FM 1 After BOOM Suite/IDPU I & T | milestone | 0d | 2004-04-27 | 2004-04-27 | 68 |  |  | 2004-04-08 | 2004-04-08 | 0d | 65d | 0d |  | STEREO | IMPACT | Boom Suite | Boom | Boom | UC-B |  |  |  |  |
| 51 | 1.1.4.28 | Receive IDPU FM 1 From BOOM Suite/IDPU I & T | milestone | 0d | 2004-04-27 | 2004-04-27 | 50 |  |  | 2004-04-08 | 2004-04-08 | 0d | 65d |  |  | STEREO | IMPACT | Boom Suite | Boom | Boom | UC-B |  |  |  |  |
| 52 | 1.2.6.2.3 | Deliver BOOM Suite FM 1 For EMC Testing | milestone | 0d | 2004-04-27 | 2004-04-27 | 3, 8 |  |  | 2004-04-01 | 2004-04-01 | 0d | 12d | 0d |  | STEREO | IMPACT | Boom Suite | Boom | Boom | UC-B |  |  |  |  |
| 53 | 1.1.48.2 | Receive BOOM Suite FM 1 For EMC Testing | milestone | 0d | 2004-04-28 | 2004-04-28 | 52FS+1d |  |  | 2004-04-08 | 2004-04-08 | 0d | 12d |  |  | STEREO | IMPACT | Boom Suite | Boom | Boom | UC-B | Boom |  |  |  |
| 54 | 1.2.6.2.5 | BOOM Suite FM 1 Ready for Delivery to APL | milestone | 0d | 2004-07-20 | 2004-07-20 | 4 |  |  | 2004-07-14 | 2004-07-14 | 0d | 18d | 0d |  | STEREO | IMPACT | Boom Suite | Boom | Boom | UC-B |  | FM1 Rdy | BOOM Suite - FM 1 Ready For Delivery | BOOM Suite FM 1 Ready for Delivery to APL |
| 55 | 1.1.1.2 | Receive BOOM FM 1 For BOOM Suite Delivery | milestone | 0d | 2004-07-20 | 2004-07-20 | 54 |  |  | 2004-07-14 | 2004-07-14 | 0d | 30d | 0d |  | STEREO | IMPACT | Boom Suite | Boom | Boom | UC-B |  |  |  |  |

| ID | WBS | Task | Type | Duration | Start | Finish | Predecessors | Complete | Baseline start | Baseline finish | Baseline duration | Total slack | Free slack | Constraint | Text11 | Text12 | Text13 | Text14 | Text16 | Text28 | Text17 | Text20 | Text22 | Text23 | Text21 |
| --- | --- | --- | --- | --- | --- | --- | --- | --- | --- | --- | --- | --- | --- | --- | --- | --- | --- | --- | --- | --- | --- | --- | --- | --- | --- |
| 56 | 1.2.6.3 | **FM 2** |  | 38d | 2004-06-21 | 2004-08-13 |  |  | 2004-06-04 | 2004-07-27 | 36d | 0d |  |  | STEREO | IMPACT | Boom Suite | Boom | Boom | UC-B |  |  |  |  |  |
| 57 | 1.2.6.3.1 | Deliver IDPU FM 2 After BOOM Suite/IDPU I & T | milestone | 0d | 2004-06-28 | 2004-06-28 | 74FS+5d |  | 2004-06-04 | 2004-06-04 | 0d | 22d | 0d |  | STEREO | IMPACT | Boom Suite | Boom | Boom | UC-B |  |  |  |  |  |
| 58 | 1.1.4.30 | Receive IDPU FM 2 From BOOM Suite/IDPU I & T | milestone | 0d | 2004-06-28 | 2004-06-28 | 57 |  | 2004-06-09 | 2004-06-09 | 0d | 22d |  |  | STEREO | IMPACT | Boom Suite | Boom | Boom | UC-B |  |  |  |  |  |
| 59 | 1.2.6.3.3 | Deliver BOOM Suite FM 2 For EMC Testing | milestone | 0d | 2004-06-21 | 2004-06-21 | 5, 10 |  | 2004-06-08 | 2004-06-08 | 0d | 13d | 0d |  | STEREO | IMPACT | Boom Suite | Boom | Boom | UC-B |  |  |  |  |  |
| 60 | 1.1.48.4 | Receive BOOM Suite FM 2 For EMC Testing | milestone | 0d | 2004-06-21 | 2004-06-21 | 59 |  | 2004-06-02 | 2004-06-02 | 0d | 13d | 0d |  | STEREO | IMPACT | Boom Suite | Boom | Boom | UC-B | Boom |  |  |  |  |
| 61 | 1.2.6.3.5 | BOOM Suite FM 2 Ready for Delivery to APL | milestone | 0d | 2004-08-13 | 2004-08-13 | 6 |  | 2004-07-27 | 2004-07-27 | 0d | 0d |  |  | STEREO | IMPACT | Boom Suite | Boom | Boom | UC-B |  | FM2 Rdy | BOOM Suite - FM 2 Ready For Delivery | BOOM Suite FM 2 Ready for Delivery to APL |  |
| 62 | 1.1.1.4 | Receive BOOM FM 2 For BOOM Suite Delivery | milestone | 0d | 2004-08-13 | 2004-08-13 | 61 |  | 2004-07-23 | 2004-07-23 | 0d | 21d | 0d |  | STEREO | IMPACT | Boom Suite | Boom | Boom | UC-B |  |  |  |  |  |
| 63 | 1.3 | **Documentation** |  | 5d | 2003-06-02 A | 2003-06-06 A |  | 100% | 2003-02-03 | 2003-02-07 | 5d |  |  |  | STEREO | IMPACT | Boom Suite | Boom | Boom | UC-B |  |  |  |  |  |
| 64 | 1.3.1 | Test Plan |  | 5d | 2003-06-02 A | 2003-06-06 A |  | 100% | 2003-02-03 | 2003-02-07 | 5d |  |  | start no earlier than 2003-05-31 | STEREO | IMPACT | Boom Suite | Boom | Boom | UC-B |  |  |  |  |  |
| 65 | 2 | **Integration & Test** |  | 92d | 2004-04-06 | 2004-08-13 |  |  | 2004-02-05 | 2004-07-14 | 112d | 0d |  |  | STEREO | IMPACT | Boom Suite | Boom | Boom | UC-B |  |  |  |  |  |
| 66 | 2.1 | **FM 1** |  | 74d | 2004-04-06 | 2004-07-20 |  |  | 2004-02-05 | 2004-06-08 | 87d | 12d |  |  | STEREO | IMPACT | Boom Suite | Boom | Boom | UC-B |  |  |  |  |  |
| 67 | 2.1.1 | FM 1 Boom/SWEA/STE/MAG I&T |  | 8d | 2004-04-06 | 2004-04-15 | 22FS-6d, 20, 24, 18 |  | 2004-02-05 | 2004-03-04 | 20d | 12d | 0d |  | STEREO | IMPACT | Boom Suite | Boom | Boom | UC-B |  | Begin FM 1 I & T |  |  | Begin FM 1 I & T / Boom/SWEA/STE/MAG |
| 68 | 2.1.2 | FM 1 Integrated Boom/IDPU I&T |  | 8d | 2004-04-16 | 2004-04-27 | 26, 67 |  | 2004-03-05 | 2004-04-01 | 20d | 12d | 0d |  | STEREO | IMPACT | Boom Suite | Boom | Boom | UC-B |  |  |  |  | BOOM/IDPU |
| 69 | 9.2.8 | SWEA/STE-D FM 1 Thermal Vac/Thermal Balance |  | 14d | 2004-06-01 | 2004-06-18 |  |  |  |  |  | 1d |  |  | STEREO | IMPACT | Boom Suite | Boom | Boom | UC-B |  |  |  |  |  |
| 70 | 2.1.4 | BOOM Suite FM 1 Bakeout |  | 5d | 2004-06-30 | 2004-07-07 | 16, 68, 28, 9, 69 |  | 2004-05-19 | 2004-05-25 | 5d | 18d | 0d |  | STEREO | IMPACT | Boom Suite | Boom | Boom | UC-B |  |  |  |  |  |
| 71 | 2.1.5 | Final BOOM Suite FM 1 I & T |  | 9d | 2004-07-08 | 2004-07-20 | 70, 30 |  | 2004-05-26 | 2004-06-08 | 9d | 18d | 0d |  | STEREO | IMPACT | Boom Suite | Boom | Boom | UC-B |  |  |  |  | Final BOOM I&T |
| 72 | 2.2 | **FM 2** |  | 54d | 2004-05-28 | 2004-08-13 |  |  | 2004-05-07 | 2004-07-14 | 47d | 0d |  |  | STEREO | IMPACT | Boom Suite | Boom | Boom | UC-B |  |  |  |  |  |
| 73 | 2.2.1 | FM 2 Boom/SWEA/STE/MAG I&T |  | 8d | 2004-05-28 | 2004-06-09 | 45FF-8d, 35, 37 |  | 2004-05-07 | 2004-05-20 | 10d | 13d | 0d |  | STEREO | IMPACT | Boom Suite | Boom | Boom | UC-B |  | Begin FM 2 I & T |  |  | Begin FM 2 I & T / Boom/SWEA/STE/MAG |
| 74 | 2.2.2 | FM 2 Integrated Boom/IDPU I&T |  | 8d | 2004-06-10 | 2004-06-21 | 39, 73 |  | 2004-05-21 | 2004-06-04 | 10d | 13d | 0d |  | STEREO | IMPACT | Boom Suite | Boom | Boom | UC-B |  |  |  |  | BOOM/IDPU |
| 75 | 2.2.3 | BOOM Suite FM 2 Bakeout |  | 5d | 2004-07-26 | 2004-07-30 | 43, 41, 33, 74, 11 |  | 2004-06-23 | 2004-06-29 | 5d | 0d |  |  | STEREO | IMPACT | Boom Suite | Boom | Boom | UC-B |  |  |  |  |  |
| 76 | 2.2.4 | Final BOOM Suite FM 2 I & T |  | 10d | 2004-08-02 | 2004-08-13 | 75 |  | 2004-06-30 | 2004-07-14 | 10d | 0d |  |  | STEREO | IMPACT | Boom Suite | Boom | Boom | UC-B |  |  |  |  | Final BOOM I & T |

Notes:
- 67: March 03 Status - place a 6 day lag into the I & T effort before the SWEA/STE-D are integrated into the suite.
- 73: March 03 Status - Delayed need of SWEA/STE-D FM 2 till 8 days into Boom Suite FM 2 I & T
