# IMPACT BOOM

Schedule from MS Project, 2000-05-26 to 2004-09-14, status date 2003-10-31, A marks actual dates.
IMPACT BOOM Development With I & T
NASA GSFC
Status Date: 10/31/2003 / Baseline Date: 01/31/2003 R1

## Calendars

- Standard w/ 10 Gov't Holidays: Mon-Fri 08:00-12:00, 13:00-17:00; Sat-Sun off. Exceptions (off unless hours are given): 2000-05-29, 2000-07-04, 2000-09-04, 2000-10-09, 2000-11-13, 2000-11-23, 2000-12-25, 2001-01-01, 2001-01-15, 2001-02-19, 2001-05-28, 2001-07-04, 2001-09-03, 2001-10-08, 2001-11-12, 2001-11-22, 2001-12-25, 2002-01-01, 2002-01-14, 2002-02-18, 2002-05-27, 2002-07-04, 2002-09-02, 2002-10-07, 2002-11-11, 2002-11-28, 2002-12-25, 2003-01-01, 2003-01-13, 2003-02-17, 2003-05-26, 2003-07-04, 2003-09-01, 2003-10-06, 2003-11-10, 2003-11-27, 2003-12-25, 2004-01-01, 2004-01-12, 2004-02-16, 2004-05-31, 2004-07-05, 2004-09-06.

## Resources

| Resource |
| --- |
| UCB-BOOM |

## Schedule

| ID | WBS | Task | Type | Duration | Start | Finish | Predecessors | Complete | Remaining | Baseline start | Baseline finish | Baseline duration | Total slack | Free slack | Constraint | Text11 | Text12 | Text13 | Text14 | Text16 | Text28 | Text23 | Text17 | Text20 | Text21 | Text22 |
| --- | --- | --- | --- | --- | --- | --- | --- | --- | --- | --- | --- | --- | --- | --- | --- | --- | --- | --- | --- | --- | --- | --- | --- | --- | --- | --- |
| 1 | 1 | **Management** |  | 325d | 2003-05-31 A | 2004-09-14 |  |  | 325d | 2002-07-01 | 2004-09-14 | 555d | 0d |  |  | STEREO | IMPACT | Boom Suite | Boom | Boom | UC-B |  |  |  |  |  |
| 2 | 1.1 | **Milestones** |  | 325d | 2003-05-31 A | 2004-09-14 |  |  | 325d | 2002-07-01 | 2004-09-14 | 555d | 0d |  |  | STEREO | IMPACT | Boom Suite | Boom | Boom | UC-B |  |  |  |  |  |
| 3 | 1.1.1 | **Receivables** |  | 304d | 2003-05-31 A | 2004-08-13 |  |  | 304d | 2003-05-31 | 2004-07-20 | 286d | 21d |  |  | STEREO | IMPACT | Boom Suite | Boom | Boom | UC-B |  |  |  |  |  |
| 4 | 1.2.6.2.5 | BOOM Suite FM 1 Ready for Delivery to APL | milestone | 0d | 2004-07-20 | 2004-07-20 |  |  |  | 2004-07-06 | 2004-07-06 | 0d | 18d | 0d |  | STEREO | IMPACT | Boom Suite | Boom | Boom | UC-B |  |  |  |  |  |
| 5 | 1.1.1.2 | Receive BOOM FM 1 For BOOM Suite Delivery | milestone | 0d | 2004-07-20 | 2004-07-20 | 4 |  |  | 2004-07-06 | 2004-07-06 | 0d | 30d | 0d |  | STEREO | IMPACT | Boom Suite | Boom | Boom | UC-B | Boom Suite - FM 1 Ready for Delivery to APL |  |  |  |  |
| 6 | 1.2.6.3.5 | BOOM Suite FM 2 Ready for Delivery to APL | milestone | 0d | 2004-08-13 | 2004-08-13 |  |  |  | 2004-07-20 | 2004-07-20 | 0d | 0d |  |  | STEREO | IMPACT | Boom Suite | Boom | Boom | UC-B |  |  |  |  |  |
| 7 | 1.1.1.4 | Receive BOOM FM 2 For BOOM Suite Delivery | milestone | 0d | 2004-08-13 | 2004-08-13 | 6 |  |  | 2004-07-20 | 2004-07-20 | 0d | 21d | 0d |  | STEREO | IMPACT | Boom Suite | Boom | Boom | UC-B | Boom Suite - FM 2 Ready for Delivery to APL |  |  |  |  |
| 8 | 1.1.11 | Instrument CDR | milestone | 3d | 2002-11-20 A | 2002-11-22 A |  | 100% |  | 2002-11-20 | 2002-11-22 | 3d |  |  | finish no earlier than 2002-11-22 | STEREO | IMPACT | Boom Suite | Boom | Boom | UC-B |  | Boom |  |  |  |
| 9 | 1.1.1.6 | Receive RFAs From Instrument CDR | milestone | 0d | 2003-05-31 A | 2003-05-31 A | 8FS+10d | 100% |  | 2003-05-31 | 2003-05-31 | 0d |  |  | start no earlier than 2003-05-31 | STEREO | IMPACT | Boom Suite | Boom | Boom | UC-B |  |  |  |  |  |
| 10 | 1.1.2 | **Contingency** |  | 39d | 2004-07-20 | 2004-09-14 |  |  |  | 2002-07-01 | 2004-09-14 | 555d | 0d |  |  | STEREO | IMPACT | Boom Suite | Boom | Boom | UC-B |  |  |  |  |  |
| 11 | 1.1.2.1 | BOOM Suite FM 1 Project Contingency | milestone | 0d | 2004-07-20 | 2004-07-20 | 5 |  |  | 2004-07-14 | 2004-07-14 | 0d | 30d | 0d |  | STEREO | IMPACT | Boom Suite | Boom | Boom | UC-B | BOOM Suite FM 1 Project Contingency |  | FM 1 Del | Deliver BOOM Suite FM 1L / Bar 2 IMPACT #1 DEL | BOOM Suite - FM 1 Delivery to APL |
| 12 | 1.1.2.2 | BOOM Suite FM 2 Project Contingency | milestone | 0d | 2004-08-13 | 2004-08-13 | 7 |  |  | 2004-07-27 | 2004-07-27 | 0d | 21d | 0d |  | STEREO | IMPACT | Boom Suite | Boom | Boom | UC-B | BOOM Suite FM 1 Project Contingency |  | FM 1 Del | Deliver BOOM Suite FM 1L / Bar 2 IMPACT #1 DEL | BOOM Suite - FM 1 Delivery to APL |
| 13 | 1.1.2.3 | Place Holder Task - Do Not Remove - Jim Rogers |  | 35d | 2004-07-27 | 2004-09-14 |  |  |  | 2004-07-27 | 2004-09-14 | 35d | 0d |  | start no earlier than 2004-07-27 | STEREO | IMPACT | Boom Suite | Boom | Boom | UC-B | BOOM Suite FM 2 Project Contingency |  | FM 2 Del | Deliver BOOM Suite FM 2L / Bar 2 IMPACT #2 DEL | BOOM Suite - FM 2 Delivery to APL |
| 14 | 1.1.2.4 | Boom Suite FM 1 Contractual Date |  | 1d | 2004-07-21 | 2004-07-21 | 11 |  |  | 2004-07-14 | 2004-07-14 | 1d | 30d |  | finish no later than 2004-09-01 | STEREO | IMPACT | Boom Suite | Boom | Boom | UC-B |  |  |  |  |  |
| 15 | 1.1.2.5 | Boom Suite FM 2 Contractual Date | milestone | 0d | 2004-08-13 | 2004-08-13 | 12 |  |  | 2004-07-27 | 2004-07-27 | 0d | 21d |  | finish no later than 2004-09-15 | STEREO | IMPACT | Boom Suite | Boom | Boom | UC-B |  |  |  |  |  |
| 16 | 2 | BOOM - Boom Structure |  | 909d | 2000-12-11 A | 2004-07-23 |  | 75% | 231.29d | 2000-12-11 | 2004-07-06 | 896d | 36d |  |  | STEREO | IMPACT | Boom Suite | Boom | Boom | UC-B |  |  |  |  |  |
| 17 | 3 | MAG - Magnetometer |  | 854d | 2000-09-01 A | 2004-01-30 |  | 90% | 85.46d | 2000-09-01 | 2004-01-19 | 844.45d | 158d |  |  | STEREO | IMPACT | Boom Suite | Boom | MAG | GSFC |  |  |  |  |  |
| 18 | 4 | STE - Suprathermal Electron Telescope and SWEA - Solar Wind Electron Analyzer |  | 829d | 2001-03-06 A | 2004-06-21 |  | 69% | 258.76d | 2001-03-06 | 2004-05-28 | 814d | 59d |  |  | STEREO | IMPACT | Boom Suite | SSI | SWEA/STE-D | UC-B |  |  |  |  |  |
| 19 | 5 | **Emulators/Simulators/GSE** |  | 375d | 2002-07-01 A | 2003-12-29 |  | 81% | 70.92d | 2002-07-01 | 2003-12-29 | 375d | 180d |  |  | STEREO | IMPACT | Boom Suite | Boom | Boom | UC-B |  |  |  |  |  |
| 20 | 5.1 | **Simulators** |  | 189.7d | 2002-10-01 A | 2003-07-03 A |  | 100% |  | 2002-10-01 | 2003-07-03 | 189.7d |  |  |  | STEREO | IMPACT | Boom Suite | Boom | Boom | UC-B |  |  |  |  |  |
| 21 | 5.1.1 | SWEA/STE/LVPS Mass Dummy |  | 3d | 2002-10-01 A | 2003-07-03 A |  | 100% |  | 2002-10-01 | 2003-07-03 | 3d |  |  | start no earlier than 2002-09-30 | STEREO | IMPACT | Boom Suite | Boom | Boom | UC-B |  |  |  |  |  |
| 22 | 5.2 | **GSE** |  | 375d | 2002-07-01 A | 2003-12-29 |  | 81% | 72.99d | 2002-07-01 | 2003-12-29 | 375d | 180d |  |  | STEREO | IMPACT | Boom Suite | Boom | Boom | UC-B |  |  |  |  |  |
| 23 | 5.2.1 | Design GSE Fixtures |  | 5.75d | 2002-09-03 A | 2002-10-02 A |  | 100% |  | 2002-09-03 | 2002-10-02 | 5.75d |  |  | start no earlier than 2002-08-31 | STEREO | IMPACT | Boom Suite | Boom | Boom | UC-B |  |  |  |  |  |
| 24 | 5.2.2 | Inspect GSE Fixtures |  | 1d | 2002-10-07 A | 2003-07-01 A |  | 100% |  | 2002-10-07 | 2003-07-01 | 1d |  |  | start no earlier than 2002-06-30 | STEREO | IMPACT | Boom Suite | Boom | Boom | UC-B |  |  |  |  |  |
| 25 | 5.2.3 | Inspect Reworked GSE Fixtures |  | 1d | 2003-06-02 A | 2003-06-02 A |  | 100% |  | 2003-06-02 | 2003-06-02 | 1d |  |  | start no earlier than 2003-05-31 | STEREO | IMPACT | Boom Suite | Boom | Boom | UC-B |  |  |  |  |  |
| 26 | 5.2.4 | GSE Track & Trolleys |  | 20d | 2002-09-03 A | 2003-07-22 A |  | 100% |  | 2002-09-03 | 2003-07-22 | 20d |  |  | start no earlier than 2002-08-31 | STEREO | IMPACT | Boom Suite | Boom | Boom | UC-B |  |  |  |  |  |
| 27 | 5.2.5 | GSE Chamber Modifications |  | 20d | 2003-06-02 A | 2003-06-27 A |  | 100% |  | 2003-06-02 | 2003-06-27 | 20d |  |  | start no earlier than 2003-05-31 | STEREO | IMPACT | Boom Suite | Boom | Boom | UC-B |  |  |  |  |  |
| 28 | 5.2.6 | GSE Vertical Deployment Fixture |  | 14d | 2002-10-01 A | 2002-10-21 A |  | 100% |  | 2002-10-01 | 2002-10-21 | 14d |  |  | start no earlier than 2002-09-30 | STEREO | IMPACT | Boom Suite | Boom | Boom | UC-B |  |  |  |  |  |
| 29 | 5.2.7 | Clean Room Facility |  | 20d | 2002-07-02 A | 2002-09-16 A |  | 100% |  | 2002-07-02 | 2002-09-16 | 20d |  |  | start no earlier than 2002-07-01 | STEREO | IMPACT | Boom Suite | Boom | Boom | UC-B |  |  |  |  |  |
| 30 | 5.2.8 | Shipping Containers |  | 20d | 2003-12-01 | 2003-12-29 |  |  |  | 2003-12-01 | 2003-12-29 | 20d | 180d |  | start no earlier than 2003-12-01 | STEREO | IMPACT | Boom Suite | Boom | Boom | UC-B |  |  |  |  |  |
| 31 | 5.2.9 | Video Camera Available |  | 1d | 2002-07-01 A | 2002-07-01 A |  | 100% |  | 2002-07-01 | 2002-07-01 | 1d |  |  | start no earlier than 2002-07-01 | STEREO | IMPACT | Boom Suite | Boom | Boom | UC-B |  |  |  |  |  |
| 32 | 6 | SWEA - Solar Wind Electron Analyzer (CESR) |  | 914d | 2000-08-05 A | 2004-03-30 |  | 97% | 30.2d | 2000-08-05 | 2004-03-02 | 894d | 117d |  |  | STEREO | IMPACT | Boom Suite | Boom | Boom | UC-B |  |  |  |  |  |
| 33 | 7 | STE - Suprathermal Electron Telescope |  | 962d | 2000-05-26 A | 2004-03-29 |  | 91% | 89.38d | 2000-05-26 | 2004-04-02 | 966d | 118d |  |  | STEREO | IMPACT | Boom Suite | Boom | Boom | UC-B |  |  |  |  |  |
| 34 | 8 | BOOM I & T |  | 534d | 2002-07-01 A | 2004-08-13 |  | 8% | 493.55d | 2002-07-01 | 2004-07-20 | 516d | 21d |  |  | STEREO | IMPACT | Boom Suite | Boom | Boom | UC-B |  |  |  |  |  |
