# IMPACT

Schedule from MS Project, 2000-01-01 to 2005-06-28, status date 2003-10-31, A marks actual dates.
IMPACT Suite Development Schedule
NASA GSFC
Status Date: 10/31/2003 / Baseline Date: 01/31/2003 R1

## Calendars

- Standard w/ 10 Gov't Holidays: Mon-Fri 08:00-12:00, 13:00-17:00; Sat-Sun off. Exceptions (off unless hours are given): 2000-01-17, 2000-02-21, 2000-05-29, 2000-07-04, 2000-09-04, 2000-10-09, 2000-11-13, 2000-11-23, 2000-12-25, 2001-01-01, 2001-01-15, 2001-02-19, 2001-05-28, 2001-07-04, 2001-09-03, 2001-10-08, 2001-11-12, 2001-11-22, 2001-12-25, 2002-01-01, 2002-01-14, 2002-02-18, 2002-05-27, 2002-07-04, 2002-09-02, 2002-10-07, 2002-11-11, 2002-11-28, 2002-12-25, 2003-01-01, 2003-01-13, 2003-02-17, 2003-05-26, 2003-07-04, 2003-09-01, 2003-10-06, 2003-11-10, 2003-11-27, 2003-12-25, 2004-01-01, 2004-01-12, 2004-02-16, 2004-05-31, 2004-07-05, 2004-09-06, 2004-10-11, 2004-11-08, 2004-11-25, 2004-12-24, 2004-12-31, 2005-01-17, 2005-02-21, 2005-05-30.

## Schedule

| ID | WBS | Task | Type | Duration | Start | Finish | Predecessors | Complete | Remaining | Baseline start | Baseline finish | Baseline duration | Total slack | Free slack | Constraint | Text11 | Text12 | Text28 | Text20 | Text21 | Text22 | Text23 |
| --- | --- | --- | --- | --- | --- | --- | --- | --- | --- | --- | --- | --- | --- | --- | --- | --- | --- | --- | --- | --- | --- | --- |
| 1 | 1 | **Management** |  | 1028d | 2000-05-24 A | 2004-06-28 |  | 99% | 0d | 2000-05-24 | 2004-06-15 | 1019d | 250.76d |  |  | STEREO | IMPACT | UC-B |  |  |  |  |
| 2 | 1.1 | **Milestones** |  | 1028d | 2000-05-24 A | 2004-06-28 |  | 99% | 0d | 2000-05-24 | 2004-06-15 | 1019d | 250.76d |  |  | STEREO | IMPACT | UC-B |  |  |  |  |
| 3 | 1.1.1 | Instrument SRR | milestone | 0d | 2000-05-24 A | 2000-05-24 A |  | 100% |  | 2000-05-24 | 2000-05-24 | 0d |  |  | start no earlier than 2000-05-24 | STEREO | IMPACT | UC-B |  |  |  |  |
| 4 | 2.1.1.1 | STE Aperture Design |  | 58d | 2000-05-26 A | 2000-08-17 A | 3FS+2d | 100% |  | 2000-05-26 | 2000-08-17 | 58d |  |  |  | STEREO | IMPACT |  |  |  |  |  |
| 5 | 3.1.2.1 | STE Charge Sensitive Amplifier Design |  | 318d | 2000-05-26 A | 2001-08-30 A | 3FS+2d | 100% |  | 2000-05-26 | 2001-08-30 | 318d |  |  |  | STEREO | IMPACT |  |  |  |  |  |
| 6 | 3.1.1.1.2 | Procure STE ETU Detector |  | 318d | 2000-05-26 A | 2001-08-30 A | 3FS+2d | 100% |  | 2000-05-26 | 2001-08-30 | 318d |  |  |  | STEREO | IMPACT |  |  |  |  |  |
| 7 | 1.1.5 | Instrument PDR | milestone | 1d | 2001-09-11 A | 2001-09-11 A |  | 100% |  | 2001-09-11 | 2001-09-11 | 1d |  |  | start no earlier than 2001-09-11 | STEREO | IMPACT | UC-B | PDR | PDR |  |  |
| 8 | 2.1.7 | Collect & verify SEP power requirements |  | 2d | 2001-09-11 A | 2001-09-12 A | 7 | 100% |  | 2001-09-11 | 2001-09-12 | 2d |  |  |  | STEREO | IMPACT |  |  |  |  |  |
| 9 | 6.1.2.1.1 | Collect & verify SEP analog/post-reg requirements |  | 6.5d | 2002-01-02 A | 2002-12-03 A | 7FS+76d | 100% |  | 2002-01-02 | 2002-12-03 | 6.5d |  |  |  | STEREO | IMPACT |  |  |  |  |  |
| 10 | 7.1.2.1.2 | Collect & verify SEP Solid State Detector bias requirements |  | 2d | 2001-11-06 A | 2001-11-07 A | 7FS+39d | 100% |  | 2001-11-06 | 2001-11-07 | 2d |  |  |  | STEREO | IMPACT |  |  |  |  |  |
| 11 | 3.1.1.2.3 | (OBSOLETE) Procure STE FM 1 & FM 2 Detectors |  | 21d | 2003-06-02 A | 2003-06-30 A | 7 | 100% |  | 2003-04-25 | 2003-08-11 | 75d |  |  | start no earlier than 2003-05-31 | STEREO | IMPACT |  |  |  |  |  |
| 12 | 3.1.1.2.2 | Procure STE Long Lead Parts |  | 241d | 2001-09-11 A | 2003-07-29 A | 7 | 100% |  | 2001-09-11 | 2003-03-31 | 241d |  |  |  | STEREO | IMPACT |  |  |  |  |  |
| 13 | 1.1.11 | Instrument CDR | milestone | 3d | 2002-11-20 A | 2002-11-22 A |  | 100% |  | 2002-11-20 | 2002-11-22 | 3d |  |  | finish no earlier than 2002-11-22 | STEREO | IMPACT | UC-B | CDR | CDR | IMPACT - Instrument CDR | Instrument CDR |
| 14 | 1.2.5.1 | Receive RFAs From Instrument CDR | milestone | 0d | 2003-03-31 A | 2003-06-30 A | 13FS+10d | 100% |  | 2003-02-01 | 2003-02-01 | 0d |  |  | start no earlier than 2003-03-31 | STEREO | IMPACT |  |  |  |  |  |
| 15 | 2.1.9 | Collect SEP power req update |  | 1d | 2003-09-29 A | 2003-09-29 A | 13 | 100% |  | 2003-06-11 | 2003-06-11 | 1d |  |  |  | STEREO | IMPACT |  |  |  |  |  |
| 16 | 6.1.2.2.2 | Collect SEP analog/post-reg requirements update |  | 1d | 2003-06-17 A | 2003-07-02 A | 13 | 100% |  | 2003-07-07 | 2003-07-07 | 1d |  |  |  | STEREO | IMPACT |  |  |  |  |  |
| 17 | 2.1.2 | Write final Software Development Plan |  | 5d | 2002-09-23 A | 2002-09-27 A | 13FS-8d | 100% |  | 2002-09-23 | 2002-09-27 | 5d |  |  |  | STEREO | IMPACT |  |  |  |  |  |
| 18 | 2.1.2.2.2.1 | Fabricate STE FM 2 Box |  | 15d | 2003-11-21 | 2003-12-12 | 13 |  |  | 2003-11-20 | 2004-01-16 | 38d | 31d |  | start no earlier than 2003-11-21 | STEREO | IMPACT |  |  |  |  |  |
| 19 | 2.1.2.2.1.1 | Fabricate STE FM 1 Box |  | 15d | 2003-11-21 | 2003-12-12 | 13 |  |  | 2003-02-03 | 2003-03-24 | 35d | 12d |  | start no earlier than 2003-11-21 | STEREO | IMPACT |  |  |  |  |  |
| 20 | 3.1.3.2.3.1 | Fabricate STE FM 2 Detector Printed Wiring Board |  | 28d | 2003-08-29 A | 2003-10-09 A | 13 | 100% |  | 2003-02-03 | 2003-02-12 | 8d |  |  | start no earlier than 2003-08-29 | STEREO | IMPACT |  |  |  |  |  |
| 21 | 3.1.3.2.2.2 | Fabrication STE FM 1 Detector Printed Wiring Board |  | 28d | 2003-08-29 A | 2003-10-09 A | 13 | 100% |  | 2003-02-03 | 2003-02-12 | 8d |  |  | start no earlier than 2003-08-29 | STEREO | IMPACT |  |  |  |  |  |
| 22 | 8.1.2.2.2.1 | Fabricate STE-U FM 2 Shaper & Interface Printed Wiring Board |  | 10d | 2003-11-14 | 2003-11-28 | 13 |  |  | 2003-02-03 | 2003-02-14 | 10d | 44d | 0d | start no earlier than 2003-11-14 | STEREO | IMPACT |  |  |  |  |  |
| 23 | 8.1.2.2.1.1 | Fabricate STE-U FM 1Shaper & Interface Printed Wiring Board |  | 10d | 2003-11-14 | 2003-11-28 | 13 |  |  | 2003-02-03 | 2003-02-14 | 10d | 44d | 0d | start no earlier than 2003-11-14 | STEREO | IMPACT |  |  |  |  |  |
| 24 | 7.1.2.2.2.1 | Fabricate STE-U FM 2 Preamp Printed Wiring Board |  | 34d | 2003-09-22 A | 2003-11-07 A | 13 | 100% |  | 2003-07-01 | 2003-07-15 | 10d |  |  | start no earlier than 2003-09-22 | STEREO | IMPACT |  |  |  |  |  |
| 25 | 7.1.2.2.1.1 | Fabricate STE-U FM 1 Preamp Printed Wiring Board |  | 34d | 2003-09-22 A | 2003-11-07 A | 13 | 100% |  | 2003-07-01 | 2003-07-15 | 10d |  |  | start no earlier than 2003-09-22 | STEREO | IMPACT |  |  |  |  |  |
| 26 | 6.1.3.2.2.1 | Fabricate SWEA / STE-D FM 2 Digital to Analog Converter Printed Wiring Board |  | 10d | 2003-11-14 | 2003-11-28 | 13 |  |  | 2003-07-01 | 2003-07-15 | 10d | 29d | 0d | start no earlier than 2003-11-14 | STEREO | IMPACT |  |  |  |  |  |
| 27 | 6.1.3.2.1.1 | Fabricate SWEA / STE-D FM 1 Digital to Analog Converter Printed Wiring Board |  | 10d | 2003-11-14 | 2003-11-28 | 13 |  |  | 2003-07-01 | 2003-07-15 | 10d | 29d | 0d | start no earlier than 2003-11-14 | STEREO | IMPACT |  |  |  |  |  |
| 28 | 3.1.2.1.2.1 | Fabricate SWEA FM 2 Baseplate |  | 100d | 2003-07-01 A | 2003-11-21 | 13 | 86% | 14d | 2003-02-03 | 2003-02-24 | 15d | 75d | 24d | start no earlier than 2003-07-01 | STEREO | IMPACT |  |  |  |  |  |
| 29 | 3.1.2.1.1.1 | Fabricate SWEA FM 1 Baseplate |  | 100d | 2003-07-01 A | 2003-11-21 | 13 | 86% | 14d | 2003-02-03 | 2003-02-20 | 13d | 53d | 24d | start no earlier than 2003-07-01 | STEREO | IMPACT |  |  |  |  |  |
| 30 | 6.1.2.1.1 | Fabricate STE-D FM 2 Shaper Printed Wiring Board |  | 10d | 2003-11-14 | 2003-11-28 | 13 |  |  | 2003-07-01 | 2003-07-15 | 10d | 30d | 0d | start no earlier than 2003-11-14 | STEREO | IMPACT |  |  |  |  |  |
| 31 | 6.1.2.1.1 | Fabricate STE-D FM 1 Shaper Printed Wiring Board |  | 10d | 2003-11-14 | 2003-11-28 | 13 |  |  | 2003-07-01 | 2003-07-15 | 10d | 30d | 0d | start no earlier than 2003-11-14 | STEREO | IMPACT |  |  |  |  |  |
| 32 | 4.2.2.2.2.1 | Fabricate STE-D FM 2 Preamp Printed Wiring Board |  | 34d | 2003-09-22 A | 2003-11-07 A | 13 | 100% |  | 2003-07-01 | 2003-07-14 | 9d |  |  | start no earlier than 2003-09-22 | STEREO | IMPACT |  |  |  |  |  |
| 33 | 4.2.2.2.1.2 | Fabricate STE-D FM 1 Preamp Printed Wiring Board |  | 34d | 2003-09-22 A | 2003-11-07 A | 13 | 100% |  | 2003-07-01 | 2003-07-14 | 9d |  |  | start no earlier than 2003-09-22 | STEREO | IMPACT |  |  |  |  |  |
| 34 | 2.3.2.2.1 | SWEA FM 2 Mechanical Fabrication |  | 36d | 2002-12-02 A | 2003-01-31 A | 13FS+4d | 100% |  | 2002-12-02 | 2003-01-31 | 36d |  |  |  | STEREO | IMPACT |  |  |  |  |  |
| 35 | 2.3.2.1.2 | SWEA FM 1 Mechanical Fabrication |  | 36d | 2002-12-02 A | 2003-01-31 A | 13FS+4d | 100% |  | 2002-12-02 | 2003-01-31 | 36d |  |  |  | STEREO | IMPACT |  |  |  |  |  |
| 36 | 5.1.1.2.2 | Finalize HET Electronics Board Design |  | 13d | 2003-07-01 A | 2003-07-18 A | 13 | 100% |  | 2003-05-14 | 2003-05-28 | 10d |  |  | start no earlier than 2003-06-30 | STEREO | IMPACT |  |  |  |  |  |
| 37 | 1.1.1.6 | Receive RFAs From Instrument CDR | milestone | 0d | 2003-05-31 A | 2003-05-31 A | 13FS+10d | 100% |  | 2002-12-09 | 2002-12-09 | 0d |  |  | start no earlier than 2003-05-31 | STEREO | IMPACT |  |  |  |  |  |
| 38 | 1.1.36 | Instrument PER | milestone | 0d | 2003-12-03 | 2003-12-03 |  |  |  | 2003-08-25 | 2003-08-25 | 0d | 394.76d |  | start no earlier than 2003-12-03 | STEREO | IMPACT | UC-B | PER |  | IMPACT - Instrument PER |  |
| 39 | 1.1.37 | IMPACT Suite FM 1 EMC Testing Complete | milestone | 0d | 2004-05-28 | 2004-05-28 | 78 |  |  | 2004-05-07 | 2004-05-07 | 0d | 0d |  |  | STEREO | IMPACT |  |  |  | IMPACT - Suite FM 1 EMC Testing Complete |  |
| 40 | 3.2.1.6 | IDPU FM 1 Bakeout |  | 5d | 2004-06-01 | 2004-06-07 | 39 |  |  |  |  |  | 37d | 0d |  | STEREO | IMPACT |  |  |  |  |  |
| 41 | 1.1.2.27 | Receive SIT FM 1 back from IMPACT Suite EMC |  | 3d | 2004-06-01 | 2004-06-03 | 39 |  |  |  |  |  | 0d |  |  | STEREO | IMPACT |  |  |  |  |  |
| 42 | 9.2.8 | SWEA/STE-D FM 1 Thermal Vac/Thermal Balance |  | 14d | 2004-06-01 | 2004-06-18 | 39 |  |  |  |  |  | 1d |  |  | STEREO | IMPACT |  |  |  |  |  |
| 43 | 1.1.41 | Boom Suite FM 2 EMC Testing Complete | milestone | 0d | 2004-06-28 | 2004-06-28 | 80 |  |  | 2004-06-15 | 2004-06-15 | 0d | 250.76d |  |  | STEREO | IMPACT |  |  |  | Boom Suite - FM 2 EMC Testing Complete |  |
| 44 | 3.4.3.1 | FM 2 MAG Analog Board Build |  | 10d | 2003-11-11 | 2003-11-24 | 13 |  |  | 2003-05-28 | 2003-06-24 | 20d | 0d |  |  | STEREO | IMPACT |  |  |  |  |  |
| 45 | 3.4.2.1 | FM 1 MAG Analog Board Build |  | 10d | 2003-10-27 | 2003-11-07 | 13 |  |  | 2003-04-03 | 2003-04-29 | 19d | 0d |  |  | STEREO | IMPACT |  |  |  |  |  |
| 46 | 3.3.2.2.2 | FM 2 MAG PWB Fabrication |  | 28d | 2003-04-14 A | 2003-09-29 A | 13 | 100% |  | 2003-03-03 | 2003-03-12 | 8d |  |  | start no earlier than 2003-03-31 | STEREO | IMPACT |  |  |  |  |  |
| 47 | 3.3.2.1.3 | FM 1 MAG PWB Fabrication |  | 28d | 2003-04-14 A | 2003-09-29 A | 13 | 100% |  | 2003-03-03 | 2003-03-12 | 8d |  |  |  | STEREO | IMPACT |  |  |  |  |  |
| 48 | 3.3.2.2.1 | FM 2 MAG Sensor Build |  | 35d | 2003-04-01 A | 2003-05-19 A | 13 | 100% |  | 2003-02-03 | 2003-03-24 | 35d |  |  | start no earlier than 2003-03-31 | STEREO | IMPACT |  |  |  |  |  |
| 49 | 3.3.2.1.2 | FM 1 MAG Sensor Build |  | 35d | 2003-04-01 A | 2003-05-19 A | 13 | 100% |  | 2003-02-03 | 2003-03-24 | 35d |  |  | start no earlier than 2003-03-31 | STEREO | IMPACT |  |  |  |  |  |

Notes:
- 13: Removed activity 367 as predesessor need to watch this activity it drove CDR negative -0.15 days for 7/31 status. / Removed 4 days of slack for BOOM CDR Preparation as well as reducing duration for some of the BOOM CDR Preperation activities predecessors to hold date. / Removed BOOM CDR Prep -21.5d (8/31/02) status / Removed SIT 120 -17d (8/31/02) status driven by frontendlogic

| ID | WBS | Task | Type | Duration | Start | Finish | Predecessors | Complete | Remaining | Baseline start | Baseline finish | Baseline duration | Total slack | Free slack | Constraint | Text11 | Text12 | Text28 | Text13 | Text22 | Text18 | Text23 |
| --- | --- | --- | --- | --- | --- | --- | --- | --- | --- | --- | --- | --- | --- | --- | --- | --- | --- | --- | --- | --- | --- | --- |
| 50 | 1.1.48 | **Receivables** |  | 37d | 2004-04-28 | 2004-06-21 |  |  |  | 2004-04-08 | 2004-06-08 | 42d | 12d |  |  | STEREO | IMPACT | UC-B |  |  |  |  |
| 51 | 1.2.6.2.3 | Deliver BOOM Suite FM 1 For EMC Testing | milestone | 0d | 2004-04-27 | 2004-04-27 |  |  |  | 2004-04-01 | 2004-04-01 | 0d | 12d | 0d |  | STEREO | IMPACT |  |  |  |  |  |
| 52 | 1.1.48.2 | Receive BOOM Suite FM 1 For EMC Testing | milestone | 0d | 2004-04-28 | 2004-04-28 | 51FS+1d |  |  | 2004-04-08 | 2004-04-08 | 0d | 12d |  |  | STEREO | IMPACT | UC-B | Boom Suite |  |  |  |
| 53 | 1.2.6.3.3 | Deliver BOOM Suite FM 2 For EMC Testing | milestone | 0d | 2004-06-21 | 2004-06-21 |  |  |  | 2004-06-02 | 2004-06-02 | 0d | 13d | 0d |  | STEREO | IMPACT |  |  |  |  |  |
| 54 | 1.1.48.4 | Receive BOOM Suite FM 2 For EMC Testing | milestone | 0d | 2004-06-21 | 2004-06-21 | 53 |  |  | 2004-06-08 | 2004-06-08 | 0d | 13d | 0d |  | STEREO | IMPACT | UC-B | Boom Suite |  |  |  |
| 55 | 1.2.8.5 | Deliver SEP FM 1 to UC-B for EMC Testing | milestone | 0d | 2004-05-04 | 2004-05-04 |  |  |  | 2004-04-16 | 2004-04-16 | 0d | 7d | 0d |  | STEREO | IMPACT |  |  |  |  |  |
| 56 | 1.1.48.6 | Receive SEP Package FM 1 For EMC Testing | milestone | 0d | 2004-05-05 | 2004-05-05 | 55FS+1d |  |  | 2004-04-23 | 2004-04-23 | 0d | 7d |  |  | STEREO | IMPACT | UC-B | Boom Suite |  |  |  |
| 57 | 1.1.49 | **Deliverables** |  | 350d | 2003-02-07 A | 2004-06-28 |  |  | 350d | 2003-02-07 | 2004-06-15 | 340d | 14d |  |  | STEREO | IMPACT | UC-B |  |  |  |  |
| 58 | 1.1.49.1 | Deliver BOOM Suite FM 1 After EMC Testing | milestone | 0d | 2004-05-28 | 2004-05-28 | 78 |  |  | 2004-05-07 | 2004-05-07 | 0d | 34d | 0d |  | STEREO | IMPACT | UC-B | Boom Suite |  |  |  |
| 59 | 1.2.5.2.14 | Receive BOOM Suite FM 1 From IMPACT Suite EMC Testing | milestone | 0d | 2004-06-07 | 2004-06-07 | 58FS+5d |  |  | 2004-05-14 | 2004-05-14 | 0d | 34d | 0d |  | STEREO | IMPACT |  |  |  |  |  |
| 60 | 1.1.49.3 | Deliver BOOM Suite FM 2 After EMC Testing | milestone | 0d | 2004-06-28 | 2004-06-28 | 80 |  |  | 2004-06-15 | 2004-06-15 | 0d | 13d | 0d |  | STEREO | IMPACT | UC-B | Boom Suite | Deliver BOOM Suite FM 2 After EMC Testing |  |  |
| 61 | 1.2.5.3.10 | Receive BOOM Suite FM 2 From IMPACT Suite EMC Testing | milestone | 0d | 2004-07-06 | 2004-07-06 | 60FS+5d |  |  | 2004-06-16 | 2004-06-16 | 0d | 13d | 0d |  | STEREO | IMPACT |  |  |  |  |  |
| 62 | 1.1.49.5 | Deliver SEP Package FM 1 After EMC Testing | milestone | 0d | 2004-05-28 | 2004-05-28 | 78 |  |  | 2004-05-07 | 2004-05-07 | 0d | 13d | 0d |  | STEREO | IMPACT |  |  | Deliver SEP Package FM 1 After EMC Testing |  |  |
| 63 | 1.2.7.2 | Receive SEP Package FM 1 From IMPACT Suite EMC Testing | milestone | 0d | 2004-06-02 | 2004-06-02 | 62FS+2d |  |  | 2004-05-14 | 2004-05-14 | 0d | 13d | 0d |  | STEREO | IMPACT |  |  |  |  |  |
| 64 | 1.1.49.7 | Deliver Flight ACTELs for HET | milestone | 0d | 2003-02-07 A | 2003-02-07 A | 74 | 100% |  | 2003-02-07 | 2003-02-07 | 0d |  |  |  | STEREO | IMPACT | GSFC |  |  | ACTEL |  |
| 65 | 1.1.49.8 | Deliver Flight ACTELS for SIT | milestone | 0d | 2003-02-07 A | 2003-02-07 A | 74 | 100% |  | 2003-02-07 | 2003-02-07 | 0d |  |  |  | STEREO | IMPACT | GSFC |  |  | ACTEL |  |
| 66 | 1.1.49.9 | Deliver Flight ACTELS for LET | milestone | 0d | 2003-02-07 A | 2003-02-07 A | 74 | 100% |  | 2003-02-07 | 2003-02-07 | 0d |  |  |  | STEREO | IMPACT | GSFC |  |  | ACTEL |  |
| 67 | 1.1.49.10 | Deliver Flight ACTELS for SEP Central | milestone | 0d | 2003-02-07 A | 2003-02-07 A | 74 | 100% |  | 2003-02-07 | 2003-02-07 | 0d |  |  |  | STEREO | IMPACT | GSFC |  |  | ACTEL |  |
| 68 | 1.1.49.11 | Deliver Flight ACTELS for S/WAVES | milestone | 0d | 2003-02-07 A | 2003-02-07 A | 74 | 100% |  | 2003-02-07 | 2003-02-07 | 0d |  |  |  | STEREO | IMPACT | GSFC |  |  | ACTEL |  |
| 69 | 1.1.49.12 | Deliver Flight ACTELS for PLASTIC | milestone | 0d | 2003-02-07 A | 2003-02-07 A | 74 | 100% |  | 2003-02-07 | 2003-02-07 | 0d |  |  |  | STEREO | IMPACT | GSFC |  |  | ACTEL |  |
| 70 | 1.2 | **Flight ACTELs** |  | 108d | 2002-09-03 A | 2003-02-07 A |  | 100% |  | 2002-09-03 | 2003-02-07 | 108d |  |  |  | STEREO | IMPACT | GSFC |  |  |  |  |
| 71 | 1.2.1 | Order ACTELS |  | 3d | 2002-09-03 A | 2002-09-05 A |  | 100% |  | 2002-09-03 | 2002-09-05 | 3d |  |  | start no earlier than 2002-09-30 | STEREO | IMPACT | GSFC |  |  |  |  |
| 72 | 1.2.2 | Receive Flight ACTELs | milestone | 1d | 2003-01-20 A | 2003-01-20 A | 71FS+90d | 100% |  | 2003-01-20 | 2003-01-20 | 1d |  |  |  | STEREO | IMPACT | GSFC |  | IMPACT - Flight ACTEL Lot Buy Received |  | IMPACT - Flight ACTEL Lot Buy Received |
| 73 | 1.2.3 | Inspect Flight ACTELs |  | 1d | 2003-01-21 A | 2003-01-21 A | 72 | 100% |  | 2003-01-21 | 2003-01-21 | 1d |  |  |  | STEREO | IMPACT |  |  |  |  |  |
| 74 | 1.2.4 | DPA Flight ACTELs |  | 13d | 2003-01-22 A | 2003-02-07 A | 73 | 100% |  | 2003-01-22 | 2003-02-07 | 13d |  |  |  | STEREO | IMPACT |  |  | IMPACT - Flight ACTEL Lot DPA Complete |  | IMPACT - Flight ACTEL Lot DPA Complete |

| ID | WBS | Task | Duration | Start | Finish | Predecessors | Complete | Remaining | Baseline start | Baseline finish | Baseline duration | Total slack | Free slack | Constraint | Work | Actual work | Text11 | Text12 | Text28 | Text20 | Text21 | Text13 | Text14 |
| --- | --- | --- | --- | --- | --- | --- | --- | --- | --- | --- | --- | --- | --- | --- | --- | --- | --- | --- | --- | --- | --- | --- | --- |
| 75 | 2 | **Integration & Test** | 30d | 2004-05-17 | 2004-06-28 |  |  |  | 2004-04-26 | 2004-06-15 | 36d | 0d |  |  |  |  | STEREO | IMPACT | UC-B |  |  |  |  |
| 76 | 2.1 | **FM 1** | 30d | 2004-05-17 | 2004-06-28 |  |  |  | 2004-04-26 | 2004-06-15 | 36d | 0d |  |  |  |  | STEREO | IMPACT | UC-B |  |  |  |  |
| 77 | 2.1.1 | **Suite** | 10d | 2004-05-17 | 2004-05-28 |  |  |  | 2004-04-26 | 2004-05-07 | 10d | 0d |  |  |  |  | STEREO | IMPACT | UC-B |  |  |  |  |
| 78 | 2.1.1.1 | IMPACT Suite FM 1 EMC Testing | 10d | 2004-05-17 | 2004-05-28 | 52, 56 |  |  | 2004-04-26 | 2004-05-07 | 10d | 0d |  | must start on 2004-05-17 |  |  | STEREO | IMPACT | UC-B | EMC | EMC |  |  |
| 79 | 2.1.2 | **FM 2** | 5d | 2004-06-22 | 2004-06-28 |  |  |  | 2004-05-10 | 2004-06-15 | 26d | 13d |  |  |  |  | STEREO | IMPACT |  |  |  |  |  |
| 80 | 2.1.2.1 | Boom Suite FM 2 EMC Testing | 5d | 2004-06-22 | 2004-06-28 | 54, 78 |  |  | 2004-06-09 | 2004-06-15 | 5d | 13d | 0d |  |  |  | STEREO | IMPACT |  |  |  | SEP Package |  |
| 81 | 3 | IMPACT Data Processing Unit | 1150d | 2000-01-01 A | 2004-07-29 |  | 88% | 140.65d | 2000-01-01 | 2004-06-04 | 1112d | 228.76d |  |  |  |  | STEREO | IMPACT |  |  |  |  |  |
| 82 | 4 | IMPACT Power Converters | 927d | 2000-07-31 A | 2004-04-09 |  | 71% | 267.97d | 2000-07-31 | 2004-01-09 | 864d | 305.76d |  |  |  |  | STEREO | IMPACT |  |  |  |  | PS |
| 83 | 5 | IMPACT BOOM | 1080d | 2000-05-26 A | 2004-09-14 |  | 76% | 261.33d | 2000-01-03 | 2004-09-15 | 1183d | 196.76d |  |  |  |  | STEREO | IMPACT | UC-B |  |  | Boom Suite |  |
| 84 | 6 | IMPACT SEP | 1207.76d? | 2000-09-05 A | 2005-06-28 |  | 69% | 369.53d? | 2000-09-05 | 2005-09-16 | 1264d? | 0d |  |  | 8673.6h | 8673.6h | STEREO | IMPACT | CIT |  |  |  |  |
