# PC - Power Converters

Schedule from MS Project, 2000-07-31 to 2004-04-09, status date 2003-10-31, A marks actual dates.
Common Power Converters Development Schedule
NASA GSFC
Status Date: 10/31/2003 / Baseline Date: 01/31/2003 R1

## Calendars

- Standard w/ 10 Gov't Holidays: Mon-Fri 08:00-12:00, 13:00-17:00; Sat-Sun off. Exceptions (off unless hours are given): 2000-09-04, 2000-10-09, 2000-11-13, 2000-11-23, 2000-12-25, 2001-01-01, 2001-01-15, 2001-02-19, 2001-05-28, 2001-07-04, 2001-09-03, 2001-10-08, 2001-11-12, 2001-11-22, 2001-12-25, 2002-01-01, 2002-01-14, 2002-02-18, 2002-05-27, 2002-07-04, 2002-09-02, 2002-10-07, 2002-11-11, 2002-11-28, 2002-12-25, 2003-01-01, 2003-01-13, 2003-02-17, 2003-05-26, 2003-07-04, 2003-09-01, 2003-10-06, 2003-11-10, 2003-11-27, 2003-12-25, 2004-01-01, 2004-01-12, 2004-02-16.

## Schedule

| ID | WBS | Task | Type | Duration | Start | Finish | Predecessors | Complete | Remaining | Baseline start | Baseline finish | Baseline duration | Total slack | Free slack | Constraint | Text11 | Text12 | Text28 | Text13 | Text14 | Text15 | Text16 | Text17 |
| --- | --- | --- | --- | --- | --- | --- | --- | --- | --- | --- | --- | --- | --- | --- | --- | --- | --- | --- | --- | --- | --- | --- | --- |
| 1 | 1 | **Management** |  | 927d | 2000-07-31 A | 2004-04-09 |  | 99% | 0d | 2000-07-31 | 2004-03-08 | 903d | 0d |  |  | STEREO | IMPACT | UC-B |  |  |  |  |  |
| 2 | 1.1 | **Milestones** |  | 927d | 2000-07-31 A | 2004-04-09 |  | 99% | 0d | 2000-07-31 | 2004-03-08 | 903d | 0d |  |  | STEREO | IMPACT | UC-B |  |  |  |  |  |
| 3 | 1.1.1 | **Contingency Blocks** |  | 382d | 2002-10-01 A | 2004-04-09 |  | 99% | 0d | 2002-10-01 | 2004-03-08 | 358d | 0d |  |  | STEREO | IMPACT | UC-B |  |  |  |  |  |
| 4 | 1.1.1.1 | IDPU ETU LVPS Contingency |  | 1d | 2003-02-05 A | 2003-02-05 A | 159 | 100% |  | 2003-02-05 | 2003-02-05 | 1d |  |  |  | STEREO | IMPACT | UC-B | IDPU | PS | LVPS Card | IDPU | LVPS |
| 5 | 1.1.1.2 | IDPU FM 1 LVPS Contingency | milestone | 0d | 2004-02-11 | 2004-02-11 | 179 |  |  | 2004-01-05 | 2004-01-05 | 0d | 28d | 0d |  | STEREO | IMPACT | UC-B | IDPU | PS | LVPS Card | IDPU | LVPS |
| 6 | 1.1.1.3 | IDPU FM 2 LVPS Contingency | milestone | 0d | 2004-04-08 | 2004-04-08 | 190 |  |  | 2004-03-03 | 2004-03-03 | 0d | 1d | 0d |  | STEREO | IMPACT | UC-B | IDPU | PS | LVPS Card | IDPU | LVPS |
| 7 | 1.1.1.4 | SEP ETU LVPS Contingency | milestone | 0d | 2003-09-12 A | 2003-09-12 A | 160 | 100% |  | 2003-09-12 | 2003-09-12 | 0d |  |  |  | STEREO | IMPACT | UC-B | SEP Package | PS | LVPS Card | SEP DPU | LVPS |
| 8 | 1.1.1.5 | SEP FM 1 LVPS Contingency | milestone | 0d | 2004-02-06 | 2004-02-06 | 180 |  |  | 2004-01-08 | 2004-01-08 | 0d | 35d | 0d |  | STEREO | IMPACT | UC-B | SEP Package | PS | LVPS Card | SEP DPU | LVPS |
| 9 | 1.1.1.6 | SEP FM 2 LVPS Contingency | milestone | 0d | 2004-04-05 | 2004-04-05 | 194 |  |  | 2004-03-08 | 2004-03-08 | 0d | 4d | 0d |  | STEREO | IMPACT | UC-B | SEP Package | PS | LVPS Card | SEP DPU | LVPS |
| 10 | 1.1.1.7 | SWEA/STE-D ETU LVPS Contingency | milestone | 0d | 2003-05-14 A | 2003-05-14 A | 161 | 100% |  | 2003-05-14 | 2003-05-14 | 0d |  |  | start no earlier than 2003-05-31 | STEREO | IMPACT | UC-B | Boom Suite | PS | LVPS Card | SWEA/STE-D | LVPS |
| 11 | 1.1.1.8 | SWEA/STE-D FM 1 LVPS Contingency | milestone | 0d | 2004-02-12 | 2004-02-12 | 181 |  |  | 2003-12-30 | 2003-12-30 | 0d | 18d | 0d |  | STEREO | IMPACT | UC-B | Boom Suite | PS | LVPS Card | SWEA/STE-D | LVPS |
| 12 | 1.1.1.9 | SWEA/STE-D FM 2 LVPS Contingency | milestone | 0d | 2004-04-09 | 2004-04-09 | 198 |  |  | 2004-02-27 | 2004-02-27 | 0d | 0d |  |  | STEREO | IMPACT | UC-B | Boom Suite | PS | LVPS Card | SWEA/STE-D | LVPS |
| 13 | 1.1.1.10 | PLASTIC ETU LVPS Contingency | milestone | 0d | 2003-07-08 A | 2003-07-08 A | 162 | 100% |  | 2003-07-08 | 2003-07-08 | 0d |  |  | start no earlier than 2003-06-30 | STEREO | PLASTIC | UC-B | PLASTIC | PS | LVPS Card |  | LVPS |
| 14 | 1.1.1.11 | PLASTIC FM 1 LVPS Contingency | milestone | 0d | 2004-01-29 | 2004-01-29 | 182 |  |  | 2003-12-11 | 2003-12-11 | 0d | 50d | 0d |  | STEREO | PLASTIC | UC-B | PLASTIC | PS | LVPS Card |  | LVPS |
| 15 | 1.1.1.12 | PLASTIC FM 2 LVPS Contingency | milestone | 0d | 2004-03-25 | 2004-03-25 | 202 |  |  | 2004-02-09 | 2004-02-09 | 0d | 11d | 0d |  | STEREO | PLASTIC | UC-B | PLASTIC | PS | LVPS Card |  | LVPS |
| 16 | 1.1.1.13 | SIT ETU HVPS Contingency | milestone | 0d | 2002-10-01 A | 2002-10-01 A | 163 | 100% |  | 2002-10-01 | 2002-10-01 | 0d |  |  | start no earlier than 2002-09-30 | STEREO | IMPACT | UC-B | SEP Package | PS | HVPS Card | SIT | HVPS |
| 17 | 1.1.1.14 | SIT FM 1 HVPS Contingency | milestone | 0d | 2003-11-28 | 2003-11-28 | 183 |  |  | 2003-09-23 | 2003-09-23 | 0d | 20d | 0d |  | STEREO | IMPACT | UC-B | SEP Package | PS | HVPS Card | SIT | HVPS |
| 18 | 1.1.1.15 | SIT FM 2 HVPS Contingency | milestone | 0d | 2004-01-27 | 2004-01-27 | 204 |  |  | 2003-11-28 | 2003-11-28 | 0d | 20d | 0d |  | STEREO | IMPACT | UC-B | SEP Package | PS | HVPS Card | SIT | HVPS |
| 19 | 1.1.2 | **Receivables** |  | 285d | 2002-10-17 A | 2003-12-05 |  | 99% | 0d | 2002-10-17 | 2003-09-30 | 240d | 20d |  |  | STEREO | IMPACT | UC-B |  |  |  |  |  |
| 20 | 1.1.3.1 | Deliver SIT ETU/SIT HVPS ETU I/F Test Results to UC-B |  | 1d | 2002-10-16 A | 2002-10-16 A |  | 100% |  | 2002-10-16 | 2002-10-16 | 1d |  |  |  | STEREO | IMPACT |  |  |  |  |  |  |
| 21 | 1.1.2.2 | Receive SIT HVPS ETU/SIT ETU I/F Test Results from UMD | milestone | 0d | 2002-10-17 A | 2002-10-17 A | 20 | 100% |  | 2002-10-17 | 2002-10-17 | 0d |  |  |  | STEREO | IMPACT |  |  |  |  |  |  |
| 22 | 1.1.5.18 | Deliver IDPU ETU/IDPU LVPS I/F Test Results |  | 1d | 2003-02-10 A | 2003-02-10 A |  | 100% |  | 2003-02-10 | 2003-02-10 | 1d |  |  |  | STEREO | IMPACT |  |  |  |  |  |  |
| 23 | 1.1.2.4 | Receive IDPU LVPS ETU/IDPU ETU I/F Test Results |  | 1d | 2003-02-14 A | 2003-02-14 A | 22 | 100% |  | 2003-02-14 | 2003-02-14 | 1d |  |  |  | STEREO | IMPACT |  |  |  |  |  |  |
| 24 | 1.1.8.6 | Deliver SEP ETU LVPS Test Feedback to UC-B | milestone | 0d | 2003-09-26 A | 2003-09-26 A |  | 100% |  | 2003-09-23 | 2003-09-23 | 0d |  |  |  | STEREO | IMPACT |  |  |  |  |  |  |
| 25 | 1.1.2.6 | Receive SEP LVPS ETU/SEP Central ETU I/F Test Results | milestone | 0d | 2003-09-26 A | 2003-09-26 A | 24 | 100% |  | 2003-09-23 | 2003-09-23 | 0d |  |  |  | STEREO | IMPACT |  |  |  |  |  |  |
| 26 | 1.1.3.17 | Deliver SWEA/STE-D ETU/SWEA LVPS ETU I/F Test Results | milestone | 0d | 2003-07-02 A | 2003-07-02 A |  | 100% |  | 2003-07-02 | 2003-07-02 | 0d |  |  |  | STEREO | IMPACT |  |  |  |  |  |  |
| 27 | 1.1.2.8 | Receive SWEA LVPS ETU/SWEA I/F Test Results | milestone | 0d | 2003-07-14 A | 2003-07-14 A | 26 | 100% |  | 2003-07-14 | 2003-07-14 | 0d |  |  |  | STEREO | IMPACT |  |  |  |  |  |  |
| 28 | 1.1.2.9 | Receive PLASTIC LVPS ETU/PLASTIC ETU I/F Test Results | milestone | 0d | 2003-10-03 A | 2003-10-03 A |  | 100% |  | 2003-09-15 | 2003-09-15 | 0d |  |  | start no earlier than 2003-10-03 | STEREO | IMPACT |  |  |  |  |  |  |
| 29 | 1.1.3.2 | Deliver SIT ETU / SIT HVPS FM 1 I/F Test Results to UC-B | milestone | 0d | 2003-12-05 | 2003-12-05 |  |  |  | 2003-09-30 | 2003-09-30 | 0d | 20d | 0d |  | STEREO | IMPACT |  |  |  |  |  |  |
| 30 | 1.1.2.11 | Receive SIT HVPS FM 1/SIT ETU I/F Test Results from UMD | milestone | 0d | 2003-12-05 | 2003-12-05 | 29 |  |  | 2003-09-30 | 2003-09-30 | 0d | 20d | 0d |  | STEREO | IMPACT |  |  |  |  |  |  |

Notes:
- 5: March 03 Status - Removed 17 days of contingency. Dropped from 90 to 73 days.
- 6: March 03 Status - Removed 17 days of contingency. Dropped from 89 to 72 days.
- 8: March 03 Status - Removed 18 days of contingency. Dropped it to 1 day.
- 9: March 03 Status - Removed 4 days of contingency.
- 11: March 03 Status - Removed 16 days of contingency. Dropped from 34 to 18 days.
- 12: March 03 Status - Removed 16 days of contingency. Dropped from 33 to 17 days.
- 13: Mar 03 status - Removed 8 days duration. Check with Dave Curtis.
- 28: Created arbitrary date of 6/27/03 based on e-mail in January from Kevin Milligan stating the PLASTIC EM testing was going to occur the week of 6/16. I've assumed that the test is 1 week and than a week to report the results.

| ID | WBS | Task | Type | Duration | Start | Finish | Predecessors | Complete | Remaining | Baseline start | Baseline finish | Baseline duration | Total slack | Free slack | Constraint | Text11 | Text12 | Text28 | Text14 | Text15 | Text16 | Text13 | Text17 | Text20 | Text21 | Text22 | Text23 |
| --- | --- | --- | --- | --- | --- | --- | --- | --- | --- | --- | --- | --- | --- | --- | --- | --- | --- | --- | --- | --- | --- | --- | --- | --- | --- | --- | --- |
| 31 | 1.1.3 | **Deliverables** |  | 927d | 2000-07-31 A | 2004-04-09 |  | 99% | 0d | 2000-07-31 | 2004-03-08 | 903d | 0d |  |  | STEREO | IMPACT | UC-B |  |  |  |  |  |  |  |  |  |
| 32 | 1.1.3.1 | Deliver Draft LVPS Requirements | milestone | 0d | 2000-07-31 A | 2000-07-31 A |  | 100% |  | 2000-07-31 | 2000-07-31 | 0d |  |  | finish no earlier than 2000-07-31 | STEREO | IMPACT | UC-B | PS | LVPS Card | LVPS |  |  |  |  |  |  |
| 33 | 1.1.3.2 | Deliver Final (Frozen) LVPS Requirements | milestone | 0d | 2001-12-15 A | 2001-12-15 A |  | 100% |  | 2001-12-15 | 2001-12-15 | 0d |  |  | finish no earlier than 2001-12-15 | STEREO | IMPACT | UC-B | PS | LVPS Card | LVPS |  |  |  |  |  |  |
| 34 | 1.1.3.3 | **ETU** |  | 243d | 2002-10-01 A | 2003-09-19 A |  | 100% |  | 2002-10-01 | 2003-09-15 | 240d |  |  |  | STEREO | IMPACT |  |  |  |  |  |  |  |  |  |  |
| 35 | 1.1.3.3.1 | Deliver IDPU ETU LVPS |  | 1d | 2003-02-05 A | 2003-02-05 A | 4 | 100% |  | 2003-02-05 | 2003-02-05 | 1d |  |  | finish no later than 2003-02-10 | STEREO | IMPACT | UC-B | PS | LVPS Card | IDPU | Boom Suite | LVPS | IDPU ETU LVPS | ETU IDPU LVPS | IDPU - ETU LVPS Available | IDPU ETU LVPS Delivered |
| 36 | 1.1.4.2 | Receive ETU IDPU LVPS From UC-B | milestone | 0d | 2003-02-05 A | 2003-02-05 A | 35 | 100% |  | 2003-02-05 | 2003-02-05 | 0d |  |  |  | STEREO | IMPACT |  |  |  |  |  |  |  |  |  |  |
| 37 | 1.1.3.3.3 | Deliver SEP ETU LVPS to CIT | milestone | 0d | 2003-09-19 A | 2003-09-19 A | 7FS+1d | 100% |  | 2003-09-15 | 2003-09-15 | 0d |  |  | start no earlier than 2003-09-19 | STEREO | IMPACT | UC-B | PS | LVPS Card | SEP DPU | SEP Package | LVPS | SEP ETU LVPS | ETU SEP LVPS | SEP - ETU LVPS Available | SEP ETU LVPS Delivered |
| 38 | 1.1.7.4.2 | Receive SEP LVPS ETU From UC-B | milestone | 0d | 2003-09-19 A | 2003-09-19 A | 37 | 100% |  | 2003-09-15 | 2003-09-15 | 0d |  |  |  | STEREO | IMPACT |  |  |  |  |  |  |  |  |  |  |
| 39 | 2.1.11 | LVPS Compatibility Test |  | 5d | 2003-09-22 A | 2003-09-26 | 37 | 80% | 1d | 2003-09-17 | 2003-09-23 | 5d | 97d | 10d |  | STEREO | IMPACT |  |  |  |  |  |  |  |  |  |  |
| 40 | 1.1.3.3.6 | Deliver SWEA/STE-D ETU LVPS | milestone | 0d | 2003-05-14 A | 2003-05-14 A | 10 | 100% |  | 2003-05-14 | 2003-05-14 | 0d |  |  | start no earlier than 2003-05-31 | STEREO | IMPACT | UC-B | PS | LVPS Card | SWEA/STE-D | Boom Suite | LVPS | SWEA ETU LVPS | ETU SWEA/STE LVPS | SWEA/STE-D - ETU LVPS Available | SWEA/STE-D ETU LVPS Delivered |
| 41 | 1.1.2.8 | Receive SWEA/STE-D ETU LVPS From UC-B | milestone | 0d | 2003-05-14 A | 2003-05-14 A | 40 | 100% |  | 2003-05-14 | 2003-05-14 | 0d |  |  |  | STEREO | IMPACT |  |  |  |  |  |  |  |  |  |  |
| 42 | 1.1.3.3.8 | Deliver PLASTIC ETU LVPS | milestone | 0d | 2003-07-08 A | 2003-07-08 A | 13 | 100% |  | 2003-07-08 | 2003-07-08 | 0d |  |  | finish no later than 2003-06-09 | STEREO | PLASTIC | UC-B | PS | LVPS Card |  | PLASTIC |  |  | ETU PLASTIC LVPS to UNH | PLASTIC - ETU LVPS Available | PLASTIC ETU LVPS Delivered |
| 43 | 1.1.3.3.9 | Deliver SIT ETU HVPS | milestone | 0d | 2002-10-01 A | 2002-10-01 A | 16 | 100% |  | 2002-10-01 | 2002-10-01 | 0d |  |  | start no earlier than 2002-09-30 | STEREO | IMPACT | UC-B | PS | HVPS Card | SIT | SEP Package | HVPS |  | ETU SIT HVPS | SIT - ETU HVPS Available | SIT ETU HVPS Delivered |
| 44 | 1.1.3.3.10 | IMPACT Suite ETU Power Supplies Complete | milestone | 0d | 2003-09-19 A | 2003-09-19 A | 35, 37, 40, 43 | 100% |  | 2003-09-15 | 2003-09-15 | 0d |  |  |  | STEREO | IMPACT |  |  |  |  |  |  |  |  |  |  |
| 45 | 1.1.2.9 | Receive ETU HVPS From UC-B |  | 1d | 2002-10-01 A | 2002-10-01 A | 43 | 100% |  | 2002-10-01 | 2002-10-01 | 1d |  |  | start no earlier than 2002-09-30 | STEREO | IMPACT |  |  |  |  |  |  |  |  |  |  |
| 46 | 1.1.3.4 | **FM 1** |  | 51d | 2003-11-28 | 2004-02-12 |  |  |  | 2003-09-23 | 2004-01-08 | 72d | 20d |  |  | STEREO | IMPACT |  |  |  |  |  |  |  |  |  |  |
| 47 | 1.1.3.4.1 | FM 1 Power Supplies Complete | milestone | 0d | 2004-02-12 | 2004-02-12 | 48, 50, 52, 54, 55 |  |  | 2004-01-08 | 2004-01-08 | 0d | 40d |  |  | STEREO | IMPACT |  | PS |  |  |  |  | FM 1 PWR Supplies | FM 1 Pwr Supplies / Bar 3 FM 1 Power Supplies | IMPACT - FM 1 Power Supplies Complete | FM 1 Power Supplies Complete |
| 48 | 1.1.3.4.2 | Deliver IDPU FM 1 LVPS | milestone | 0d | 2004-02-11 | 2004-02-11 | 5 |  |  | 2004-01-05 | 2004-01-05 | 0d | 28d | 0d |  | STEREO | IMPACT | UC-B | PS | LVPS Card | IDPU | Boom Suite | LVPS | IDPU FM 1 LVPS | FM1 Power Supplies |  | IDPU FM 1 LVPS Delivered |
| 49 | 1.1.4.4 | Receive FM 1 IDPU LVPS From UC-B | milestone | 0d | 2004-02-11 | 2004-02-11 | 48 |  |  | 2004-01-05 | 2004-01-05 | 0d | 28d | 0d |  | STEREO | IMPACT |  |  |  |  |  |  |  |  |  |  |
| 50 | 1.1.3.4.4 | Deliver SEP FM 1 LVPS to CIT | milestone | 0d | 2004-02-06 | 2004-02-06 | 8 |  |  | 2004-01-08 | 2004-01-08 | 0d | 35d | 0d |  | STEREO | IMPACT | UC-B | PS | LVPS Card | SEP DPU | SEP Package | LVPS | SEP FM 1 LVPS | FM1 Power Supplies |  | SEP FM 1 LVPS Delivered |
| 51 | 1.1.7.4.4 | Receive SEP LVPS FM 1 From UC-B | milestone | 0d | 2004-02-06 | 2004-02-06 | 50 |  |  | 2004-01-08 | 2004-01-08 | 0d | 35d | 0d |  | STEREO | IMPACT |  |  |  |  |  |  |  |  |  |  |
| 52 | 1.1.3.4.6 | Deliver SWEA/STE-D FM 1 LVPS | milestone | 0d | 2004-02-12 | 2004-02-12 | 11 |  |  | 2003-12-30 | 2003-12-30 | 0d | 18d | 0d |  | STEREO | IMPACT | UC-B | PS | LVPS Card | SWEA/STE-D | Boom Suite | LVPS | SWEA FM 1 LVPS | FM1 Power Supplies |  | SWEA/STE-D FM 1 LVPS Delivered |
| 53 | 1.1.2.10 | Receive SWEA/STE-D FM 1 LVPS From UC-B | milestone | 0d | 2004-02-12 | 2004-02-12 | 52 |  |  | 2003-12-30 | 2003-12-30 | 0d | 18d | 0d |  | STEREO | IMPACT |  |  |  |  |  |  |  |  |  |  |
| 54 | 1.1.3.4.8 | Deliver PLASTIC FM 1 LVPS | milestone | 0d | 2004-01-29 | 2004-01-29 | 14 |  |  | 2003-12-11 | 2003-12-11 | 0d | 50d | 10d |  | STEREO | PLASTIC | UC-B | PS | LVPS Card |  | PLASTIC |  |  | FM1 Power Supplies |  | PLASTIC FM 1 LVPS Delivered |
| 55 | 1.1.3.4.9 | Deliver SIT FM 1 HVPS | milestone | 0d | 2003-11-28 | 2003-11-28 | 17 |  |  | 2003-09-23 | 2003-09-23 | 0d | 20d | 0d |  | STEREO | IMPACT | UC-B | PS | HVPS Card | SIT | SEP Package | HVPS |  | FM 2 Power Supplies |  | SIT FM 1 HVPS Delivered |
| 56 | 1.1.2.11 | Receive FM 1 HVPS From UC-B | milestone | 0d | 2003-11-28 | 2003-11-28 | 55 |  |  | 2003-09-23 | 2003-09-23 | 0d | 20d | 0d |  | STEREO | IMPACT |  |  |  |  |  |  |  |  |  |  |

Notes:
- 37: Changed Delivery date from 10/8/02 to 3/31/03 based on comment from CIT, 1/8/03 / 2003 May Status - Delivery date moved to 7/21/03
- 40: FNL of 8/31/02 removed 1/9/03
- 42: FNL of 11/1/02 removed 1/9/03
- 43: This activity at one time was a critical milestone however with the new way Tom Parr wants to do the chart it can't remain tagged as critical, therfore for historical purposes Bob Palfy created this note.
- 47: FNL of 6/3/03 removed 1/9/03
- 48: FNL of 6/3/03 removed 1/9/03
- 50: FNL of 6/3/03 removed 1/9/03
- 52: FNL of 6/3/03 removed 1/9/03
- 54: FNL of 6/3/03 removed 1/9/03
- 55: FNL of 6/3/03 removed 1/9/03

| ID | WBS | Task | Type | Duration | Start | Finish | Predecessors | Complete | Remaining | Baseline start | Baseline finish | Baseline duration | Total slack | Free slack | Constraint | Text11 | Text12 | Text14 | Text20 | Text21 | Text22 | Text23 | Text13 | Text15 | Text16 | Text17 | Text28 |
| --- | --- | --- | --- | --- | --- | --- | --- | --- | --- | --- | --- | --- | --- | --- | --- | --- | --- | --- | --- | --- | --- | --- | --- | --- | --- | --- | --- |
| 57 | 1.1.3.5 | **FM 2** |  | 52d | 2004-01-27 | 2004-04-09 |  |  |  | 2003-11-28 | 2004-03-08 | 67d | 0d |  |  | STEREO | IMPACT |  |  |  |  |  |  |  |  |  |  |
| 58 | 1.1.3.5.1 | FM 2 Power Supplies Complete | milestone | 0d | 2004-04-09 | 2004-04-09 | 59, 61, 63, 65, 66 |  |  | 2004-03-08 | 2004-03-08 | 0d | 0d |  |  | STEREO | IMPACT | PS | FM 2 PWR Supplies | FM 2 Pwr Supplies / Bar 3 FM 2 Power Supplies | IMPACT - FM 2 Power Supplies Complete | FM 2 Power Supplies Complete |  |  |  |  |  |
| 59 | 1.1.3.5.2 | Deliver IDPU FM 2 LVPS | milestone | 0d | 2004-04-08 | 2004-04-08 | 6 |  |  | 2004-03-03 | 2004-03-03 | 0d | 1d | 0d |  | STEREO | IMPACT | PS | IDPU FM 2 LVPS | FM2 Power Supplies |  | IDPU FM 2 LVPS Delivered | Boom Suite | LVPS Card | IDPU | LVPS | UC-B |
| 60 | 1.1.4.6 | Receive FM 2 IDPU LVPS From UC-B | milestone | 0d | 2004-04-08 | 2004-04-08 | 59 |  |  | 2004-03-03 | 2004-03-03 | 0d | 27d | 0d |  | STEREO | IMPACT |  |  |  |  |  |  |  |  |  |  |
| 61 | 1.1.3.5.4 | Deliver SEP FM 2 LVPS to CIT | milestone | 0d | 2004-04-05 | 2004-04-05 | 9 |  |  | 2004-03-08 | 2004-03-08 | 0d | 4d | 0d |  | STEREO | IMPACT | PS | SEP FM 2 LVPS | FM2 Power Supplies |  | SEP FM 2 LVPS Delivered | SEP Package | LVPS Card | SEP DPU | LVPS | UC-B |
| 62 | 1.1.7.4.6 | Receive SEP LVPS FM 2 From UC-B | milestone | 0d | 2004-04-05 | 2004-04-05 | 61 |  |  | 2004-03-08 | 2004-03-08 | 0d | 24d | 0d |  | STEREO | IMPACT |  |  |  |  |  |  |  |  |  |  |
| 63 | 1.1.3.5.6 | Deliver SWEA/STE-D FM 2 LVPS | milestone | 0d | 2004-04-09 | 2004-04-09 | 12 |  |  | 2004-02-27 | 2004-02-27 | 0d | 0d |  |  | STEREO | IMPACT | PS | SWEA FM 2 LVPS | FM2 Power Supplies |  | SWEA/STE-D FM 2 LVPS Delivered | Boom Suite | LVPS Card | SWEA/STE-D | LVPS | UC-B |
| 64 | 1.1.2.12 | Receive SWEA/STE-D FM 2 LVPS From UC-B | milestone | 0d | 2004-04-09 | 2004-04-09 | 63 |  |  | 2004-02-27 | 2004-02-27 | 0d | 0d |  |  | STEREO | IMPACT |  |  |  |  |  |  |  |  |  |  |
| 65 | 1.1.3.5.8 | Deliver PLASTIC FM 2 LVPS | milestone | 0d | 2004-03-25 | 2004-03-25 | 15 |  |  | 2004-02-09 | 2004-02-09 | 0d | 11d |  |  | STEREO | PLASTIC | PS |  | FM2 Power Supplies |  | PLASTIC FM 2 LVPS Delivered | PLASTIC | LVPS Card |  |  | UC-B |
| 66 | 1.1.3.5.9 | Deliver SIT FM 2 HVPS | milestone | 0d | 2004-01-27 | 2004-01-27 | 18 |  |  | 2003-11-28 | 2003-11-28 | 0d | 20d | 0d |  | STEREO | IMPACT | PS |  | FM2 Power Supplies |  | SIT FM 2 HVPS Delivered | SEP Package | HVPS Card | SIT | HVPS | UC-B |
| 67 | 1.1.2.13 | Receive FM 2 HVPS From UC-B | milestone | 0d | 2004-01-27 | 2004-01-27 | 66 |  |  | 2003-11-28 | 2003-11-28 | 0d | 20d | 0d |  | STEREO | IMPACT |  |  |  |  |  |  |  |  |  |  |
| 68 | 2 | **Power** |  | 927d | 2000-07-31 A | 2004-04-09 |  | 71% | 268.37d | 2000-07-31 | 2004-03-08 | 903d | 0d |  |  | STEREO | IMPACT | PS |  |  |  |  |  |  |  |  | UC-B |
| 69 | 2.1 | **Design, Manufacture, Assembly and Test** |  | 927d | 2000-07-31 A | 2004-04-09 |  | 71% | 268.37d | 2000-07-31 | 2004-03-08 | 903d | 0d |  |  | STEREO | IMPACT | PS |  |  |  |  |  |  |  |  | UC-B |
| 70 | 2.1.1 | **Procurements** |  | 492d | 2001-12-19 A | 2003-12-04 |  | 92% | 41.28d | 2001-12-19 | 2003-10-22 | 463d | 1d |  |  | STEREO | IMPACT | PS |  |  |  |  |  |  |  |  | UC-B |
| 71 | 2.1.1.1 | **ETU** |  | 135d | 2001-12-19 A | 2002-07-02 A |  | 100% |  | 2001-12-19 | 2002-07-02 | 135d |  |  |  | STEREO | IMPACT | PS |  |  |  |  |  |  |  |  | UC-B |
| 72 | 2.1.1.1.1 | Procure ETU Parts |  | 66d | 2001-12-19 A | 2002-03-26 A | 86 | 100% |  | 2001-12-19 | 2002-03-26 | 66d |  |  |  | STEREO | IMPACT | PS |  |  |  |  |  | LVPS Card |  |  | UC-B |
| 73 | 2.1.1.1.2 | Procure HVPS Printed Wiring Boards |  | 9.55d | 2002-06-19 A | 2002-07-02 A | 118 | 100% |  | 2002-06-19 | 2002-07-02 | 9.55d |  |  | start no earlier than 2002-05-31 | STEREO | IMPACT | PS |  |  |  |  |  | HVPS Card |  |  | UC-B |
| 74 | 2.1.1.2 | **FM 1 & FM 2** |  | 337d | 2002-08-01 A | 2003-12-04 |  | 89% | 35.85d | 2002-08-01 | 2003-10-22 | 308d | 1d |  |  | STEREO | IMPACT | PS |  |  |  |  |  |  |  |  | UC-B |
| 75 | 2.1.1.2.1 | Procure LVPS Flight Long Lead Parts (and Screen) |  | 139d | 2002-08-01 A | 2003-07-07 A | 72 | 100% |  | 2002-08-01 | 2003-07-07 | 139d |  |  | finish no earlier than 2003-06-17 | STEREO | IMPACT | PS |  |  |  |  |  |  |  |  | UC-B |
| 76 | 2.1.1.2.2 | Procure HVPS Flight Long Lead Parts (and Screen) |  | 93d | 2002-08-01 A | 2002-12-13 A | 72 | 100% |  | 2002-08-01 | 2002-12-13 | 93d |  |  |  | STEREO | IMPACT |  |  |  |  |  |  |  |  |  |  |
| 77 | 2.1.1.2.3 | Procure SIT HVPS Flight Printed Wire Board |  | 10d | 2003-04-01 A | 2003-04-14 A | 125 | 100% |  | 2003-04-01 | 2003-04-14 | 10d |  |  | start no earlier than 2003-03-31 | STEREO | IMPACT | PS |  |  |  | SIT Flight HVPS Printed Wiring Boards Ordered |  |  |  |  | UC-B |
| 78 | 2.1.1.2.4 | Procure IDPU Flight Printed Wiring Board |  | 10d | 2003-11-20 | 2003-12-04 | 121 |  |  | 2003-09-22 | 2003-10-03 | 10d | 1d | 0d |  | STEREO | IMPACT |  |  |  |  | IDPU Flight LVPS Printed Wiring Boards Ordered |  |  |  |  |  |
| 79 | 2.1.1.2.5 | Procure SEP Flight Printed Wiring Board |  | 10d | 2003-11-11 | 2003-11-24 | 122 |  |  | 2003-10-09 | 2003-10-22 | 10d | 4d | 0d |  | STEREO | IMPACT |  |  |  |  | SEP Flight LVPS Printed Wiring Boards Ordered |  |  |  |  |  |
| 80 | 2.1.1.2.6 | Procure SWEA Flight Printed Wiring Board |  | 10d | 2003-11-18 | 2003-12-02 | 123 |  |  | 2003-10-03 | 2003-10-17 | 10d | 0d |  |  | STEREO | IMPACT |  |  |  |  | SWEA/STE-D Flight LVPS Printed Wiring Boards Ordered |  |  |  |  |  |
| 81 | 2.1.1.2.7 | Procure PLASTIC Flight Printed Wiring Board |  | 10d | 2003-10-24 A | 2003-11-06 A | 124 | 100% |  | 2003-09-16 | 2003-09-29 | 10d |  |  | start no earlier than 2003-10-24 | STEREO | IMPACT |  |  |  |  | PLASTIC Flight LVPS Printed Wiring Boards Ordered |  |  |  |  |  |

Notes:
- 59: FNL of 12/3/03 removed 1/9/03
- 61: FNL of 12/3/03 removed 1/9/03
- 63: FNL of 12/3/03 removed 1/9/03
- 65: FNL of 12/3/03 removed 1/9/03
- 66: FNL of 12/3/03 removed 1/9/03

| ID | WBS | Task | Type | Duration | Start | Finish | Predecessors | Complete | Remaining | Baseline start | Baseline finish | Baseline duration | Total slack | Constraint | Text11 | Text12 | Text14 | Text16 | Text28 | Text15 | Text17 | Text13 | Text23 |
| --- | --- | --- | --- | --- | --- | --- | --- | --- | --- | --- | --- | --- | --- | --- | --- | --- | --- | --- | --- | --- | --- | --- | --- |
| 82 | 2.1.2 | **Design** |  | 670d | 2000-07-31 A | 2003-04-02 A |  | 100% |  | 2000-07-31 | 2003-04-02 | 670d |  |  | STEREO | IMPACT | PS | LVPS | UC-B |  |  |  |  |
| 83 | 2.1.2.1 | Develop Low Voltage Topology |  | 96d | 2000-07-31 A | 2000-12-15 A | 32 | 100% |  | 2000-07-31 | 2000-12-15 | 96d |  |  | STEREO | IMPACT | PS | LVPS | UC-B | LVPS Card |  |  |  |
| 84 | 2.1.2.2 | Breadboard Different Topologies |  | 76d | 2000-12-18 A | 2001-04-06 A | 83 | 100% |  | 2000-12-18 | 2001-04-06 | 76d |  |  | STEREO | IMPACT | PS | LVPS | UC-B | LVPS Card |  |  |  |
| 85 | 2.1.2.3 | Test Different Topologies |  | 78d | 2001-04-09 A | 2001-07-27 A | 84 | 100% |  | 2001-04-09 | 2001-07-27 | 78d |  |  | STEREO | IMPACT | PS | LVPS | UC-B | LVPS Card |  |  |  |
| 86 | 2.1.2.4 | Design IDPU LVPS |  | 68d | 2001-09-11 A | 2001-12-18 A | 85, 33 | 100% |  | 2001-09-11 | 2001-12-18 | 68d |  |  | STEREO | IMPACT | PS | IDPU | UC-B | LVPS Card | LVPS |  |  |
| 87 | 2.1.2.5 | Design SEP LVPS |  | 9d | 2001-12-19 A | 2002-01-02 A | 86 | 100% |  | 2001-12-19 | 2002-01-02 | 9d |  |  | STEREO | IMPACT | PS | SEP DPU | UC-B | LVPS Card | LVPS | SEP Package |  |
| 88 | 2.1.2.6 | Design SWEA LVPS |  | 9d | 2002-01-02 A | 2002-01-15 A | 87 | 100% |  | 2002-01-02 | 2002-01-15 | 9d |  |  | STEREO | IMPACT | PS | SWEA/STE-D | UC-B | LVPS Card | LVPS | Boom Suite |  |
| 89 | 2.1.2.7 | Design PLASTIC LVPS |  | 10d | 2002-01-16 A | 2002-01-29 A | 88 | 100% |  | 2002-01-16 | 2002-01-29 | 10d |  |  | STEREO | PLASTIC | PS |  | UC-B | LVPS Card |  | PLASTIC |  |
| 90 | 2.1.2.8 | Design SIT HVPS |  | 24d | 2000-07-31 A | 2000-08-31 A |  | 100% |  | 2000-07-31 | 2000-08-31 | 24d |  | start no earlier than 2000-07-31 | STEREO | IMPACT | PS | SIT | UC-B | HVPS Card | HVPS | SEP Package |  |
| 91 | 2.1.2.9 | Design SIT Box Internal |  | 10.5d | 2002-05-01 A | 2002-06-07 A |  | 100% |  | 2002-05-01 | 2002-06-07 | 10.5d |  | start no earlier than 2002-04-30 | STEREO | IMPACT | PS | SIT | UC-B | HVPS Card | HVPS | SEP Package |  |
| 92 | 2.1.2.10 | Final mods to PLASTIC, SEP, and SWEA LVPS designs |  | 10d | 2003-02-06 A | 2003-04-02 A | 35 | 100% |  | 2003-02-06 | 2003-04-02 | 10d |  |  | STEREO | IMPACT |  |  |  |  |  |  |  |
| 93 | 2.1.3 | **Fabrication** |  | 440d | 2002-05-06 A | 2004-02-05 |  | 80% | 88.74d | 2002-05-06 | 2003-12-31 | 416d | 1d |  | STEREO | IMPACT | PS |  | UC-B |  |  |  |  |
| 94 | 2.1.3.1 | **ETU** |  | 300d | 2002-05-06 A | 2003-07-15 A |  | 100% |  | 2002-05-06 | 2003-07-15 | 300d |  |  | STEREO | IMPACT | PS |  | UC-B |  |  |  |  |
| 95 | 2.1.3.1.1 | **IDPU** |  | 133d | 2002-05-06 A | 2002-11-13 A |  | 100% |  | 2002-05-06 | 2002-11-13 | 133d |  |  | STEREO | IMPACT |  |  |  |  |  |  |  |
| 96 | 2.1.3.1.1.1 | IDPU LVPS Form Factor |  | 1d | 2002-05-06 A | 2002-05-06 A |  | 100% |  | 2002-05-06 | 2002-05-06 | 1d |  | start no earlier than 2002-05-06 | STEREO | IMPACT | PS |  | UC-B | LVPS Card |  | IDPU |  |
| 97 | 2.1.3.1.1.2 | Fabricate ETU IDPU LVPS Tray |  | 10d | 2002-06-03 A | 2002-06-14 A | 96 | 100% |  | 2002-06-03 | 2002-06-14 | 10d |  | start no earlier than 2002-05-31 | STEREO | IMPACT | PS | IDPU | UC-B | LVPS Card | LVPS | IDPU |  |
| 98 | 2.1.3.1.1.3 | Layout IDPU LVPS |  | 15.5d | 2002-06-03 A | 2002-09-12 A | 96 | 100% |  | 2002-06-03 | 2002-09-12 | 15.5d |  | start no earlier than 2002-05-31 | STEREO | IMPACT | PS | IDPU | UC-B | LVPS Card | LVPS | IDPU |  |
| 99 | 2.1.3.1.1.4 | Fabricate IDPU LVPS PWB |  | 9d | 2002-10-01 A | 2002-10-14 A | 98 | 100% |  | 2002-10-01 | 2002-10-14 | 9d |  | start no earlier than 2002-09-30 | STEREO | IMPACT | PS | IDPU | UC-B | LVPS Card | LVPS | IDPU |  |
| 100 | 2.1.3.1.1.5 | Wind IDPU ETU LVPS Magnetics |  | 9.8d | 2002-10-01 A | 2002-11-13 A | 117 | 100% |  | 2002-10-01 | 2002-11-13 | 9.8d |  | start no earlier than 2002-09-30 | STEREO | IMPACT | PS | IDPU | UC-B | LVPS Card | LVPS | IDPU |  |
| 101 | 2.1.3.1.2 | SEP LVPS Form Factor |  | 1d | 2003-03-31 A | 2003-03-31 A |  | 100% |  | 2003-03-31 | 2003-03-31 | 1d |  | start no earlier than 2003-03-01 | STEREO | IMPACT | PS | IDPU | UC-B | LVPS Card | LVPS | SEP Package |  |
| 102 | 2.1.3.1.3 | Fabricate ETU SEP LVPS Box |  | 20d | 2002-10-01 A | 2002-10-29 A | 101 | 100% |  | 2002-10-01 | 2002-10-29 | 20d |  | start no earlier than 2002-09-30 | STEREO | IMPACT | PS | IDPU | UC-B | LVPS Card | LVPS | SEP Package |  |
| 103 | 2.1.3.1.4 | Layout SEP LVPS |  | 19d | 2003-04-03 A | 2003-06-06 A | 92, 101 | 100% |  | 2003-04-03 | 2003-06-06 | 19d |  |  | STEREO | IMPACT |  |  |  |  |  |  |  |
| 104 | 2.1.3.1.5 | Fabricate SEP LVPS PWB |  | 10d | 2003-07-01 A | 2003-07-15 A | 103 | 100% |  | 2003-07-01 | 2003-07-15 | 10d |  | start no earlier than 2003-06-30 | STEREO | IMPACT | PS | SEP DPU | UC-B | LVPS Card | LVPS | SEP Package | SEP ETU LVPS Printed Wiring Board Fabricated |
| 105 | 2.1.3.1.6 | Wind SEP ETU LVPS Magnetics |  | 11d | 2003-05-01 A | 2003-05-15 A | 92 | 100% |  | 2003-05-01 | 2003-05-15 | 11d |  | start no earlier than 2003-05-01 | STEREO | IMPACT | PS | SEP DPU | UC-B | LVPS Card | LVPS | SEP Package |  |
| 106 | 2.1.3.1.7 | SWEA LVPS Form Factor | milestone | 0d | 2003-01-24 A | 2003-01-24 A |  | 100% |  | 2003-01-24 | 2003-01-24 | 0d |  | start no earlier than 2002-11-30 | STEREO | IMPACT | PS | SWEA/STE-D | UC-B | LVPS Card | LVPS | Boom Suite |  |
| 107 | 2.1.3.1.8 | Fabricate ETU SWEA Interface Box |  | 10d | 2003-01-27 A | 2003-02-07 A | 106 | 100% |  | 2003-01-27 | 2003-02-07 | 10d |  |  | STEREO | IMPACT | PS | SWEA/STE-D | UC-B | LVPS Card | LVPS | Boom Suite |  |
| 108 | 2.1.3.1.9 | Layout SWEA LVPS |  | 9d | 2003-03-05 A | 2003-03-17 A | 106, 88, 92 | 100% |  | 2003-03-05 | 2003-03-17 | 9d |  | start no earlier than 2003-03-01 | STEREO | IMPACT | PS | SWEA/STE-D | UC-B | LVPS Card | LVPS | Boom Suite |  |
| 109 | 2.1.3.1.10 | Fabricate SWEA LVPS PWB |  | 10d | 2003-04-01 A | 2003-04-14 A | 108 | 100% |  | 2003-04-01 | 2003-04-14 | 10d |  | start no earlier than 2003-03-31 | STEREO | IMPACT | PS | SWEA/STE-D | UC-B | LVPS Card | LVPS | Boom Suite | SWEA/STE-D ETU LVPS Printed Wiring Board Fabricated |
| 110 | 2.1.3.1.11 | Wind SWEA ETU LVPS Magnetics |  | 10d | 2003-04-03 A | 2003-04-16 A | 92 | 100% |  | 2003-04-03 | 2003-04-16 | 10d |  | start no earlier than 2003-03-31 | STEREO | IMPACT | PS | SWEA/STE-D | UC-B | LVPS Card | LVPS | Boom Suite |  |
| 111 | 2.1.3.1.12 | PLASTIC LVPS Form Factor |  | 1d | 2003-02-03 A | 2003-02-03 A |  | 100% |  | 2003-02-03 | 2003-02-03 | 1d |  | start no earlier than 2003-02-01 | STEREO | PLASTIC | PS |  | UC-B | LVPS Card | LVPS | PLASTIC |  |
| 112 | 2.1.3.1.13 | Fabricate ETU PLASTIC LVPS Box |  | 10d | 2003-05-01 A | 2003-05-14 A | 111 | 100% |  | 2003-05-01 | 2003-05-14 | 10d |  | start no earlier than 2003-05-01 | STEREO | PLASTIC | PS |  | UC-B | LVPS Card | LVPS | PLASTIC |  |
| 113 | 2.1.3.1.14 | Layout PLASTIC LVPS |  | 10d | 2003-03-05 A | 2003-03-18 A | 111, 92 | 100% |  | 2003-03-05 | 2003-03-18 | 10d |  | start no earlier than 2003-03-01 | STEREO | PLASTIC | PS |  | UC-B | LVPS Card | LVPS | PLASTIC |  |
| 114 | 2.1.3.1.15 | Fabricate PLASTIC LVPS PWB |  | 10d | 2003-04-01 A | 2003-04-14 A | 113 | 100% |  | 2003-04-01 | 2003-04-14 | 10d |  | start no earlier than 2003-03-31 | STEREO | PLASTIC | PS |  | UC-B | LVPS Card | LVPS | PLASTIC | PLASTIC ETU LVPS Printed Wiring Board Fabricated |
| 115 | 2.1.3.1.16 | Wind PLASTIC ETU LVPS Magnetics |  | 10d | 2003-05-01 A | 2003-05-14 A | 92 | 100% |  | 2003-05-01 | 2003-05-14 | 10d |  | start no earlier than 2003-05-01 | STEREO | PLASTIC | PS |  | UC-B | LVPS Card | LVPS | PLASTIC |  |
| 116 | 2.1.3.1.17 | Fabricate SIT ETU HVPS Box |  | 11d | 2002-06-07 A | 2002-06-21 A | 91 | 100% |  | 2002-06-07 | 2002-06-21 | 11d |  | start no earlier than 2002-05-31 | STEREO | IMPACT | PS | SIT | UC-B | HVPS Card | HVPS | SEP Package |  |
| 117 | 2.1.3.1.18 | Wind SIT ETU HVPS Magnetics |  | 15d | 2002-07-02 A | 2002-07-23 A |  | 100% |  | 2002-07-02 | 2002-07-23 | 15d |  | start no earlier than 2002-07-01 | STEREO | IMPACT | PS | SIT | UC-B | HVPS Card | HVPS | SEP Package |  |
| 118 | 2.1.3.1.19 | Layout SIT ETU HVPS Boards |  | 14.5d | 2002-05-06 A | 2002-06-18 A | 91 | 100% |  | 2002-05-06 | 2002-06-18 | 14.5d |  |  | STEREO | IMPACT | PS | SIT | UC-B | HVPS Card | HVPS | SEP Package |  |

Notes:
- 91: Need to check this one with DWC is this actually a GSFC activity? / No we decided to rename it to internals and have the box design out of sit for the externals be a pred to this activity

| ID | WBS | Task | Duration | Start | Finish | Predecessors | Complete | Remaining | Baseline start | Baseline finish | Baseline duration | Total slack | Free slack | Constraint | Text11 | Text12 | Text14 | Text28 | Text15 | Text16 | Text17 | Text19 | Text23 | Text13 |
| --- | --- | --- | --- | --- | --- | --- | --- | --- | --- | --- | --- | --- | --- | --- | --- | --- | --- | --- | --- | --- | --- | --- | --- | --- |
| 119 | 2.1.3.2 | **FM 1 & FM 2** | 263d | 2003-01-21 A | 2004-02-05 |  | 68% | 83.65d | 2003-01-21 | 2003-12-31 | 239d | 1d |  |  | STEREO | IMPACT | PS | UC-B |  |  |  |  |  |  |
| 120 | 2.1.3.2.1 | FM 1 & FM 2 LVPS Boxes | 89d | 2003-05-01 A | 2003-10-31 |  | 75% | 22d | 2003-05-01 | 2003-10-31 | 89d | 27d | 0d | start no earlier than 2003-05-01 | STEREO | IMPACT | PS | UC-B | LVPS Card | LVPS | LVPS | Sandy Shuman |  |  |
| 121 | 2.1.3.2.2 | Re-layout IDPU LVPS Flight Printed Wiring Board | 101d | 2003-02-26 A | 2003-11-19 A | 23 | 100% |  | 2003-02-26 | 2003-09-19 | 60d |  |  |  | STEREO | IMPACT |  |  |  |  |  |  |  |  |
| 122 | 2.1.3.2.3 | Re-layout SEP LVPS Flight Printed Wiring Board | 32d | 2003-09-24 A | 2003-11-07 A | 25FS-3d | 100% |  | 2003-09-24 | 2003-10-08 | 10d |  |  |  | STEREO | IMPACT |  |  |  |  |  |  |  |  |
| 123 | 2.1.3.2.4 | Re-layout SWEA LVPS Flight Printed Wiring Board | 5d | 2003-11-11 | 2003-11-17 | 27, 122 |  |  | 2003-09-19 | 2003-10-02 | 10d | 0d |  |  | STEREO | IMPACT |  |  |  |  |  |  |  |  |
| 124 | 2.1.3.2.5 | Re-layout PLASTIC LVPS Flight Printed Wiring Board | 6d | 2003-07-01 A | 2003-10-03 A | 28 | 100% |  | 2003-07-01 | 2003-09-15 | 6d |  |  | start no earlier than 2003-06-30 | STEREO | IMPACT |  |  |  |  |  |  |  |  |
| 125 | 2.1.3.2.6 | Re-layout SIT HVPS Flight Printed Wiring Board | 10d | 2003-01-21 A | 2003-03-03 A | 21 | 100% |  | 2003-01-21 | 2003-03-03 | 10d |  |  |  | STEREO | IMPACT |  |  |  |  |  |  |  |  |
| 126 | 2.1.3.2.7 | **FM 1** | 207d | 2003-01-29 A | 2003-11-21 |  | 69% | 63.48d | 2003-01-29 | 2003-10-17 | 183d | 11d |  |  | STEREO | IMPACT | PS | UC-B |  | LVPS | LVPS |  |  |  |
| 127 | 2.1.3.2.7.1 | Wind HVPS FM 1 Magnets | 3d | 2003-01-29 A | 2003-05-16 A | 21 | 100% |  | 2003-01-29 | 2003-05-16 | 3d |  |  |  | STEREO | IMPACT |  |  |  |  |  |  |  |  |
| 128 | 2.1.3.2.7.2 | Wind IDPU LVPS FM 1 Magnets | 10d | 2003-10-17 A | 2003-10-30 A | 23 | 100% |  | 2003-09-22 | 2003-10-03 | 10d |  |  | start no earlier than 2003-10-17 | STEREO | IMPACT |  |  |  |  |  |  |  |  |
| 129 | 2.1.3.2.7.3 | Wind SEP LVPS FM 1 Magnets | 15d | 2003-09-29 A | 2003-10-20 A | 25 | 100% |  | 2003-09-24 | 2003-10-15 | 15d |  |  |  | STEREO | IMPACT |  |  |  |  |  |  |  |  |
| 130 | 2.1.3.2.7.4 | Wind SWEA LVPS FM 1 Magnets | 9d | 2003-11-11 | 2003-11-21 | 27, 123SS |  |  | 2003-10-03 | 2003-10-17 | 10d | 11d |  |  | STEREO | IMPACT |  |  |  |  |  |  |  |  |
| 131 | 2.1.3.2.7.5 | Wind PLASTIC LVPS FM 1 Magnets | 38d | 2003-09-29 A | 2003-11-21 | 28FS-5d, 124FS-5d | 63% | 14d | 2003-09-16 | 2003-09-29 | 10d | 11d | 0d |  | STEREO | IMPACT | PS | UC-B |  | LVPS | LVPS |  |  |  |
| 132 | 2.1.3.2.8 | **FM 2** | 41d | 2003-12-08 | 2004-02-05 |  |  |  | 2003-10-01 | 2003-12-31 | 62d | 1d |  |  | STEREO | IMPACT | PS | UC-B |  | LVPS | LVPS |  |  |  |
| 133 | 2.1.3.2.8.1 | Wind HVPS FM 2 Magnets | 15d | 2003-12-08 | 2003-12-29 | 30 |  |  | 2003-10-01 | 2003-10-22 | 15d | 20d | 0d |  | STEREO | IMPACT |  |  |  |  |  |  |  |  |
| 134 | 2.1.3.2.8.2 | Wind IDPU LVPS FM 2 Magnets | 15d | 2004-01-15 | 2004-02-04 | 171 |  |  | 2003-12-05 | 2003-12-26 | 15d | 1d | 0d |  | STEREO | IMPACT |  |  |  |  |  |  |  |  |
| 135 | 2.1.3.2.8.3 | Wind SEP LVPS FM 2 Magnets | 15d | 2004-01-09 | 2004-01-30 | 172 |  |  | 2003-12-10 | 2003-12-31 | 15d | 4d | 0d |  | STEREO | IMPACT |  |  |  |  |  |  |  |  |
| 136 | 2.1.3.2.8.4 | Wind SWEA LVPS FM 2 Magnets | 15d | 2004-01-16 | 2004-02-05 | 173 |  |  | 2003-12-02 | 2003-12-22 | 15d | 0d |  |  | STEREO | IMPACT |  |  |  |  |  |  |  |  |
| 137 | 2.1.3.2.8.5 | Wind PLASTIC LVPS FM 2 Magnets | 15d | 2003-12-31 | 2004-01-22 | 174 |  |  | 2003-11-13 | 2003-12-04 | 15d | 11d | 0d |  | STEREO | IMPACT | PS | UC-B |  | LVPS | LVPS |  |  |  |
| 138 | 2.1.4 | **Assembly** | 400d | 2002-07-24 A | 2004-02-27 |  | 51% | 196.5d | 2002-07-24 | 2004-01-23 | 376d | 0d |  |  | STEREO | IMPACT | PS | UC-B |  |  |  |  |  |  |
| 139 | 2.1.4.1 | **ETU** | 255d | 2002-07-24 A | 2003-07-29 A |  | 100% |  | 2002-07-24 | 2003-07-29 | 255d |  |  |  | STEREO | IMPACT | PS | UC-B |  |  |  |  |  |  |
| 140 | 2.1.4.1.1 | Assemble IDPU ETU LVPS | 35.5d | 2002-10-15 A | 2003-01-21 A | 72, 97, 99, 100 | 100% |  | 2002-10-15 | 2003-01-21 | 35.5d |  |  | start no earlier than 2002-09-30 | STEREO | IMPACT | PS | UC-B | LVPS Card | IDPU | LVPS |  | IDPU ETU LVPS Assembled |  |
| 141 | 2.1.4.1.2 | Assemble SEP ETU LVPS | 10d | 2003-07-16 A | 2003-07-29 A | 105, 104, 102 | 100% |  | 2003-07-16 | 2003-07-29 | 10d |  |  | start no earlier than 2003-06-30 | STEREO | IMPACT | PS | UC-B | LVPS Card | SEP DPU | LVPS |  | SEP ETU LVPS Assembled | SEP Package |
| 142 | 2.1.4.1.3 | Assemble SWEA ETU LVPS | 9d | 2003-04-17 A | 2003-04-29 A | 107, 109, 110 | 100% |  | 2003-04-17 | 2003-04-29 | 9d |  |  |  | STEREO | IMPACT | PS | UC-B | LVPS Card | SWEA/STE-D | LVPS |  | SWEA/STE-D ETU LVPS Assembled | Boom Suite |
| 143 | 2.1.4.1.4 | Assemble PLASTIC ETU LVPS | 9d | 2003-05-15 A | 2003-06-06 A | 115, 114 | 100% |  | 2003-05-15 | 2003-06-06 | 9d |  |  |  | STEREO | PLASTIC | PS | UC-B | LVPS Card |  | LVPS |  | PLASTIC ETU LVPS Assembled | PLASTIC |
| 144 | 2.1.4.1.5 | Assemble SIT ETU HVPS | 20.1d | 2002-07-24 A | 2002-09-05 A | 73, 117, 116 | 100% |  | 2002-07-24 | 2002-09-05 | 20.1d |  |  |  | STEREO | IMPACT | PS | UC-B | HVPS Card | SIT | HVPS |  |  | SEP Package |

| ID | WBS | Task | Duration | Start | Finish | Predecessors | Complete | Remaining | Baseline start | Baseline finish | Baseline duration | Total slack | Free slack | Constraint | Text11 | Text12 | Text14 | Text28 | Text13 | Text15 | Text16 | Text17 | Text20 | Text23 |
| --- | --- | --- | --- | --- | --- | --- | --- | --- | --- | --- | --- | --- | --- | --- | --- | --- | --- | --- | --- | --- | --- | --- | --- | --- |
| 145 | 2.1.4.2 | **FM 1** | 155d | 2003-05-19 A | 2003-12-30 |  | 47% | 81.89d | 2003-05-19 | 2003-11-24 | 131d | 1d |  |  | STEREO | IMPACT | PS | UC-B |  |  |  |  |  |  |
| 146 | 2.1.4.2.1 | Assemble IDPU FM 1 LVPS | 12d | 2003-12-11 | 2003-12-29 | 75, 120, 128, 165 |  |  | 2003-11-03 | 2003-11-19 | 12d | 1d | 0d |  | STEREO | IMPACT | PS | UC-B | IDPU | LVPS Card | IDPU | LVPS | Assy IDPU FM 1 LVPS | IDPU FM 1 LVPS Assembled |
| 147 | 2.1.4.2.2 | Assemble SEP FM 1 LVPS | 15d | 2003-12-03 | 2003-12-23 | 129, 75, 120FF-5d, 166 |  |  | 2003-11-03 | 2003-11-24 | 15d | 4d | 0d |  | STEREO | IMPACT | PS | UC-B | SEP Package | LVPS Card | SEP DPU | LVPS |  | SEP FM 1 LVPS Assembled |
| 148 | 2.1.4.2.3 | Assemble SWEA FM 1 LVPS | 14d | 2003-12-10 | 2003-12-30 | 130, 75, 167 |  |  | 2003-10-27 | 2003-11-14 | 14d | 0d |  |  | STEREO | IMPACT | PS | UC-B | Boom Suite | LVPS Card | SWEA/STE-D | LVPS |  | SWEA/STE-D FM 1 LVPS Assembled |
| 149 | 2.1.4.2.4 | Assemble PLASTIC FM 1 LVPS | 15d | 2003-11-24 | 2003-12-15 | 131, 75, 168 |  |  | 2003-10-08 | 2003-10-28 | 15d | 11d | 0d |  | STEREO | PLASTIC | PS | UC-B |  | LVPS Card |  | LVPS |  | PLASTIC FM 1 LVPS Assembled |
| 150 | 2.1.4.2.5 | Assemble SIT FM 1 HVPS | 50d | 2003-05-19 A | 2003-09-02 A | 127, 76, 169 | 100% |  | 2003-05-19 | 2003-09-02 | 50d |  |  |  | STEREO | IMPACT | PS | UC-B | SEP Package | HVPS Card | SIT | HVPS |  | SIT FM 1 HVPS Assembled |
| 151 | 2.1.4.3 | **FM 2** | 41d | 2003-12-30 | 2004-02-27 |  |  |  | 2003-10-23 | 2004-01-23 | 62d | 0d |  |  | STEREO | IMPACT | PS | UC-B |  |  |  |  |  |  |
| 152 | 2.1.4.3.1 | Assemble IDPU FM 2 LVPS | 15d | 2004-02-05 | 2004-02-26 | 134 |  |  | 2003-12-29 | 2004-01-20 | 15d | 1d | 0d |  | STEREO | IMPACT | PS | UC-B | IDPU | LVPS Card | IDPU | LVPS |  | IDPU FM 2 LVPS Assembled |
| 153 | 2.1.4.3.2 | Assemble SEP FM 2 LVPS | 15d | 2004-02-02 | 2004-02-23 | 135 |  |  | 2004-01-02 | 2004-01-23 | 15d | 4d | 0d |  | STEREO | IMPACT | PS | UC-B | SEP Package | LVPS Card | SEP DPU | LVPS |  | SEP FM 2 LVPS Assembled |
| 154 | 2.1.4.3.3 | Assemble SWEA FM 2 LVPS | 15d | 2004-02-06 | 2004-02-27 | 136 |  |  | 2003-12-23 | 2004-01-15 | 15d | 0d |  |  | STEREO | IMPACT | PS | UC-B | Boom Suite | LVPS Card | SWEA/STE-D | LVPS |  | SWEA/STE-D FM 2 LVPS Assembled |
| 155 | 2.1.4.3.4 | Assemble PLASTIC FM 2 LVPS | 14d | 2004-01-23 | 2004-02-11 | 137 |  |  | 2003-12-05 | 2003-12-24 | 14d | 11d | 0d |  | STEREO | PLASTIC | PS | UC-B | PLASTIC | LVPS Card |  | LVPS |  | PLASTIC FM 2 LVPS Assembled |
| 156 | 2.1.4.3.5 | Assemble SIT FM 2 HVPS | 14d | 2003-12-30 | 2004-01-20 | 133, 30 |  |  | 2003-10-23 | 2003-11-12 | 14d | 20d | 0d |  | STEREO | IMPACT | PS | UC-B | SEP Package | HVPS Card | SIT | HVPS |  | SIT FM 2 HVPS Assembled |
| 157 | 2.1.5 | **Test** | 403d | 2002-08-30 A | 2004-04-09 |  | 20% | 321.75d | 2002-08-30 | 2004-03-08 | 379d | 0d |  |  | STEREO | IMPACT | PS | UC-B |  |  |  |  |  |  |
| 158 | 2.1.5.1 | **ETU** | 260d | 2002-08-30 A | 2003-09-12 A |  | 100% |  | 2002-08-30 | 2003-09-12 | 260d |  |  |  | STEREO | IMPACT | PS | UC-B |  |  |  |  |  |  |
| 159 | 2.1.5.1.1 | Test IDPU ETU LVPS | 12d | 2003-01-20 A | 2003-02-05 A | 140FS-5d | 100% |  | 2003-01-20 | 2003-02-05 | 12d |  |  | start no earlier than 2002-11-30 | STEREO | IMPACT | PS | UC-B | IDPU | LVPS Card | IDPU | LVPS |  | IDPU ETU LVPS Tested |
| 160 | 2.1.5.1.2 | Test SEP ETU LVPS | 32d | 2003-07-30 A | 2003-09-12 A | 141 | 100% |  | 2003-07-30 | 2003-09-12 | 32d |  |  |  | STEREO | IMPACT | PS | UC-B | SEP Package | LVPS Card | SEP DPU | LVPS |  | SEP ETU LVPS Tested |
| 161 | 2.1.5.1.3 | Test SWEA ETU LVPS | 10d | 2003-05-01 A | 2003-05-14 A | 142 | 100% |  | 2003-05-01 | 2003-05-14 | 10d |  |  |  | STEREO | IMPACT | PS | UC-B | Boom Suite | LVPS Card | SWEA/STE-D | LVPS |  | SWEA/STE-D ETU LVPS Tested |
| 162 | 2.1.5.1.4 | Test PLASTIC ETU LVPS | 10d | 2003-06-06 A | 2003-07-08 A | 143, 112FF | 100% |  | 2003-06-06 | 2003-07-08 | 10d |  |  | start no earlier than 2003-06-01 | STEREO | PLASTIC | PS | UC-B | PLASTIC | LVPS Card |  | LVPS |  | PLASTIC ETU LVPS Tested |
| 163 | 2.1.5.1.5 | Test SIT ETU HVPS | 5.5d | 2002-08-30 A | 2002-10-01 A | 144FF-4d | 100% |  | 2002-08-30 | 2002-10-01 | 5.5d |  |  |  | STEREO | IMPACT | PS | UC-B | SEP Package | HVPS Card | SIT | HVPS |  |  |
| 164 | 2.1.5.2 | **FM 1 & FM 2** | 166d | 2003-04-15 A | 2003-12-10 |  | 21% | 131.42d | 2003-04-15 | 2003-10-29 | 138d | 1d |  |  | STEREO | IMPACT |  |  |  |  |  |  |  |  |
| 165 | 2.1.5.2.1 | Coupon Test IDPU Flight Printed Wiring Board | 4d | 2003-12-05 | 2003-12-10 | 78 |  |  | 2003-10-07 | 2003-10-10 | 4d | 1d | 0d |  | STEREO | IMPACT |  |  |  |  |  |  |  |  |
| 166 | 2.1.5.2.2 | Coupon Test SEP Flight Printed Wiring Board | 5d | 2003-11-25 | 2003-12-02 | 79 |  |  | 2003-10-23 | 2003-10-29 | 5d | 4d | 0d |  | STEREO | IMPACT |  |  |  |  |  |  |  |  |
| 167 | 2.1.5.2.3 | Coupon Test SWEA Flight Printed Wiring Board | 5d | 2003-12-03 | 2003-12-09 | 80 |  |  | 2003-10-20 | 2003-10-24 | 5d | 0d |  |  | STEREO | IMPACT |  |  |  |  |  |  |  |  |
| 168 | 2.1.5.2.4 | Coupon Test PLASTIC Flight Printed Wiring Board | 5d | 2003-11-07 | 2003-11-14 | 81 |  |  | 2003-09-30 | 2003-10-07 | 5d | 16d | 5d |  | STEREO | IMPACT |  |  |  |  |  |  |  |  |
| 169 | 2.1.5.2.5 | Coupon Test SIT HVPS Flight Printed Wiring Board | 5d | 2003-04-15 A | 2003-04-21 A | 77 | 100% |  | 2003-04-15 | 2003-04-21 | 5d |  |  | start no earlier than 2003-03-31 | STEREO | IMPACT |  |  |  |  |  |  |  |  |

| ID | WBS | Task | Duration | Start | Finish | Predecessors | Baseline start | Baseline finish | Baseline duration | Total slack | Free slack | Constraint | Text11 | Text12 | Text14 | Text28 | Text13 | Text15 | Text16 | Text17 | Text23 |
| --- | --- | --- | --- | --- | --- | --- | --- | --- | --- | --- | --- | --- | --- | --- | --- | --- | --- | --- | --- | --- | --- |
| 170 | 2.1.5.3 | **FM 1** | 70d | 2003-10-31 | 2004-02-12 |  | 2003-07-10 | 2004-01-08 | 124.5d | 20d |  |  | STEREO | IMPACT | PS | UC-B |  |  |  |  |  |
| 171 | 2.1.5.3.1 | Test IDPU FM 1 LVPS | 10d | 2003-12-30 | 2004-01-14 | 146 | 2003-11-20 | 2003-12-04 | 10d | 1d | 0d |  | STEREO | IMPACT | PS | UC-B | IDPU | LVPS Card | IDPU | LVPS | IDPU FM 1 LVPS Tested |
| 172 | 2.1.5.3.2 | Test SEP FM 1 LVPS | 10d | 2003-12-24 | 2004-01-08 | 147 | 2003-11-25 | 2003-12-09 | 10d | 4d | 0d |  | STEREO | IMPACT | PS | UC-B | SEP Package | LVPS Card | SEP DPU | LVPS | SEP FM 1 LVPS Tested |
| 173 | 2.1.5.3.3 | Test SWEA FM 1 LVPS | 10d | 2003-12-31 | 2004-01-15 | 148 | 2003-11-17 | 2003-12-01 | 10d | 0d |  |  | STEREO | IMPACT | PS | UC-B | Boom Suite | LVPS Card | SWEA/STE-D | LVPS | SWEA/STE-D FM 1 LVPS Tested |
| 174 | 2.1.5.3.4 | Test PLASTIC FM 1 LVPS | 10d | 2003-12-16 | 2003-12-30 | 149 | 2003-10-29 | 2003-11-12 | 10d | 11d | 0d |  | STEREO | PLASTIC | PS | UC-B | PLASTIC | LVPS Card |  | LVPS | PLASTIC FM 1 LVPS Tested |
| 175 | 2.1.5.3.5 | Coat & Stake IDPU LVPS FM 1 Boards | 5d | 2004-01-15 | 2004-01-21 | 171 | 2003-12-05 | 2003-12-11 | 5d | 28d | 0d |  | STEREO | IMPACT | PS | UC-B |  |  | LVPS | LVPS |  |
| 176 | 2.1.5.3.6 | Coat & Stake SEP LVPS FM 1 Boards | 5d | 2004-01-09 | 2004-01-16 | 172 | 2003-12-10 | 2003-12-16 | 5d | 35d | 0d |  | STEREO | IMPACT |  |  |  |  |  |  |  |
| 177 | 2.1.5.3.7 | Coat & Stake SWEA LVPS FM 1 Boards | 5d | 2004-01-16 | 2004-01-22 | 173 | 2003-12-02 | 2003-12-08 | 5d | 18d | 0d |  | STEREO | IMPACT |  |  |  |  |  |  |  |
| 178 | 2.1.5.3.8 | Coat & Stake PLASTIC LVPS FM 1 Boards | 5d | 2003-12-31 | 2004-01-07 | 174 | 2003-11-13 | 2003-11-19 | 5d | 50d | 0d |  | STEREO | IMPACT |  |  |  |  |  |  |  |
| 179 | 2.1.5.3.9 | Retest IDPU LVPS FM 1 Boards | 15d | 2004-01-22 | 2004-02-11 | 175 | 2003-12-12 | 2004-01-05 | 15d | 28d | 0d |  | STEREO | IMPACT | PS | UC-B |  |  | LVPS | LVPS |  |
| 180 | 2.1.5.3.10 | Retest SEP LVPS FM 1 Boards | 15d | 2004-01-19 | 2004-02-06 | 176 | 2003-12-17 | 2004-01-08 | 15d | 35d | 0d |  | STEREO | IMPACT |  |  |  |  |  |  |  |
| 181 | 2.1.5.3.11 | Retest SWEA LVPS FM 1 Boards | 15d | 2004-01-23 | 2004-02-12 | 177 | 2003-12-09 | 2003-12-30 | 15d | 18d | 0d |  | STEREO | IMPACT |  |  |  |  |  |  |  |
| 182 | 2.1.5.3.12 | Retest PLASTIC LVPS FM 1 Boards | 15d | 2004-01-08 | 2004-01-29 | 178 | 2003-11-20 | 2003-12-11 | 15d | 50d | 0d |  | STEREO | IMPACT |  |  |  |  |  |  |  |
| 183 | 2.1.5.3.13 | Test SIT FM 1 HVPS | 19d | 2003-10-31 | 2003-11-28 | 150 | 2003-07-10 | 2003-09-15 | 11d | 20d | 0d | start no earlier than 2003-10-31 | STEREO | IMPACT | PS | UC-B | SEP Package | HVPS Card | SIT | HVPS | SIT FM 1 HVPS Tested |
| 184 | 2.1.5.3.14 | Coat & Stake SIT HVPS FM 1 Boards | 5d | 2003-12-01 | 2003-12-05 | 183 | 2003-09-16 | 2003-09-22 | 5d | 85d | 0d |  | STEREO | IMPACT | PS | UC-B | SEP Package |  | SIT | HVPS |  |
| 185 | 2.1.5.3.15 | Retest SIT HVPS FM 1 Boards | 1d | 2003-12-08 | 2003-12-08 | 184 | 2003-09-23 | 2003-09-23 | 1d | 85d |  |  | STEREO | IMPACT | PS | UC-B | SEP Package |  | SIT | HVPS |  |
| 186 | 2.1.5.4 | **FM 2** | 57d | 2004-01-21 | 2004-04-09 |  | 2003-11-13 | 2004-03-08 | 78d | 0d |  |  | STEREO | IMPACT | PS | UC-B |  |  |  |  |  |
| 187 | 2.1.5.4.1 | **IDPU** | 30d | 2004-02-27 | 2004-04-08 |  | 2004-01-21 | 2004-03-03 | 30d | 1d |  |  | STEREO | IMPACT |  |  |  |  |  |  |  |
| 188 | 2.1.5.4.1.1 | Test IDPU FM 2 LVPS | 10d | 2004-02-27 | 2004-03-11 | 152 | 2004-01-21 | 2004-02-03 | 10d | 1d | 0d |  | STEREO | IMPACT | PS | UC-B |  | LVPS Card | IDPU | LVPS | IDPU FM 2 LVPS Tested |
| 189 | 2.1.5.4.1.2 | Coat & Stake IDPU LVPS FM 2 Boards | 5d | 2004-03-12 | 2004-03-18 | 188 | 2004-02-04 | 2004-02-10 | 5d | 1d | 0d |  | STEREO | IMPACT | PS | UC-B |  |  | LVPS | LVPS |  |
| 190 | 2.1.5.4.1.3 | Retest IDPU LVPS FM 2 Boards | 15d | 2004-03-19 | 2004-04-08 | 189 | 2004-02-11 | 2004-03-03 | 15d | 1d | 0d |  | STEREO | IMPACT | PS | UC-B |  |  | LVPS | LVPS |  |
| 191 | 2.1.5.4.2 | **SEP** | 30d | 2004-02-24 | 2004-04-05 |  | 2004-01-26 | 2004-03-08 | 30d | 4d |  |  | STEREO | IMPACT |  |  |  |  |  |  |  |
| 192 | 2.1.5.4.2.1 | Test SEP FM 2 LVPS | 10d | 2004-02-24 | 2004-03-08 | 153 | 2004-01-26 | 2004-02-06 | 10d | 4d | 0d |  | STEREO | IMPACT | PS | UC-B | SEP Package | LVPS Card | SEP DPU | LVPS | SEP FM 2 LVPS Tested |
| 193 | 2.1.5.4.2.2 | Coat & Stake SEP LVPS FM 2 Boards | 5d | 2004-03-09 | 2004-03-15 | 192 | 2004-02-09 | 2004-02-13 | 5d | 4d | 0d |  | STEREO | IMPACT |  |  |  |  |  |  |  |
| 194 | 2.1.5.4.2.3 | Retest SEP LVPS FM 2 Boards | 15d | 2004-03-16 | 2004-04-05 | 193 | 2004-02-17 | 2004-03-08 | 15d | 4d | 0d |  | STEREO | IMPACT |  |  |  |  |  |  |  |

| ID | WBS | Task | Duration | Start | Finish | Predecessors | Baseline start | Baseline finish | Baseline duration | Total slack | Free slack | Text11 | Text12 | Text13 | Text14 | Text15 | Text16 | Text17 | Text23 | Text28 |
| --- | --- | --- | --- | --- | --- | --- | --- | --- | --- | --- | --- | --- | --- | --- | --- | --- | --- | --- | --- | --- |
| 195 | 2.1.5.4.3 | **SWEA** | 30d | 2004-03-01 | 2004-04-09 |  | 2004-01-16 | 2004-02-27 | 30d | 0d |  | STEREO | IMPACT |  |  |  |  |  |  |  |
| 196 | 2.1.5.4.3.1 | Test SWEA FM 2 LVPS | 10d | 2004-03-01 | 2004-03-12 | 154 | 2004-01-16 | 2004-01-29 | 10d | 0d |  | STEREO | IMPACT | Boom Suite | PS | LVPS Card | SWEA/STE-D | LVPS | SWEA/STE-D FM 2 LVPS Tested | UC-B |
| 197 | 2.1.5.4.3.2 | Coat & Stake SWEA LVPS FM 2 Boards | 5d | 2004-03-15 | 2004-03-19 | 196 | 2004-01-30 | 2004-02-05 | 5d | 0d |  | STEREO | IMPACT |  |  |  |  |  |  |  |
| 198 | 2.1.5.4.3.3 | Retest SWEA LVPS FM 2 Boards | 15d | 2004-03-22 | 2004-04-09 | 197 | 2004-02-06 | 2004-02-27 | 15d | 0d |  | STEREO | IMPACT |  |  |  |  |  |  |  |
| 199 | 2.1.5.4.4 | **PLASTIC** | 30d | 2004-02-12 | 2004-03-25 |  | 2003-12-26 | 2004-02-09 | 30d | 11d |  | STEREO | IMPACT |  |  |  |  |  |  |  |
| 200 | 2.1.5.4.4.1 | Test PLASTIC FM 2 LVPS | 10d | 2004-02-12 | 2004-02-26 | 155 | 2003-12-26 | 2004-01-09 | 10d | 11d | 0d | STEREO | PLASTIC | PLASTIC | PS | LVPS Card |  | LVPS | PLASTIC FM 2 LVPS Tested | UC-B |
| 201 | 2.1.5.4.4.2 | Coat & Stake PLASTIC LVPS FM 2 Boards | 5d | 2004-02-27 | 2004-03-04 | 200 | 2004-01-13 | 2004-01-19 | 5d | 11d | 0d | STEREO | IMPACT |  |  |  |  |  |  |  |
| 202 | 2.1.5.4.4.3 | Retest PLASTIC LVPS FM 2 Boards | 15d | 2004-03-05 | 2004-03-25 | 201 | 2004-01-20 | 2004-02-09 | 15d | 11d | 0d | STEREO | IMPACT |  |  |  |  |  |  |  |
| 203 | 2.1.5.4.5 | **SIT** | 11d | 2004-01-21 | 2004-02-04 |  | 2003-11-13 | 2003-11-28 | 11d | 20d |  | STEREO | IMPACT |  |  |  |  |  |  |  |
| 204 | 2.1.5.4.5.1 | Test SIT FM 2 HVPS | 5d | 2004-01-21 | 2004-01-27 | 156 | 2003-11-13 | 2003-11-19 | 5d | 20d | 0d | STEREO | IMPACT | SEP Package | PS | HVPS Card | SIT | HVPS | SIT FM 2 HVPS Tested | UC-B |
| 205 | 2.1.5.4.5.2 | Coat & Stake SIT FM 2 HVPS Boards | 5d | 2004-01-28 | 2004-02-03 | 204 | 2003-11-20 | 2003-11-26 | 5d | 46d | 0d | STEREO | IMPACT | SEP Package | PS |  | SIT | HVPS |  | UC-B |
| 206 | 2.1.5.4.5.3 | Retest SIT FM 2 HVPS Boards | 1d | 2004-02-04 | 2004-02-04 | 205 | 2003-11-28 | 2003-11-28 | 1d | 46d |  | STEREO | IMPACT | SEP Package | PS |  | SIT | HVPS |  | UC-B |
