# IMPACT SEP

Schedule from MS Project, 2000-09-05 to 2005-06-28, status date 2003-10-31, A marks actual dates.
SEP Package Development With I & T
NASA GSFC
Status Date: 10/31/2003 / Baseline Date: 01/31/2003 R1

## Calendars

- Standard w/ 10 Gov't Holidays: Mon-Fri 08:00-12:00, 13:00-17:00; Sat-Sun off. Exceptions (off unless hours are given): 2000-10-09, 2000-11-13, 2000-11-23, 2000-12-25, 2001-01-01, 2001-01-15, 2001-02-19, 2001-05-28, 2001-07-04, 2001-09-03, 2001-10-08, 2001-11-12, 2001-11-22, 2001-12-25, 2002-01-01, 2002-01-14, 2002-02-18, 2002-05-27, 2002-07-04, 2002-09-02, 2002-10-07, 2002-11-11, 2002-11-28, 2002-12-25, 2003-01-01, 2003-01-13, 2003-02-17, 2003-05-26, 2003-07-04, 2003-09-01, 2003-10-06, 2003-11-10, 2003-11-27, 2003-12-25, 2004-01-01, 2004-01-12, 2004-02-16, 2004-05-31, 2004-07-05, 2004-09-06, 2004-10-11, 2004-11-08, 2004-11-25, 2004-12-24, 2004-12-31, 2005-01-17, 2005-02-21, 2005-05-30.

## Schedule

| ID | WBS | Task | Type | Duration | Start | Finish | Predecessors | Complete | Remaining | Baseline start | Baseline finish | Baseline duration | Total slack | Free slack | Constraint | Work | Actual work | Text11 | Text12 | Text13 | Text28 | Text14 | Text16 | Text20 | Text22 | Text23 | Text21 |
| --- | --- | --- | --- | --- | --- | --- | --- | --- | --- | --- | --- | --- | --- | --- | --- | --- | --- | --- | --- | --- | --- | --- | --- | --- | --- | --- | --- |
| 1 | 1 | **Management** |  | 558d | 2002-05-21 A | 2004-08-09 |  |  | 558d | 2002-05-21 | 2004-07-27 | 549d | 26d |  |  |  |  | STEREO | IMPACT | SEP Package | CIT |  |  |  |  |  |  |
| 2 | 1.1 | **Milestones** |  | 558d | 2002-05-21 A | 2004-08-09 |  |  | 558d | 2002-05-21 | 2004-07-27 | 549d | 26d |  |  |  |  | STEREO | IMPACT | SEP Package | CIT |  |  |  |  |  |  |
| 3 | 1.1.1 | SEP Software Design Review | milestone | 0d | 2002-05-21 A | 2002-05-21 A |  | 100% |  | 2002-05-21 | 2002-05-21 | 0d |  |  | start no earlier than 2002-07-31 |  |  | STEREO | IMPACT | SEP Package | CIT | SEP Cen | MAG |  |  |  |  |
| 4 | 1.1.2 | **Receivables** |  | 0d | 2004-08-06 | 2004-08-06 |  |  |  | 2004-07-01 | 2004-07-27 | 16d | 17d |  |  |  |  | STEREO | IMPACT | SEP Package |  |  |  |  |  |  |  |
| 5 | 1.2.8.11 | SEP Package FM 1 Complete | milestone | 0d | 2004-08-06 | 2004-08-06 |  |  |  | 2004-07-01 | 2004-07-01 | 0d | 0d |  |  |  |  | STEREO | IMPACT | SEP Package |  |  |  |  |  |  |  |
| 6 | 1.1.2.2 | SEP Package FM 1 Ready For Delivery to APL | milestone | 0d | 2004-08-06 | 2004-08-06 | 5 |  |  | 2004-07-01 | 2004-07-01 | 0d | 17d | 0d |  |  |  | STEREO | IMPACT | SEP Package |  | SEP Package |  | FM 1 Rdy | SEP Package - FM 1 Ready For Delivery | FM 1 Ready For Delivery to APL |  |
| 7 | 1.2.8.13 | SEP Package FM 2 Complete | milestone | 0d | 2004-08-06 | 2004-08-06 |  |  |  | 2004-07-16 | 2004-07-16 | 0d | 26d | 0d |  |  |  | STEREO | IMPACT | SEP Package |  |  |  |  |  |  |  |
| 8 | 1.1.2.4 | SEP Package FM 2 Ready For Delivery to APL | milestone | 0d | 2004-08-06 | 2004-08-06 | 7 |  |  | 2004-07-27 | 2004-07-27 | 0d | 26d | 0d |  |  |  | STEREO | IMPACT | SEP Package |  | SEP Package |  | FM 2 Rdy | SEP Package - FM 2 Ready For Delivery | FM 2 Ready for Delivery to APL |  |
| 9 | 1.1.3 | **Contingency** |  | 1d | 2004-08-06 | 2004-08-09 |  |  |  | 2003-04-30 | 2004-07-27 | 312d | 17d |  |  |  |  | STEREO | IMPACT | SEP Package | CIT |  |  |  |  |  |  |
| 10 | 1.1.3.1 | SEP Package FM 1 Project Contingency | milestone | 0d | 2004-08-06 | 2004-08-06 | 6 |  |  | 2004-07-14 | 2004-07-14 | 0d | 17d | 0d |  |  |  | STEREO | IMPACT | SEP Package | CIT | SEP Package |  | Del FM 1 | SEP Package - FM 1 Delivery to APL | FM 1 Project Contingency | FM1 & 2 SEP to APL / Bar 2 IMPACT #1 DEL |
| 11 | 1.1.3.2 | SEP Package FM 2 Project Contingency | milestone | 0d | 2004-08-06 | 2004-08-06 | 8 |  |  | 2004-07-27 | 2004-07-27 | 0d | 26d | 0d |  |  |  | STEREO | IMPACT | SEP Package | CIT | SEP Package |  | Del FM 2 | SEP Package - Delivery FM 2 to APL | FM 2 Project Contingency | FM1 & 2 SEP to APLL / Bar 2 IMPACT #2 DEL |
| 12 | 1.1.3.3 | SEP Package FM 1 Contractual Date |  | 1d | 2004-08-09 | 2004-08-09 | 10 |  |  | 2004-07-14 | 2004-07-14 | 1d | 17d |  | must finish on 2004-09-01 |  |  | STEREO | IMPACT | SEP Package |  |  |  |  |  |  |  |
| 13 | 1.1.3.4 | SEP Package FM 2 Contractual Date |  | 1d | 2004-08-09 | 2004-08-09 | 11 |  |  | 2004-07-27 | 2004-07-27 | 1d | 26d |  | must finish on 2004-09-15 |  |  | STEREO | IMPACT | SEP Package |  |  |  |  |  |  |  |
| 14 | 1.2 | **Documentation** |  | 0d | 2003-04-30 A | 2003-04-30 A |  | 100% |  | 2003-04-30 | 2003-04-30 | 0d |  |  |  |  |  | STEREO | IMPACT | SEP Package | CIT |  |  |  |  |  |  |
| 15 | 1.2.1 | Data Transfer Protocol ICD Finished | milestone | 0d | 2003-04-30 A | 2003-04-30 A |  | 100% |  | 2003-04-30 | 2003-04-30 | 0d |  |  | start no earlier than 2003-04-30 |  |  | STEREO | IMPACT | SEP Package | CIT | SEP Cen |  |  |  |  |  |
| 16 | 2 | **Systems Engineering** |  | 1147.76d | 2000-12-01 A | 2005-06-28 |  | 58% | 477.88d | 2000-12-01 | 2005-06-28 | 1147.76d | 0d |  |  |  |  | STEREO | IMPACT | SEP Package | CIT |  |  |  |  |  |  |
| 17 | 2.1 | **Documentation** |  | 1147.76d | 2000-12-01 A | 2005-06-28 |  | 58% | 477.88d | 2000-12-01 | 2005-06-28 | 1147.76d | 0d |  |  |  |  | STEREO | IMPACT | SEP Package | CIT |  |  |  |  |  |  |
| 18 | 2.1.1 | SEP Development Oversight |  | 963d | 2000-12-01 A | 2005-06-28 |  | 55% | 436.76d | 2000-12-01 | 2005-06-28 | 963d | 0d |  | start no earlier than 2000-12-01 |  |  | STEREO | IMPACT | SEP Package | CIT | SEP Cen |  |  |  |  |  |
| 19 | 2.1.2 | Make ICDs |  | 86d | 2001-07-31 A | 2003-08-29 A |  | 100% |  | 2001-07-31 | 2003-08-29 | 86d |  |  | start no earlier than 2001-07-31 |  |  | STEREO | IMPACT | SEP Package | CIT | SEP Cen |  |  |  |  |  |
| 20 | 3 | SEP CEN - Solar Energy Partical Package Central Processor |  | 726d? | 2001-08-15 A | 2004-07-07 |  | 80% | 143.47d? | 2001-08-15 | 2004-07-07 | 726d? | 244.76d |  |  |  |  | STEREO | IMPACT | SEP Package |  |  |  |  |  |  |  |
| 21 | 4 | LET - Low Energy Telescope |  | 1065d | 2000-09-05 A | 2004-12-02 |  | 75% | 266.36d | 2000-09-05 | 2004-12-02 | 1065d | 142.76d |  |  |  |  | STEREO | IMPACT | SEP Package | CIT | LET | LET |  |  |  |  |
| 22 | 5 | HET - High Energy Telescope |  | 905.5d | 2000-09-05 A | 2004-04-15 |  | 79% | 194.49d | 2000-09-05 | 2004-03-12 | 882d | 302.26d |  |  |  |  | STEREO | IMPACT | SEP Package |  | HET | HET |  |  |  |  |
| 23 | 6 | SIT - Suprathermal Ion Telescope |  | 982d | 2000-09-05 A | 2004-08-02 |  | 63% | 359.08d | 2000-09-05 | 2004-03-12 | 882d | 226.76d |  |  |  |  | STEREO | IMPACT | SEP Package |  | SIT | SIT |  |  |  |  |
| 24 | 7 | SEPT - Solar Electron and Proton Telescope |  | 783d | 2001-01-02 A | 2004-02-16 |  | 90% | 81.07d | 2001-01-02 | 2004-01-09 | 759d | 344.76d |  |  | 8673.6h | 8673.6h | STEREO | IMPACT | SEP Package |  | SEPT | SEPT |  |  |  |  |
| 25 | 8 | SEP I & T - Solar Energy Partical Package Integration and Test |  | 939d | 2001-03-01 A | 2004-11-23 |  | 48% | 490.66d | 2001-03-01 | 2005-01-21 | 978d | 148.76d |  |  |  |  | STEREO | IMPACT | SEP Package |  |  |  |  |  |  |  |
