# SIT - Suprathermal Ion Telescope

Schedule from MS Project, 2000-09-05 to 2004-08-02, status date 2003-10-31, A marks actual dates.
SIT Instrument Development Schedule
NASA GSFC
Status Date: 10/31/2003 / Baseline Date: 01/31/2003 R1

## Calendars

- Standard w/ 10 Gov't Holidays: Mon-Fri 08:00-12:00, 13:00-17:00; Sat-Sun off. Exceptions (off unless hours are given): 2000-10-09, 2000-11-13, 2000-11-23, 2000-12-25, 2001-01-01, 2001-01-15, 2001-02-19, 2001-05-28, 2001-07-04, 2001-09-03, 2001-10-08, 2001-11-12, 2001-11-22, 2001-12-25, 2002-01-01, 2002-01-14, 2002-02-18, 2002-05-27, 2002-07-04, 2002-09-02, 2002-10-07, 2002-11-11, 2002-11-28, 2002-12-25, 2003-01-01, 2003-01-13, 2003-02-17, 2003-05-26, 2003-07-04, 2003-09-01, 2003-10-06, 2003-11-10 08:00-12:00, 13:00-17:00, 2003-11-27, 2003-12-25, 2004-01-01, 2004-01-12, 2004-02-16, 2004-05-31, 2004-07-05.

## Schedule

| ID | WBS | Task | Type | Duration | Start | Finish | Predecessors | Complete | Remaining | Baseline start | Baseline finish | Baseline duration | Total slack | Free slack | Constraint | Text11 | Text12 | Text13 | Text14 | Text16 | Text28 | Text21 | Text23 | Text22 |
| --- | --- | --- | --- | --- | --- | --- | --- | --- | --- | --- | --- | --- | --- | --- | --- | --- | --- | --- | --- | --- | --- | --- | --- | --- |
| 1 | 1 | **Management** |  | 876d | 2001-01-11 A | 2004-07-06 |  | 60% | 350.4d | 2001-01-11 | 2004-03-12 | 795d | 19d |  |  | STEREO | IMPACT | SEP Package | SIT | SIT | UMD |  |  |  |
| 2 | 1.1 | **Milestones** |  | 876d | 2001-01-11 A | 2004-07-06 |  | 55% | 398.18d | 2001-01-11 | 2004-03-12 | 795d | 19d |  |  | STEREO | IMPACT | SEP Package | SIT | SIT | UMD |  |  |  |
| 3 | 1.1.1 | **Contingency** |  | 245d | 2003-07-11 A | 2004-06-30 |  |  | 245d | 2003-07-11 | 2004-03-12 | 167d | 22d |  |  | STEREO | IMPACT | SEP Package | SIT | SIT | UMD |  |  |  |
| 4 | 1.1.1.1 | SIT FM 1 Delivery to CIT for SEP I & T Contingency | milestone | 0d | 2004-06-30 | 2004-06-30 | 353 |  |  | 2004-03-02 | 2004-03-02 | 0d | 22d |  |  | STEREO | IMPACT | SEP Package | SIT | SIT | UMD |  |  |  |
| 5 | 1.1.1.2 | SIT FM 2 Delivery to CIT for SEP I & T Contingency | milestone | 0d | 2004-06-30 | 2004-06-30 | 353 |  |  | 2004-03-12 | 2004-03-12 | 0d | 22d |  |  | STEREO | IMPACT | SEP Package | SIT | SIT | UMD |  |  |  |
| 6 | 1.1.1.3 | SIT S/W Delivery to CIT for SEP Central I/F Testing Contingency | milestone | 0d | 2003-07-11 A | 2003-07-11 A | 314, 378 | 100% |  | 2003-07-11 | 2003-07-11 | 0d |  |  |  | STEREO | IMPACT | SEP Package | SIT | SIT | UMD |  |  |  |
| 7 | 1.1.2 | **Receivables** |  | 854d | 2001-01-11 A | 2004-06-03 |  | 50% | 427d | 2001-01-11 | 2003-11-28 | 724d | 0d |  |  | STEREO | IMPACT | SEP Package | SIT | SIT | UMD |  |  |  |
| 8 | 1.1.2.1 | Receive SIT On-Board Software SPEC From UMD |  | 1d | 2002-06-14 A | 2002-06-14 A | 48 | 100% |  | 2002-06-14 | 2002-06-14 | 1d |  |  |  | STEREO | IMPACT | SEP Package | SIT | SIT | GSFC |  |  |  |
| 9 | 1.1.2.2 | Receive SIT ETU Front-End Logic only ACTEL Pinout Definition From GSFC |  | 1d | 2002-10-25 A | 2002-10-25 A | 42 | 100% |  | 2002-10-25 | 2002-10-25 | 1d |  |  | start no earlier than 2002-09-30 | STEREO | IMPACT | SEP Package | SIT | SIT | UMD |  |  |  |
| 10 | 1.1.2.3 | Receive SIT Front-End Logic/MISC ACTEL Pinout Definition From GSFC |  | 1d | 2002-12-20 A | 2002-12-20 A | 43 | 100% |  | 2002-12-20 | 2002-12-20 | 1d |  |  | start no earlier than 2002-11-30 | STEREO | IMPACT | SEP Package | SIT | SIT | GSFC |  |  |  |
| 11 | 1.1.2.4 | Receive SIT ETU Front-End Logic only on ACTEL Chip fromm GSFC |  | 1d | 2002-10-22 A | 2002-10-22 A | 44 | 100% |  | 2002-10-22 | 2002-10-22 | 1d |  |  |  | STEREO | IMPACT | SEP Package | SIT | SIT | UMD |  |  |  |
| 12 | 1.1.2.5 | Receive SIT Prototype Front-End Logic/MISC ACTEL Chip from GSFC |  | 1d | 2003-01-15 A | 2003-01-15 A | 45 | 100% |  | 2003-01-15 | 2003-01-15 | 1d |  |  | start no earlier than 2002-07-01 | STEREO | IMPACT | SEP Package | SIT | SIT | UMD |  |  |  |
| 13 | 1.1.2.6 | Receive SIT Final ACTEL Chip from GSFC | milestone | 0d | 2003-12-15 | 2003-12-15 | 46 |  |  | 2003-08-01 | 2003-08-01 | 0d | 72d | 0d |  | STEREO | IMPACT | SEP Package | SIT | SIT | UMD | Flt. VLSI Chip to SIT |  |  |
| 14 | 1.1.2.7 | Receive SIT S/W for Functional Testing From GSFC | milestone | 0d | 2003-07-11 A | 2003-07-11 A | 51 | 100% |  | 2003-07-11 | 2003-07-11 | 0d |  |  |  | STEREO | IMPACT | SEP Package | SIT | SIT | UMD |  |  |  |
| 15 | 1.1.3.3.9 | Deliver SIT ETU HVPS | milestone | 0d | 2002-10-01 A | 2002-10-01 A |  | 100% |  | 2002-10-01 | 2002-10-01 | 0d |  |  | start no earlier than 2002-09-30 | STEREO | IMPACT | SEP Package | SIT | SIT | UMD |  |  |  |
| 16 | 1.1.2.9 | Receive ETU HVPS From UC-B |  | 1d | 2002-10-01 A | 2002-10-01 A | 15 | 100% |  | 2002-10-01 | 2002-10-01 | 1d |  |  | start no earlier than 2002-09-30 | STEREO | IMPACT | SEP Package | SIT | SIT | UMD |  |  |  |
| 17 | 1.1.3.4.9 | Deliver SIT FM 1 HVPS | milestone | 0d | 2003-11-28 | 2003-11-28 |  |  |  | 2003-09-23 | 2003-09-23 | 0d | 20d | 0d |  | STEREO | IMPACT | SEP Package | SIT | SIT | UMD |  |  |  |
| 18 | 1.1.2.11 | Receive FM 1 HVPS From UC-B | milestone | 0d | 2003-11-28 | 2003-11-28 | 17 |  |  | 2003-09-23 | 2003-09-23 | 0d | 20d | 0d |  | STEREO | IMPACT | SEP Package | SIT | SIT | UMD |  | FM 1 HVPS Available |  |
| 19 | 1.1.3.5.9 | Deliver SIT FM 2 HVPS | milestone | 0d | 2004-01-27 | 2004-01-27 |  |  |  | 2003-11-28 | 2003-11-28 | 0d | 20d | 0d |  | STEREO | IMPACT | SEP Package | SIT | SIT | UMD |  |  |  |
| 20 | 1.1.2.13 | Receive FM 2 HVPS From UC-B | milestone | 0d | 2004-01-27 | 2004-01-27 | 19 |  |  | 2003-11-28 | 2003-11-28 | 0d | 20d | 0d |  | STEREO | IMPACT | SEP Package | SIT | SIT | UMD |  | FM 2 HVPS Available |  |
| 21 | 1.1.2.14 | Receive SIT FM 1 Telescope From GSFC | milestone | 0d | 2004-02-05 | 2004-02-05 | 52 |  |  | 2003-09-09 | 2003-09-09 | 0d | 1d | 0d |  | STEREO | IMPACT | SEP Package | SIT | SIT | UMD |  | FM 1 Telescope Available |  |
| 22 | 1.1.2.15 | Receive SIT FM 2 Telescope From GSFC | milestone | 0d | 2004-02-05 | 2004-02-05 | 53 |  |  | 2003-09-09 | 2003-09-09 | 0d | 21d | 1d |  | STEREO | IMPACT | SEP Package | SIT | SIT | UMD |  | FM 2 Telescope Available |  |
| 23 | 1.1.2.16 | Receive Proto Digital TOF brd From MPAe | milestone | 0d | 2001-01-11 A | 2001-01-11 A |  | 100% |  | 2001-01-11 | 2001-01-11 | 0d |  |  | start no earlier than 2001-11-01 | STEREO | IMPACT | SEP Package | SIT | SIT | UMD |  |  |  |
| 24 | 1.1.2.17 | Receive Proto Analog TOF brd from MPAe | milestone | 0d | 2001-12-17 A | 2001-12-17 A |  | 100% |  | 2001-12-17 | 2001-12-17 | 0d |  |  | start no earlier than 2001-12-17 | STEREO | IMPACT | SEP Package | SIT | SIT | UMD |  |  |  |
| 25 | 1.1.2.18 | Receive FM 1 Digital TOF Boards from MPAe | milestone | 0d | 2002-07-31 A | 2002-07-31 A | 54 | 100% |  | 2002-07-31 | 2002-07-31 | 0d |  |  |  | STEREO | IMPACT | SEP Package | SIT | SIT | UMD |  |  |  |
| 26 | 1.1.2.19 | Receive FM 1 Analog TOF Boards from MPAe | milestone | 0d | 2002-08-30 A | 2002-08-30 A | 55 | 100% |  | 2002-08-30 | 2002-08-30 | 0d |  |  | start no earlier than 2002-08-01 | STEREO | IMPACT | SEP Package | SIT | SIT | UMD |  |  |  |
| 27 | 1.1.2.20 | Receive Remade FM 1 Digital TOF Boards from MPAe | milestone | 0d | 2004-01-05 | 2004-01-05 |  |  |  | 2003-08-18 | 2003-08-18 | 0d | 16d | 0d | start no earlier than 2004-01-05 | STEREO | IMPACT | SEP Package | SIT | SIT | UMD |  | FM 1 Digital TOF Boards Available | SIT - FM 1 Digital TOF Boards Available |
| 28 | 1.1.2.21 | Receive Remade FM 1 Analog TOF Boards from MPAe | milestone | 0d | 2004-01-05 | 2004-01-05 |  |  |  | 2003-08-18 | 2003-08-18 | 0d | 16d | 0d | start no earlier than 2004-01-05 | STEREO | IMPACT | SEP Package | SIT | SIT | UMD |  | FM 1 Analog TOF Boards Available | SIT - FM 1 Analog TOF Boards Available |
| 29 | 1.1.2.22 | Receive FM 2 Digital TOF Boards from MPAe | milestone | 0d | 2004-01-05 | 2004-01-05 | 56 |  |  | 2003-08-29 | 2003-08-29 | 0d | 36d | 11d |  | STEREO | IMPACT | SEP Package | SIT | SIT | UMD |  | FM 2 Digital TOF Boards Available | SIT - FM 2 Digital TOF Boards Available |
| 30 | 1.1.2.23 | Receive FM 2 Analog TOF Boards from MPAe | milestone | 0d | 2004-01-05 | 2004-01-05 | 57 |  |  | 2003-08-29 | 2003-08-29 | 0d | 36d | 11d |  | STEREO | IMPACT | SEP Package | SIT | SIT | UMD |  | FM 2 Analog TOF Boards Available | SIT - FM 2 Analog TOF Boards Available |
| 31 | 1.2.8.1 | Deliver SIT EM Back to UMD | milestone | 0d | 2003-08-01 A | 2003-08-01 A |  | 100% |  | 2003-08-01 | 2003-08-01 | 0d |  |  | start no earlier than 2003-06-30 | STEREO | IMPACT | SEP Package | SIT | SIT | UMD |  |  |  |
| 32 | 1.1.2.25 | Receive SIT EM Back from CIT | milestone | 0d | 2003-08-04 A | 2003-08-04 A | 31FS+5d | 100% |  | 2003-08-04 | 2003-08-04 | 0d |  |  |  | STEREO | IMPACT | SEP Package | SIT | SIT | UMD |  |  |  |
| 33 | 1.1.37 | IMPACT Suite FM 1 EMC Testing Complete | milestone | 0d | 2004-05-28 | 2004-05-28 |  |  |  |  |  |  | 0d |  |  | STEREO | IMPACT | SEP Package | SIT | SIT | UMD |  |  |  |
| 34 | 1.1.2.27 | Receive SIT FM 1 back from IMPACT Suite EMC |  | 3d | 2004-06-01 | 2004-06-03 | 33 |  |  |  |  |  | 0d |  |  | STEREO | IMPACT | SEP Package | SIT | SIT | UMD |  |  |  |
| 35 | 2.4.16 | SEP FM 2 system test |  | 1d | 2004-05-17 | 2004-05-17 |  |  |  |  |  |  | 9d | 0d |  | STEREO | IMPACT | SEP Package | SIT | SIT | UMD |  |  |  |
| 36 | 1.1.2.29 | Receive SIT FM 2 back from Initial SEP I&T |  | 3d | 2004-05-18 | 2004-05-20 | 35 |  |  |  |  |  | 9d |  |  | STEREO | IMPACT | SEP Package | SIT | SIT | UMD |  |  |  |

Notes:
- 4: March 03 Status - Dropped contingency from 2 days to 0 days.
- 6: Removed 33 days of duration 1/9/03
- 20: Successor is 259 flat
- 27: The original plan was for 7/21/03. Now expected by mid August. Set new constraint date to mid August 8/18. / As of 11/3/03 the board is still not complete because of parts issues (commercial ACTEL). New completion date is estimated at mid December 2003.
- 28: The original plan was for 7/21/03. Now expected by mid August. Set new constraint date to mid August, 8/18. / As of 11/3/03 the board is still not complete because of parts issues. New completion date is estimated at mid December 2003.
- 29: The original plan was for 7/21/03. Now expected by mid August. Set new constraint date to mid August. / As of 11/3/03 the board is still not complete because of parts issues (commercial ACTEL). New completion date is estimated at mid December 2003.
- 30: The original plan was for 7/21/03. Now expected by mid August. Set new constraint date to mid August. / As of 11/3/03 the board is still not complete because of parts issues. New completion date is estimated at mid December 2003.

| ID | WBS | Task | Type | Duration | Start | Finish | Predecessors | Complete | Remaining | Baseline start | Baseline finish | Baseline duration | Total slack | Free slack | Constraint | Text11 | Text12 | Text13 | Text14 | Text16 | Text28 | Text19 | Text20 | Text22 | Text23 | Text21 |
| --- | --- | --- | --- | --- | --- | --- | --- | --- | --- | --- | --- | --- | --- | --- | --- | --- | --- | --- | --- | --- | --- | --- | --- | --- | --- | --- |
| 37 | 1.1.3 | **Deliverables** |  | 684d | 2001-10-16 A | 2004-07-06 |  | 60% | 273.6d | 2001-10-16 | 2004-03-12 | 603d | 19d |  |  | STEREO | IMPACT | SEP Package | SIT | SIT | UMD |  |  |  |  |  |
| 38 | 1.1.3.1 | Deliver SIT ETU/SIT HVPS ETU I/F Test Results to UC-B |  | 1d | 2002-10-16 A | 2002-10-16 A | 318 | 100% |  | 2002-10-16 | 2002-10-16 | 1d |  |  |  | STEREO | IMPACT | SEP Package | SIT | SIT | UMD |  |  |  |  |  |
| 39 | 1.1.3.2 | Deliver SIT ETU / SIT HVPS FM 1 I/F Test Results to UC-B | milestone | 0d | 2003-12-05 | 2003-12-05 | 294 |  |  | 2003-09-30 | 2003-09-30 | 0d | 20d | 0d |  | STEREO | IMPACT | SEP Package | SIT | SIT | UMD |  |  |  |  |  |
| 40 | 1.1.2.11 | Receive SIT HVPS FM 1/SIT ETU I/F Test Results from UMD | milestone | 0d | 2003-12-05 | 2003-12-05 | 39 |  |  | 2003-09-30 | 2003-09-30 | 0d | 20d | 0d |  | STEREO | IMPACT | SEP Package | SIT | SIT | UMD |  |  |  |  |  |
| 41 | 1.1.2.2 | Receive SIT HVPS ETU/SIT ETU I/F Test Results from UMD | milestone | 0d | 2002-10-17 A | 2002-10-17 A | 38 | 100% |  | 2002-10-17 | 2002-10-17 | 0d |  |  |  | STEREO | IMPACT | SEP Package | SIT | SIT | UMD |  |  |  |  |  |
| 42 | 1.1.3.5 | Deliver SIT ETU Front-End Logic only ACTEL Pinout Defintion to UMD | milestone | 0d | 2002-10-25 A | 2002-10-25 A | 136SS+5d | 100% |  | 2002-10-25 | 2002-10-25 | 0d |  |  | start no earlier than 2002-09-30 | STEREO | IMPACT | SEP Package | SIT | SIT | UMD |  |  |  |  |  |
| 43 | 1.1.3.6 | Deliver SIT Front-End Logic/MISC ACTEL Pinout Defintion to UMD |  | 1d | 2002-12-20 A | 2002-12-20 A | 138SS+5d | 100% |  | 2002-12-20 | 2002-12-20 | 1d |  |  | start no earlier than 2002-11-30 | STEREO | IMPACT | SEP Package | SIT | SIT | UMD |  |  |  |  |  |
| 44 | 1.1.3.7 | Deliver SIT ETU Front-End Logic only ACTEL Chip to UMD | milestone | 0d | 2002-10-22 A | 2002-10-22 A | 137 | 100% |  | 2002-10-22 | 2002-10-22 | 0d |  |  |  | STEREO | IMPACT | SEP Package | SIT | SIT | UMD |  |  |  |  |  |
| 45 | 1.1.3.8 | Deliver SIT Prototype Front-End Logic/MISC ACTEL Chip to UMD |  | 1d | 2003-01-15 A | 2003-01-15 A | 139 | 100% |  | 2003-01-15 | 2003-01-15 | 1d |  |  | start no earlier than 2002-07-01 | STEREO | IMPACT | SEP Package | SIT | SIT | GSFC |  |  |  |  |  |
| 46 | 1.1.3.9 | Deliver SIT Final ACTEL Chip to UMD | milestone | 0d | 2003-12-15 | 2003-12-15 | 142 |  |  | 2003-08-01 | 2003-08-01 | 0d | 72d | 0d |  | STEREO | IMPACT | SEP Package | SIT | SIT | GSFC |  |  |  |  |  |
| 47 | 1.1.3.10 | Deliver SIT Front-End Logic Design to GSFC |  | 1d | 2001-10-16 A | 2001-10-16 A |  | 100% |  | 2001-10-16 | 2001-10-16 | 1d |  |  | start no earlier than 2001-12-20 | STEREO | IMPACT | SEP Package | SIT | SIT | UMD |  |  |  |  |  |
| 48 | 1.1.3.11 | Deliver SIT On-Board Software SPEC to GSFC |  | 1d | 2002-06-14 A | 2002-06-14 A |  | 100% |  | 2002-06-14 | 2002-06-14 | 1d |  |  | start no earlier than 2002-03-01 | STEREO | IMPACT | SEP Package | SIT | SIT | UMD |  |  |  |  |  |
| 49 | 1.1.3.12 | Delivery SIT S/W to CIT for SEP Central I/F Testing | milestone | 0d | 2003-07-23 A | 2003-07-23 A | 6 | 100% |  | 2003-07-23 | 2003-07-23 | 0d |  |  |  | STEREO | IMPACT | SEP Package | SIT | SIT | UMD |  |  |  |  |  |
| 50 | 1.1.7.3.2 | (OBSOLETE) Receive SIT S/W for SEP Central I/F Testing |  | 21d | 2003-05-30 A | 2003-06-30 A | 49 | 100% |  | 2003-05-30 | 2003-06-30 | 21d |  |  |  | STEREO | IMPACT | SEP Package | SIT | SIT | UMD |  |  |  |  |  |
| 51 | 1.1.3.14 | Delivery SIT S/W to UMD for Functional Testing | milestone | 0d | 2003-07-18 A | 2003-07-18 A | 314 | 100% |  | 2003-07-18 | 2003-07-18 | 0d |  |  |  | STEREO | IMPACT | SEP Package | SIT | SIT | UMD |  |  |  |  |  |
| 52 | 1.1.3.15 | Deliver SIT FM 1 Telescope Assembly to UMD | milestone | 0d | 2004-02-05 | 2004-02-05 | 98 |  |  | 2003-09-09 | 2003-09-09 | 0d | 1d | 0d |  | STEREO | IMPACT | SEP Package | SIT | SIT | GSFC | Sandy Shuman |  |  |  |  |
| 53 | 1.1.3.16 | Delivery SIT FM 2 Telescope Assembly to UMD | milestone | 0d | 2004-02-05 | 2004-02-05 | 100 |  |  | 2003-09-09 | 2003-09-09 | 0d | 21d | 0d |  | STEREO | IMPACT | SEP Package | SIT | SIT | GSFC | Sandy Shuman |  |  |  |  |
| 54 | 1.1.3.17 | Delivery FM 1 Digital TOF Boards to UMD | milestone | 0d | 2002-07-31 A | 2002-07-31 A | 179 | 100% |  | 2002-07-31 | 2002-07-31 | 0d |  |  |  | STEREO | IMPACT | SEP Package | SIT | SIT | MP |  |  |  |  |  |
| 55 | 1.1.3.18 | Delivery FM 1 Analog TOF Boards to UMD |  | 1d | 2002-08-30 A | 2002-08-30 A | 180 | 100% |  | 2002-08-30 | 2002-08-30 | 1d |  |  |  | STEREO | IMPACT | SEP Package | SIT | SIT | MP |  |  |  |  |  |
| 56 | 1.1.3.19 | Delivery FM 2 Digital TOF Boards to UMD | milestone | 0d | 2004-01-05 | 2004-01-05 | 179FS+20d |  |  | 2003-08-29 | 2003-08-29 | 0d | 36d | 0d | start no earlier than 2004-01-05 | STEREO | IMPACT | SEP Package | SIT | SIT | MP |  |  |  |  |  |
| 57 | 1.1.3.20 | Delivery FM 2 Analog TOF Boards to UMD | milestone | 0d | 2004-01-05 | 2004-01-05 | 180FS+20d |  |  | 2003-08-29 | 2003-08-29 | 0d | 36d | 0d | start no earlier than 2004-01-05 | STEREO | IMPACT | SEP Package | SIT | SIT | MP |  |  |  |  |  |
| 58 | 1.1.3.21 | Deliver SIT EM to CIT | milestone | 0d | 2003-07-21 A | 2003-07-21 A |  | 100% |  | 2003-07-21 | 2003-07-21 | 0d |  |  | must start on 2003-06-13 | STEREO | IMPACT | SEP Package | SIT | SIT | UMD |  | SIT EM | SIT - Deliver EM to CIT | Deliver EM for SEP EM I & T |  |
| 59 | 1.2.7.6.2 | Receive SIT EM From UMD For SEP EM I & T | milestone | 0d | 2003-07-23 A | 2003-07-23 A | 58FS+5d | 100% |  | 2003-07-23 | 2003-07-23 | 0d |  |  | start no earlier than 2003-06-30 | STEREO | IMPACT | SEP Package | SIT | SIT | UMD |  |  |  |  |  |
| 60 | 1.1.3.23 | Deliver SIT FM 1 to CIT For SEP I & T and Suite EMC | milestone | 0d | 2004-04-26 | 2004-04-26 | 323 |  |  | 2004-03-02 | 2004-03-02 | 0d | 7d | 0d |  | STEREO | IMPACT | SEP Package | SIT | SIT | UMD |  | SIT FM 1 | SIT - FM 1 Delivery to CIT For SEP I & T | Deliver FM 1 for SEP I & T | SIT FM 1 & FM 2 to CIT |
| 61 | 1.1.3.24 | Final Delivery of SIT FM 1 to CIT |  | 3d | 2004-07-01 | 2004-07-06 | 353 |  |  |  |  |  | 0d |  |  | STEREO | IMPACT | SEP Package | SIT | SIT | UMD |  |  |  |  |  |
| 62 | 4.3.3 | FM 1 LET/HET/SIT/SEPT/SEP Central Thermal Balance Test |  | 5d | 2004-07-07 | 2004-07-13 | 61 |  |  |  |  |  | 0d |  |  | STEREO | IMPACT | SEP Package | SIT | SIT | UMD |  |  |  |  |  |
| 63 | 1.2.7.6.4 | Receive SIT FM 1 From UMD For SEP FM 1 I & T | milestone | 0d | 2004-04-29 | 2004-04-29 | 60FS+3d |  |  | 2004-03-09 | 2004-03-09 | 0d | 7d | 0d |  | STEREO | IMPACT | SEP Package | SIT | SIT | UMD |  |  |  |  |  |
| 64 | 1.1.3.27 | Deliver SIT FM 2 to CIT For SEP I & T | milestone | 0d | 2004-05-06 | 2004-05-06 | 328 |  |  | 2004-03-12 | 2004-03-12 | 0d | 0d |  |  | STEREO | IMPACT | SEP Package | SIT | SIT | UMD |  | SIT FM 2 | SIT - FM 2 Delivery to CIT For SEP I & T | Deliver FM 2 for SEP I & T | SIT FM 1 & FM 2 to CIT |
| 65 | 1.1.3.28 | Final Delivery of SIT FM 2 to CIT |  | 1d | 2004-07-01 | 2004-07-01 | 353 |  |  |  |  |  | 21d | 2d |  | STEREO | IMPACT | SEP Package | SIT | SIT | UMD |  |  |  |  |  |
| 66 | 4.4.4 | FM 2 LET/HET/SIT/SEPT/SEP Central Thermal Balance Test |  | 5d | 2004-07-07 | 2004-07-13 | 65 |  |  |  |  |  | 26d | 0d |  | STEREO | IMPACT | SEP Package | SIT | SIT | UMD |  |  |  |  |  |
| 67 | 1.2.7.6.6 | Receive SIT FM 2 From UMD For SEP FM 2 I & T | milestone | 0d | 2004-05-11 | 2004-05-11 | 64FS+3d |  |  | 2004-03-19 | 2004-03-19 | 0d | 9d | 0d |  | STEREO | IMPACT | SEP Package | SIT | SIT | UMD |  |  |  |  |  |

Notes:
- 58: Need to setup a return for this and all other ETU/EMs
- 60: FNL of 1/6/04 removed 1/9/03
- 64: FNL of 1/6/04 removed 1/9/03

| ID | WBS | Task | Duration | Start | Finish | Predecessors | Complete | Baseline start | Baseline finish | Baseline duration | Total slack | Free slack | Constraint | Text11 | Text12 | Text13 | Text14 | Text16 | Text28 | Text19 | Text23 |
| --- | --- | --- | --- | --- | --- | --- | --- | --- | --- | --- | --- | --- | --- | --- | --- | --- | --- | --- | --- | --- | --- |
| 68 | 1.2 | **Documentation** | 3d | 2002-02-26 A | 2002-02-28 A |  | 100% | 2002-02-26 | 2002-02-28 | 3d |  |  |  | STEREO | IMPACT | SEP Package | SIT | SIT | UMD |  |  |
| 69 | 1.2.1 | Update Front-End Logic Requirements | 3d | 2002-02-26 A | 2002-02-28 A | 194 | 100% | 2002-02-26 | 2002-02-28 | 3d |  |  |  | STEREO | IMPACT | SEP Package | SIT | SIT | UMD |  |  |
| 70 | 2 | **Systems Engineering** | 622.2d | 2000-09-05 A | 2003-03-03 A |  | 100% | 2000-09-05 | 2003-03-03 | 622.2d |  |  |  | STEREO | IMPACT | SEP Package | SIT | SIT | UMD |  |  |
| 71 | 2.1 | **Documentation** | 387.2d | 2001-08-13 A | 2003-03-03 A |  | 100% | 2001-08-13 | 2003-03-03 | 387.2d |  |  |  | STEREO | IMPACT | SEP Package | SIT | SIT | UMD |  |  |
| 72 | 2.1.1 | SIT ICD Drawings | 60d | 2001-08-13 A | 2001-11-06 A | 75 | 100% | 2001-08-13 | 2001-11-06 | 60d |  |  |  | STEREO | IMPACT | SEP Package | SIT | SIT | UMD |  |  |
| 73 | 2.1.2 | Generate Energy Board Parts List | 2d | 2002-10-01 A | 2003-03-03 A | 198 | 100% | 2002-10-01 | 2003-03-03 | 2d |  |  | start no earlier than 2002-09-30 | STEREO | IMPACT | SEP Package | SIT | SIT | UMD |  |  |
| 74 | 2.2 | **Studies** | 528d | 2000-09-05 A | 2002-10-11 A |  | 100% | 2000-09-05 | 2002-10-11 | 528d |  |  |  | STEREO | IMPACT | SEP Package | SIT | SIT | UMD |  |  |
| 75 | 2.2.1 | Fields of View Analysis | 235d | 2000-09-05 A | 2001-08-10 A |  | 100% | 2000-09-05 | 2001-08-10 | 235d |  |  | start no earlier than 2000-09-05 | STEREO | IMPACT | SEP Package | SIT | SIT | UMD |  |  |
| 76 | 2.2.2 | Study SIT Front-End Logic Design | 8d | 2002-10-01 A | 2002-10-11 A | 47 | 100% | 2002-10-01 | 2002-10-11 | 8d |  |  | start no earlier than 2002-09-30 | STEREO | IMPACT | SEP Package | SIT | SIT | UMD |  |  |
| 77 | 3 | **Structure** | 76d | 2003-11-07 | 2004-02-27 |  |  | 2002-09-03 | 2003-12-12 | 321d | 1d |  |  | STEREO | IMPACT | SEP Package | SIT | SIT | GSFC |  |  |
| 78 | 3.1 | **Design, Manufacture, Assembly and Test** | 76d | 2003-11-07 | 2004-02-27 |  |  | 2002-09-03 | 2003-12-12 | 321d | 1d |  |  | STEREO | IMPACT | SEP Package | SIT | SIT | GSFC |  |  |
| 79 | 3.1.1 | **Design** | 42d | 2003-11-07 | 2004-01-08 |  |  | 2002-09-03 | 2003-07-16 | 217.5d | 1d |  |  | STEREO | IMPACT | SEP Package | SIT | SIT | GSFC |  |  |
| 80 | 3.1.1.1 | Modify/Complete SIT Electronics Enclosure Design | 10d | 2003-11-07 | 2003-11-20 |  |  | 2002-09-03 | 2003-07-16 | 21d | 1d | 0d | start no earlier than 2003-11-07 | STEREO | IMPACT | SEP Package | SIT | SIT | GSFC | Sandy Shuman |  |
| 81 | 3.1.2.2 | Complete Design of HET Housing | 5d | 2003-11-21 | 2003-11-28 | 80 |  |  |  |  | 1d | 0d |  | STEREO | IMPACT | SEP Package | SIT | SIT | UMD |  |  |
| 82 | 3.1.1.1 | Place Order For HET EM Housing | 2d | 2003-12-01 | 2003-12-02 |  |  |  |  |  | 1d | 0d |  | STEREO | IMPACT | SEP Package | SIT | SIT | UMD |  |  |
| 83 | 3.1.1.4 | Modify/Complete SIT Housing Design | 10d | 2003-12-03 | 2003-12-16 | 82 |  | 2002-09-03 | 2003-07-16 | 21d | 1d | 0d |  | STEREO | IMPACT | SEP Package | SIT | SIT | GSFC | Sandy Shuman |  |
| 84 | 3.1.1.2 | Complete Design of SEP Common Electronics Enclosure | 5d | 2003-12-17 | 2003-12-23 | 83 |  |  |  |  | 60d | 0d |  | STEREO | IMPACT | SEP Package | SIT | SIT | UMD |  |  |
| 85 | 3.1.1.6 | Complete SIT Doors Design | 10d | 2003-12-24 | 2004-01-08 | 84 |  | 2002-09-03 | 2003-07-09 | 21d | 96d | 19d |  | STEREO | IMPACT | SEP Package | SIT | SIT | GSFC | Sandy Shuman |  |
| 86 | 3.1.2 | **Fabrication** | 66d | 2003-11-21 | 2004-02-27 |  |  | 2003-07-16 | 2003-10-07 | 57d | 18d |  |  | STEREO | IMPACT | SEP Package | SIT | SIT | GSFC |  |  |
| 87 | 3.1.2.1 | **FM 1 & FM 2** | 66d | 2003-11-21 | 2004-02-27 |  |  | 2003-07-16 | 2003-10-07 | 57d | 18d |  |  | STEREO | IMPACT | SEP Package | SIT | SIT | GSFC |  |  |
| 88 | 3.1.2.1.1 | **FM 1** | 66d | 2003-11-21 | 2004-02-27 |  |  | 2003-07-16 | 2003-10-07 | 57d | 18d |  |  | STEREO | IMPACT | SEP Package | SIT | SIT | GSFC |  |  |
| 89 | 3.1.2.1.1.1 | Fabricate SIT FM 1 Electronics Enclosure | 15d | 2003-11-21 | 2003-12-12 | 80 |  | 2003-07-16 | 2003-08-12 | 19d | 18d | 17d |  | STEREO | IMPACT | SEP Package | SIT | SIT | GSFC | Sandy Shuman | FM 1 Housing Fabricated |
| 90 | 3.1.2.1.1.2 | Fabricate SIT FM 1 Housing | 15d | 2003-12-17 | 2004-01-08 | 83 |  | 2003-07-16 | 2003-08-12 | 19d | 1d | 0d |  | STEREO | IMPACT | SEP Package | SIT | SIT | GSFC | Sandy Shuman | FM 1 Door Fabricated |
| 91 | 3.1.2.1.1.3 | Fabricate SIT FM 1 Doors | 15d | 2004-02-06 | 2004-02-27 | 98, 85 |  | 2003-09-09 | 2003-10-07 | 19d | 77d |  |  | STEREO | IMPACT | SEP Package | SIT | SIT | GSFC | Sandy Shuman | FM 1 Electronics Enclosure Fabricated |

| ID | WBS | Task | Type | Duration | Start | Finish | Predecessors | Complete | Remaining | Baseline start | Baseline finish | Baseline duration | Total slack | Free slack | Constraint | Text11 | Text12 | Text13 | Text14 | Text16 | Text28 | Text19 | Text23 |
| --- | --- | --- | --- | --- | --- | --- | --- | --- | --- | --- | --- | --- | --- | --- | --- | --- | --- | --- | --- | --- | --- | --- | --- |
| 92 | 3.1.2.1.2 | **FM 2** |  | 66d | 2003-11-21 | 2004-02-27 |  |  |  | 2003-07-16 | 2003-10-07 | 57d | 38d |  |  | STEREO | IMPACT | SEP Package | SIT | SIT | GSFC |  |  |
| 93 | 3.1.2.1.2.1 | Fabricate SIT FM 2 Electronics Enclosure |  | 15d | 2003-11-21 | 2003-12-12 | 80 |  |  | 2003-07-16 | 2003-08-12 | 19d | 38d | 17d |  | STEREO | IMPACT | SEP Package | SIT | SIT | GSFC | Sandy Shuman | FM 2 Housing Fabricated |
| 94 | 3.1.2.1.2.2 | Fabricate SIT FM 2 Housing |  | 15d | 2003-12-17 | 2004-01-08 | 83 |  |  | 2003-07-16 | 2003-08-12 | 19d | 21d | 0d |  | STEREO | IMPACT | SEP Package | SIT | SIT | GSFC | Sandy Shuman | FM 2 Door Fabricated |
| 95 | 3.1.2.1.2.3 | Fabricate SIT FM 2 Doors |  | 15d | 2004-02-06 | 2004-02-27 | 100, 85 |  |  | 2003-09-09 | 2003-10-07 | 19d | 77d |  |  | STEREO | IMPACT | SEP Package | SIT | SIT | GSFC | Sandy Shuman | FM 2 Electronics Enclosure Fabricated |
| 96 | 3.1.3 | **Assembly** |  | 19d | 2004-01-09 | 2004-02-05 |  |  |  | 2003-08-12 | 2003-09-09 | 19d | 1d |  |  | STEREO | IMPACT | SEP Package | SIT | SIT | GSFC |  |  |
| 97 | 3.1.3.1 | **FM 1** |  | 19d | 2004-01-09 | 2004-02-05 |  |  |  | 2003-08-12 | 2003-09-09 | 19d | 1d |  |  | STEREO | IMPACT | SEP Package | SIT | SIT | GSFC |  |  |
| 98 | 3.1.3.1.1 | Assemble SIT FM 1 Telescope |  | 19d | 2004-01-09 | 2004-02-05 | 89, 90 |  |  | 2003-08-12 | 2003-09-09 | 19d | 1d | 0d |  | STEREO | IMPACT | SEP Package | SIT | SIT | GSFC | Sandy Shuman | FM 1 Telescope Assembled |
| 99 | 3.1.3.2 | **FM 2** |  | 19d | 2004-01-09 | 2004-02-05 |  |  |  | 2003-08-12 | 2003-09-09 | 19d | 21d |  |  | STEREO | IMPACT | SEP Package | SIT | SIT | GSFC |  |  |
| 100 | 3.1.3.2.1 | Assemble SIT FM 2 Telescope |  | 19d | 2004-01-09 | 2004-02-05 | 93, 94 |  |  | 2003-08-12 | 2003-09-09 | 19d | 21d | 0d |  | STEREO | IMPACT | SEP Package | SIT | SIT | GSFC | Sandy Shuman | FM 2 Telescope Assembled |
| 101 | 3.1.4 | **Test** |  | 3d | 2004-02-06 | 2004-02-10 |  |  |  | 2003-10-07 | 2003-12-12 | 47d | 1d |  |  | STEREO | IMPACT | SEP Package | SIT | SIT | GSFC |  |  |
| 102 | 3.1.4.1 | **FM 1** |  | 2d | 2004-02-06 | 2004-02-09 |  |  |  | 2003-10-07 | 2003-10-08 | 2d | 1d |  |  | STEREO | IMPACT | SEP Package | SIT | SIT | GSFC |  |  |
| 103 | 3.1.4.1.1 | Inspect/Test Fit SIT FM 1 Housing |  | 2d | 2004-02-06 | 2004-02-09 | 21, 330 |  |  | 2003-10-07 | 2003-10-08 | 2d | 1d | 0d |  | STEREO | IMPACT | SEP Package | SIT | SIT | GSFC |  | FM 1 Telescope Fit Tested |
| 104 | 3.1.4.2 | **FM 2** |  | 2d | 2004-02-09 | 2004-02-10 |  |  |  | 2003-12-11 | 2003-12-12 | 2d | 20d |  |  | STEREO | IMPACT | SEP Package | SIT | SIT | GSFC |  |  |
| 105 | 3.1.4.2.1 | Inspect/Test Fit SIT FM 2 Housing |  | 2d | 2004-02-09 | 2004-02-10 | 22, 339 |  |  | 2003-12-11 | 2003-12-12 | 2d | 20d | 0d |  | STEREO | IMPACT | SEP Package | SIT | SIT | GSFC |  | FM 2 Telescope Fit Tested |
| 106 | 4 | **Detectors** |  | 393d | 2002-08-01 A | 2004-02-25 |  | 32% | 265.54d | 2002-08-01 | 2003-12-29 | 353d | 111d |  |  | STEREO | IMPACT | SEP Package | SIT | SIT | UMD |  |  |
| 107 | 4.1 | **Design, Manufacture, Assembly and Test** |  | 393d | 2002-08-01 A | 2004-02-25 |  | 32% | 265.54d | 2002-08-01 | 2003-12-29 | 353d | 111d |  |  | STEREO | IMPACT | SEP Package | SIT | SIT | UMD |  |  |
| 108 | 4.1.1 | **Procurements** |  | 126d | 2002-08-01 A | 2003-02-03 A |  | 100% |  | 2002-08-01 | 2003-02-03 | 126d |  |  |  | STEREO | IMPACT | SEP Package | SIT | SIT | UMD |  |  |
| 109 | 4.1.1.1 | **FM 1 & FM 2** |  | 126d | 2002-08-01 A | 2003-02-03 A |  | 100% |  | 2002-08-01 | 2003-02-03 | 126d |  |  |  | STEREO | IMPACT | SEP Package | SIT | SIT | UMD |  |  |
| 110 | 4.1.1.1.1 | Order Flight Micro Channel Plates |  | 1d | 2002-08-01 A | 2002-08-01 A | 115SF | 100% |  | 2002-08-01 | 2002-08-01 | 1d |  |  | start no earlier than 2002-07-31 | STEREO | IMPACT | SEP Package | SIT | SIT | UMD |  |  |
| 111 | 4.1.1.1.2 | Order Flight Solid State Detectors |  | 1d | 2002-08-01 A | 2002-08-01 A | 116SF | 100% |  | 2002-08-01 | 2002-08-01 | 1d |  |  | start no earlier than 2002-07-31 | STEREO | IMPACT | SEP Package | SIT | SIT | UMD |  |  |
| 112 | 4.1.1.1.3 | Order Flight Foils | milestone | 0d | 2003-02-03 A | 2003-02-03 A | 117SF | 100% |  | 2003-02-03 | 2003-02-03 | 0d |  |  | start no earlier than 2003-03-01 | STEREO | IMPACT | SEP Package | SIT | SIT | UMD |  |  |
| 113 | 4.1.2 | **Fabrication** |  | 12d | 2003-03-14 A | 2003-03-31 A |  | 100% |  | 2003-03-14 | 2003-03-31 | 12d |  |  |  | STEREO | IMPACT | SEP Package | SIT | SIT | UMD |  |  |
| 114 | 4.1.2.1 | **FM 1 & FM 2** |  | 12d | 2003-03-14 A | 2003-03-31 A |  | 100% |  | 2003-03-14 | 2003-03-31 | 12d |  |  |  | STEREO | IMPACT | SEP Package | SIT | SIT | UMD |  |  |
| 115 | 4.1.2.1.1 | Receive & Inspect FM 1 & FM 2 Micro Channel Plates |  | 2d | 2003-03-14 A | 2003-03-17 A | 125SF, 120SF | 100% |  | 2003-03-14 | 2003-03-17 | 2d |  |  | start no earlier than 2003-02-01 | STEREO | IMPACT | SEP Package | SIT | SIT | UMD |  |  |
| 116 | 4.1.2.1.2 | Receive & Inspect FM 1 & FM 2 Solid State Detectors |  | 2d | 2003-03-28 A | 2003-03-31 A | 126SF, 121SF | 100% |  | 2003-03-28 | 2003-03-31 | 2d |  |  | start no earlier than 2003-03-01 | STEREO | IMPACT | SEP Package | SIT | SIT | UMD |  |  |
| 117 | 4.1.2.1.3 | Receive & Inspect FM 1 & FM 2 Foils |  | 2d | 2003-03-28 A | 2003-03-31 A | 127SF, 122SF | 100% |  | 2003-03-28 | 2003-03-31 | 2d |  |  | start no earlier than 2003-03-01 | STEREO | IMPACT | SEP Package | SIT | SIT | UMD |  |  |

| ID | WBS | Task | Duration | Start | Finish | Predecessors | Complete | Remaining | Baseline start | Baseline finish | Baseline duration | Total slack | Free slack | Constraint | Text11 | Text12 | Text13 | Text14 | Text16 | Text28 |
| --- | --- | --- | --- | --- | --- | --- | --- | --- | --- | --- | --- | --- | --- | --- | --- | --- | --- | --- | --- | --- |
| 118 | 4.1.3 | **Test** | 126d | 2003-08-25 A | 2004-02-25 |  | 29% | 90d | 2003-03-18 | 2003-12-29 | 198d | 111d |  |  | STEREO | IMPACT | SEP Package | SIT | SIT | UMD |
| 119 | 4.1.3.1 | **FM 1** | 125d | 2003-08-25 A | 2004-02-24 |  | 29% | 89.29d | 2003-03-18 | 2003-10-22 | 153d | 112d |  |  | STEREO | IMPACT | SEP Package | SIT | SIT | UMD |
| 120 | 4.1.3.1.1 | Test FM 1 Micro Channel Plates | 20d | 2003-08-25 A | 2003-09-22 A |  | 100% |  | 2003-03-18 | 2003-09-22 | 20d |  |  | start no earlier than 2003-08-25 | STEREO | IMPACT | SEP Package | SIT | SIT | UMD |
| 121 | 4.1.3.1.2 | Test FM 1 Solid States Detectors | 20d | 2003-11-05 | 2003-12-03 |  |  |  | 2003-07-28 | 2003-08-25 | 20d | 167d | 0d | start no earlier than 2003-11-05 | STEREO | IMPACT | SEP Package | SIT | SIT | UMD |
| 122 | 4.1.3.1.3 | Test FM 1 Foils | 20d | 2003-11-05 | 2003-12-03 | 121SS |  |  | 2003-07-28 | 2003-08-25 | 20d | 167d |  |  | STEREO | IMPACT | SEP Package | SIT | SIT | UMD |
| 123 | 4.1.3.1.4 | Alpha Tests FM 1 w/Proto Elect | 10d | 2004-02-10 | 2004-02-24 | 103 |  |  | 2003-10-09 | 2003-10-22 | 10d | 112d |  |  | STEREO | IMPACT | SEP Package | SIT | SIT | UMD |
| 124 | 4.1.3.2 | **FM 2** | 126d | 2003-08-25 A | 2004-02-25 |  | 29% | 90d | 2003-03-18 | 2003-12-29 | 198d | 111d |  |  | STEREO | IMPACT | SEP Package | SIT | SIT | UMD |
| 125 | 4.1.3.2.1 | Test FM 2 Micro Channel Plates | 20d | 2003-08-25 A | 2003-09-22 A |  | 100% |  | 2003-03-18 | 2003-09-22 | 20d |  |  | start no earlier than 2003-08-25 | STEREO | IMPACT | SEP Package | SIT | SIT | UMD |
| 126 | 4.1.3.2.2 | Test FM 2 Solid States Detectors | 20d | 2003-11-05 | 2003-12-03 |  |  |  | 2003-07-28 | 2003-08-25 | 20d | 167d | 0d | start no earlier than 2003-11-05 | STEREO | IMPACT | SEP Package | SIT | SIT | UMD |
| 127 | 4.1.3.2.3 | Test FM 2 Foils | 20d | 2003-11-05 | 2003-12-03 | 126SS |  |  | 2003-07-28 | 2003-08-25 | 20d | 167d |  |  | STEREO | IMPACT | SEP Package | SIT | SIT | UMD |
| 128 | 4.1.3.2.4 | Alpha Tests FM 2 w/Proto Elect | 10d | 2004-02-11 | 2004-02-25 | 105 |  |  | 2003-12-15 | 2003-12-29 | 10d | 111d |  |  | STEREO | IMPACT | SEP Package | SIT | SIT | UMD |
| 129 | 5 | **ACTEL** | 304d | 2002-10-15 A | 2003-12-30 |  | 85% | 45.81d | 2002-10-15 | 2003-09-15 | 231d | 72d |  |  | STEREO | IMPACT | SEP Package | SIT | SIT | UMD |
| 130 | 5.1 | **Design, Manufacture, Assembly and Test** | 304d | 2002-10-15 A | 2003-12-30 |  | 85% | 45.81d | 2002-10-15 | 2003-09-15 | 231d | 72d |  |  | STEREO | IMPACT | SEP Package | SIT | SIT | UMD |
| 131 | 5.1.1 | **Design** | 15d | 2003-07-02 A | 2003-07-24 A |  | 100% |  | 2003-07-02 | 2003-07-24 | 15d |  |  |  | STEREO | IMPACT | SEP Package | SIT | SIT | UMD |
| 132 | 5.1.1.1 | **FM 1 & FM 2** | 15d | 2003-07-02 A | 2003-07-24 A |  | 100% |  | 2003-07-02 | 2003-07-24 | 15d |  |  |  | STEREO | IMPACT | SEP Package | SIT | SIT | UMD |
| 133 | 5.1.1.1.1 | Finalize Design of SIT ACTEL Chip | 15d | 2003-07-02 A | 2003-07-24 A | 145 | 100% |  | 2003-07-02 | 2003-07-24 | 15d |  |  | start no earlier than 2003-05-31 | STEREO | IMPACT | SEP Package | SIT | SIT | GSFC |
| 134 | 5.1.2 | **Fabrication** | 294d | 2002-10-15 A | 2003-12-15 |  | 97% | 9.19d | 2002-10-15 | 2003-08-01 | 200.6d | 72d |  |  | STEREO | IMPACT | SEP Package | SIT | SIT | UMD |
| 135 | 5.1.2.1 | **ETU** | 62d | 2002-10-15 A | 2003-01-15 A |  | 100% |  | 2002-10-15 | 2003-01-15 | 62d |  |  |  | STEREO | IMPACT | SEP Package | SIT | SIT | GSFC |
| 136 | 5.1.2.1.1 | Implement SIT Front-End Logic only on ACTEL Chip | 5d | 2002-10-15 A | 2002-10-21 A | 76 | 100% |  | 2002-10-15 | 2002-10-21 | 5d |  |  | start no earlier than 2002-09-30 | STEREO | IMPACT | SEP Package | SIT | SIT | UMD |
| 137 | 5.1.2.1.2 | Burn SIT ETU Front-End Logic only on ACTEL Chip | 1d | 2002-10-22 A | 2002-10-22 A | 136 | 100% |  | 2002-10-22 | 2002-10-22 | 1d |  |  |  | STEREO | IMPACT | SEP Package | SIT | SIT | UMD |
| 138 | 5.1.2.1.3 | Implement SIT Front-End Logic/MISC on ACTEL Chip | 19d | 2002-12-16 A | 2003-01-14 A | 256SS+5d | 100% |  | 2002-12-16 | 2003-01-14 | 19d |  |  | start no earlier than 2002-11-30 | STEREO | IMPACT | SEP Package | SIT | SIT | GSFC |
| 139 | 5.1.2.1.4 | Burn SIT Prototype Front-End Logic/MISC on ACTEL Chip | 1d | 2003-01-15 A | 2003-01-15 A | 138 | 100% |  | 2003-01-15 | 2003-01-15 | 1d |  |  |  | STEREO | IMPACT | SEP Package | SIT | SIT | GSFC |
| 140 | 5.1.2.2 | **FM 1 & FM 2** | 99.4d | 2003-07-24 A | 2003-12-15 |  | 83% | 16.57d | 2003-07-24 | 2003-08-01 | 6d | 72d |  |  | STEREO | IMPACT | SEP Package | SIT | SIT | UMD |
| 141 | 5.1.2.2.1 | Implement Final SIT ACTEL Chip Design | 5d | 2003-07-24 A | 2003-07-31 A | 133 | 100% |  | 2003-07-24 | 2003-07-31 | 5d |  |  | start no earlier than 2003-05-31 | STEREO | IMPACT | SEP Package | SIT | SIT | GSFC |
| 142 | 5.1.2.2.2 | Burn Final SIT ACTEL Chip | 1d | 2003-12-15 | 2003-12-15 | 141 |  |  | 2003-07-31 | 2003-08-01 | 1d | 72d | 0d | start no earlier than 2003-12-15 | STEREO | IMPACT | SEP Package | SIT | SIT | GSFC |

| ID | WBS | Task | Type | Duration | Start | Finish | Predecessors | Complete | Remaining | Baseline start | Baseline finish | Baseline duration | Total slack | Constraint | Text11 | Text12 | Text13 | Text14 | Text16 | Text28 |
| --- | --- | --- | --- | --- | --- | --- | --- | --- | --- | --- | --- | --- | --- | --- | --- | --- | --- | --- | --- | --- |
| 143 | 5.1.3 | **Test** |  | 230d | 2003-02-03 A | 2003-12-30 |  | 62% | 88.46d | 2003-02-03 | 2003-09-15 | 157d | 72d |  | STEREO | IMPACT | SEP Package | SIT | SIT | UMD |
| 144 | 5.1.3.1 | **ETU** |  | 105.6d | 2003-02-03 A | 2003-07-02 A |  | 100% |  | 2003-02-03 | 2003-07-02 | 105.6d |  |  | STEREO | IMPACT | SEP Package | SIT | SIT | UMD |
| 145 | 5.1.3.1.1 | Evaluate SIT Prototype ACTEL Chip |  | 16d | 2003-02-03 A | 2003-07-02 A | 12 | 100% |  | 2003-02-03 | 2003-07-02 | 16d |  | finish no earlier than 2003-05-01 | STEREO | IMPACT | SEP Package | SIT | SIT | UMD |
| 146 | 5.1.3.2 | **FM 1 & FM 2** |  | 10d | 2003-12-16 | 2003-12-30 |  |  |  | 2003-09-02 | 2003-09-15 | 10d | 72d |  | STEREO | IMPACT | SEP Package | SIT | SIT | UMD |
| 147 | 5.1.3.2.1 | Evaluate SIT Final ACTEL Chip |  | 10d | 2003-12-16 | 2003-12-30 | 13 |  |  | 2003-09-02 | 2003-09-15 | 10d | 72d |  | STEREO | IMPACT | SEP Package | SIT | SIT | UMD |
| 148 | 6 | **TOF Board** |  | 523d | 2002-01-04 A | 2004-02-03 |  | 91% | 44.89d | 2002-01-04 | 2003-09-12 | 426d | 25d |  | STEREO | IMPACT | SEP Package | SIT | SIT | UMD |
| 149 | 6.1 | **Design, Manufacture, Assembly and Test** |  | 523d | 2002-01-04 A | 2004-02-03 |  | 91% | 44.89d | 2002-01-04 | 2003-09-12 | 426d | 25d |  | STEREO | IMPACT | SEP Package | SIT | SIT | UMD |
| 150 | 6.1.1 | **Procurements** |  | 110d | 2003-03-03 A | 2003-08-05 A |  | 100% |  | 2003-03-03 | 2003-08-05 | 110d |  |  | STEREO | IMPACT | SEP Package | SIT | SIT | UMD |
| 151 | 6.1.1.1 | **FM 1 & FM 2** |  | 110d | 2003-03-03 A | 2003-08-05 A |  | 100% |  | 2003-03-03 | 2003-08-05 | 110d |  |  | STEREO | IMPACT | SEP Package | SIT | SIT | UMD |
| 152 | 6.1.1.1.1 | PIND Test AD96687 |  | 46d | 2003-06-02 A | 2003-08-05 A |  | 100% |  | 2003-06-02 | 2003-08-05 | 46d |  | start no earlier than 2003-05-31 | STEREO | IMPACT | SEP Package | SIT | SIT | MP |
| 153 | 6.1.1.1.2 | Screening of transistors AT41435 |  | 33d | 2003-03-03 A | 2003-04-16 A |  | 100% |  | 2003-03-03 | 2003-04-16 | 33d |  | start no earlier than 2003-03-01 | STEREO | IMPACT | SEP Package | SIT | SIT | MP |
| 154 | 6.1.1.1.3 | Receive transistors | milestone | 0d | 2003-04-16 A | 2003-04-16 A | 153 | 100% |  | 2003-04-16 | 2003-04-16 | 0d |  | start no earlier than 2003-02-01 | STEREO | IMPACT | SEP Package | SIT | SIT | MP |
| 155 | 6.1.1.1.4 | Qualification test of AT41435 |  | 21d | 2003-04-17 A | 2003-05-15 A | 153 | 100% |  | 2003-04-17 | 2003-05-15 | 21d |  | start no earlier than 2003-02-01 | STEREO | IMPACT | SEP Package | SIT | SIT | MP |
| 156 | 6.1.1.1.5 | Receive coax connectors | milestone | 0d | 2003-04-30 A | 2003-04-30 A |  | 100% |  | 2003-04-30 | 2003-04-30 | 0d |  | start no earlier than 2003-04-30 | STEREO | IMPACT | SEP Package | SIT | SIT | UMD |
| 157 | 6.1.2 | **Design** |  | 125d | 2002-02-19 A | 2002-08-14 A |  | 100% |  | 2002-02-19 | 2002-08-14 | 125d |  |  | STEREO | IMPACT | SEP Package | SIT | SIT | UMD |
| 158 | 6.1.2.1 | **FM 1 & FM 2** |  | 125d | 2002-02-19 A | 2002-08-14 A |  | 100% |  | 2002-02-19 | 2002-08-14 | 125d |  |  | STEREO | IMPACT | SEP Package | SIT | SIT | UMD |
| 159 | 6.1.2.1.1 | Freeze TOF System Design |  | 1d | 2002-02-19 A | 2002-02-19 A |  | 100% |  | 2002-02-19 | 2002-02-19 | 1d |  | start no earlier than 2002-02-19 | STEREO | IMPACT | SEP Package | SIT | SIT | MP |
| 160 | 6.1.2.1.2 | PCB Design Place and Route |  | 10d | 2002-04-17 A | 2002-04-30 A |  | 100% |  | 2002-04-17 | 2002-04-30 | 10d |  | start no earlier than 2002-04-17 | STEREO | IMPACT | SEP Package | SIT | SIT | MP |
| 161 | 6.1.2.1.3 | Finish Analog TOF Printed Circuit Board Layout |  | 10d | 2002-08-01 A | 2002-08-14 A |  | 100% |  | 2002-08-01 | 2002-08-14 | 10d |  | start no earlier than 2002-07-31 | STEREO | IMPACT | SEP Package | SIT | SIT | MP |
| 162 | 6.1.3 | **Fabrication** |  | 83d | 2002-05-01 A | 2002-08-27 A |  | 100% |  | 2002-05-01 | 2002-08-27 | 83d |  |  | STEREO | IMPACT | SEP Package | SIT | SIT | UMD |
| 163 | 6.1.3.1 | **FM 1 & FM 2** |  | 83d | 2002-05-01 A | 2002-08-27 A |  | 100% |  | 2002-05-01 | 2002-08-27 | 83d |  |  | STEREO | IMPACT | SEP Package | SIT | SIT | UMD |
| 164 | 6.1.3.1.1 | Digital TOF Printed Circuit Board manufacturing (brockstedt) |  | 19d | 2002-05-01 A | 2002-05-28 A | 160 | 100% |  | 2002-05-01 | 2002-05-28 | 19d |  |  | STEREO | IMPACT | SEP Package | SIT | SIT | MP |
| 165 | 6.1.3.1.2 | Inspection of Digital TOF Printed Circuit Board from US side |  | 10d | 2002-05-29 A | 2002-06-11 A | 164 | 100% |  | 2002-05-29 | 2002-06-11 | 10d |  |  | STEREO | IMPACT | SEP Package | SIT | SIT | UMD |
| 166 | 6.1.3.1.3 | Analog TOF FM 1 board fabrication |  | 8d | 2002-08-15 A | 2002-08-26 A | 161FS+1d | 100% |  | 2002-08-15 | 2002-08-26 | 8d |  | start no earlier than 2002-07-31 | STEREO | IMPACT | SEP Package | SIT | SIT | MP |
| 167 | 6.1.3.1.4 | Inspection of Printed Circuit Board from US side |  | 1d | 2002-08-27 A | 2002-08-27 A | 166 | 100% |  | 2002-08-27 | 2002-08-27 | 1d |  | start no earlier than 2002-07-01 | STEREO | IMPACT | SEP Package | SIT | SIT | UMD |

| ID | WBS | Task | Type | Duration | Start | Finish | Predecessors | Complete | Remaining | Baseline start | Baseline finish | Baseline duration | Total slack | Free slack | Constraint | Text11 | Text12 | Text13 | Text14 | Text16 | Text28 | Text23 |
| --- | --- | --- | --- | --- | --- | --- | --- | --- | --- | --- | --- | --- | --- | --- | --- | --- | --- | --- | --- | --- | --- | --- |
| 168 | 6.1.4 | **Assembly** |  | 55d | 2002-06-12 A | 2002-08-28 A |  | 100% |  | 2002-06-12 | 2002-08-28 | 55d |  |  |  | STEREO | IMPACT | SEP Package | SIT | SIT | UMD |  |
| 169 | 6.1.4.1 | **FM 1 & FM 2** |  | 55d | 2002-06-12 A | 2002-08-28 A |  | 100% |  | 2002-06-12 | 2002-08-28 | 55d |  |  |  | STEREO | IMPACT | SEP Package | SIT | SIT | UMD |  |
| 170 | 6.1.4.1.1 | Digital TOF Board population |  | 10d | 2002-06-12 A | 2002-07-09 A | 165 | 100% |  | 2002-06-12 | 2002-07-09 | 10d |  |  |  | STEREO | IMPACT | SEP Package | SIT | SIT | MP |  |
| 171 | 6.1.4.1.2 | FM #1 board passive parts population |  | 1d | 2002-08-28 A | 2002-08-28 A | 167 | 100% |  | 2002-08-28 | 2002-08-28 | 1d |  |  | start no earlier than 2002-07-01 | STEREO | IMPACT | SEP Package | SIT | SIT | MP |  |
| 172 | 6.1.4.1.3 | FM #1 board active parts population |  | 1d | 2002-08-28 A | 2002-08-28 A | 171 | 100% |  | 2002-08-28 | 2002-08-28 | 1d |  |  | start no earlier than 2002-07-01 | STEREO | IMPACT | SEP Package | SIT | SIT | MP |  |
| 173 | 6.1.5 | **Test** |  | 523d | 2002-01-04 A | 2004-02-03 |  | 68% | 168.71d | 2002-01-04 | 2003-09-12 | 426d | 25d |  |  | STEREO | IMPACT | SEP Package | SIT | SIT | UMD |  |
| 174 | 6.1.5.1 | **ETU** |  | 13d | 2002-01-04 A | 2002-01-23 A |  | 100% |  | 2002-01-04 | 2002-01-23 | 13d |  |  |  | STEREO | IMPACT | SEP Package | SIT | SIT | UMD |  |
| 175 | 6.1.5.1.1 | Test Proto Digital TOF Board |  | 6d | 2002-01-04 A | 2002-01-11 A | 362, 23 | 100% |  | 2002-01-04 | 2002-01-11 | 6d |  |  |  | STEREO | IMPACT | SEP Package | SIT | SIT | UMD |  |
| 176 | 6.1.5.1.2 | Bench Test Proto TOF System |  | 5d | 2002-01-04 A | 2002-01-10 A | 175, 24 | 100% |  | 2002-01-04 | 2002-01-10 | 5d |  |  |  | STEREO | IMPACT | SEP Package | SIT | SIT | UMD |  |
| 177 | 6.1.5.1.3 | Alpha Test with Proto TOF |  | 9d | 2002-01-10 A | 2002-01-23 A | 176, 363 | 100% |  | 2002-01-10 | 2002-01-23 | 9d |  |  |  | STEREO | IMPACT | SEP Package | SIT | SIT | UMD |  |
| 178 | 6.1.5.2 | **FM 1 & FM 2** |  | 397d | 2002-07-05 A | 2004-02-03 |  | 52% | 189.05d | 2002-07-05 | 2003-09-12 | 300d | 25d |  |  | STEREO | IMPACT | SEP Package | SIT | SIT | UMD |  |
| 179 | 6.1.5.2.1 | Digital TOF Functional / Environmental Tests |  | 19d | 2002-07-05 A | 2002-07-31 A | 170 | 100% |  | 2002-07-05 | 2002-07-31 | 19d |  |  | start no earlier than 2002-07-01 | STEREO | IMPACT | SEP Package | SIT | SIT | UMD |  |
| 180 | 6.1.5.2.2 | Analog TOF Electronics Test |  | 3d | 2002-08-28 A | 2002-08-30 A | 172 | 100% |  | 2002-08-28 | 2002-08-30 | 3d |  |  | start no earlier than 2002-07-01 | STEREO | IMPACT | SEP Package | SIT | SIT | UMD |  |
| 181 | 6.1.5.2.3 | **FM 1** |  | 10d | 2004-01-05 | 2004-01-19 |  |  |  | 2003-07-29 | 2003-08-11 | 10d | 16d |  |  | STEREO | IMPACT | SEP Package | SIT | SIT | UMD |  |
| 182 | 6.1.5.2.3.1 | FM 1 TOF Boards Functional Test |  | 10d | 2004-01-05 | 2004-01-19 | 27, 28 |  |  | 2003-07-29 | 2003-08-11 | 10d | 16d | 0d |  | STEREO | IMPACT | SEP Package | SIT | SIT | UMD | FM 1 TOF Boards Functional Test Complete |
| 183 | 6.1.5.2.4 | **FM 2** |  | 10d | 2004-01-21 | 2004-02-03 |  |  |  | 2003-08-29 | 2003-09-12 | 10d | 25d |  |  | STEREO | IMPACT | SEP Package | SIT | SIT | UMD |  |
| 184 | 6.1.5.2.4.1 | FM 2 TOF Boards Functional Test |  | 10d | 2004-01-21 | 2004-02-03 | 364, 29, 30 |  |  | 2003-08-29 | 2003-09-12 | 10d | 25d | 20d |  | STEREO | IMPACT | SEP Package | SIT | SIT | UMD | FM 2 TOF Boards Functional Test Complete |
| 185 | 7 | **Energy Board** |  | 492d | 2002-01-24 A | 2004-01-07 |  | 75% | 121.9d | 2002-01-24 | 2003-08-12 | 391d | 144d |  |  | STEREO | IMPACT | SEP Package | SIT | SIT | UMD |  |
| 186 | 7.1 | **Design, Manufacture, Assembly and Test** |  | 492d | 2002-01-24 A | 2004-01-07 |  | 75% | 121.9d | 2002-01-24 | 2003-08-12 | 391d | 144d |  |  | STEREO | IMPACT | SEP Package | SIT | SIT | UMD |  |
| 187 | 7.1.1 | **Procurements** |  | 10d | 2002-03-14 A | 2002-03-28 A |  | 100% |  | 2002-03-14 | 2002-03-28 | 10d |  |  |  | STEREO | IMPACT | SEP Package | SIT | SIT | UMD |  |
| 188 | 7.1.1.1 | **ETU** |  | 10d | 2002-03-14 A | 2002-03-28 A |  | 100% |  | 2002-03-14 | 2002-03-28 | 10d |  |  |  | STEREO | IMPACT | SEP Package | SIT | SIT | UMD |  |
| 189 | 7.1.1.1.1 | Energy Board Preliminary Parts Order | milestone | 0d | 2002-03-14 A | 2002-03-14 A | 69 | 100% |  | 2002-03-14 | 2002-03-14 | 0d |  |  |  | STEREO | IMPACT | SEP Package | SIT | SIT | UMD |  |
| 190 | 7.1.1.1.2 | Procure Proto Printed Curcuit Board |  | 10d | 2002-03-15 A | 2002-03-28 A | 195 | 100% |  | 2002-03-15 | 2002-03-28 | 10d |  |  |  | STEREO | IMPACT | SEP Package | SIT | SIT | UMD |  |
| 191 | 7.1.2 | **Design** |  | 278d | 2002-01-24 A | 2003-03-04 A |  | 100% |  | 2002-01-24 | 2003-03-04 | 278d |  |  |  | STEREO | IMPACT | SEP Package | SIT | SIT | UMD |  |
| 192 | 7.1.2.1 | **ETU** |  | 132d | 2002-01-24 A | 2002-07-31 A |  | 100% |  | 2002-01-24 | 2002-07-31 | 132d |  |  |  | STEREO | IMPACT | SEP Package | SIT | SIT | UMD |  |
| 193 | 7.1.2.1.1 | Decision to Proceed |  | 1d | 2002-01-24 A | 2002-01-24 A |  | 100% |  | 2002-01-24 | 2002-01-24 | 1d |  |  | start no earlier than 2002-01-24 | STEREO | IMPACT | SEP Package | SIT | SIT | UMD |  |
| 194 | 7.1.2.1.2 | Design Energy Board |  | 4d | 2002-02-20 A | 2002-02-25 A | 159, 193 | 100% |  | 2002-02-20 | 2002-02-25 | 4d |  |  |  | STEREO | IMPACT | SEP Package | SIT | SIT | UMD |  |
| 195 | 7.1.2.1.3 | Energy Board Preliminary Layout |  | 10d | 2002-03-01 A | 2002-03-14 A | 69 | 100% |  | 2002-03-01 | 2002-03-14 | 10d |  |  |  | STEREO | IMPACT | SEP Package | SIT | SIT | UMD |  |
| 196 | 7.1.2.1.4 | Energy Board ETU Layout |  | 10d | 2002-07-18 A | 2002-07-31 A | 317 | 100% |  | 2002-07-18 | 2002-07-31 | 10d |  |  |  | STEREO | IMPACT | SEP Package | SIT | SIT | UMD |  |

| ID | WBS | Task | Duration | Start | Finish | Predecessors | Complete | Remaining | Baseline start | Baseline finish | Baseline duration | Total slack | Free slack | Constraint | Text11 | Text12 | Text13 | Text14 | Text16 | Text28 | Text23 |
| --- | --- | --- | --- | --- | --- | --- | --- | --- | --- | --- | --- | --- | --- | --- | --- | --- | --- | --- | --- | --- | --- |
| 197 | 7.1.2.2 | **FM 1 & FM 2** | 128d | 2002-08-27 A | 2003-03-04 A |  | 100% |  | 2002-08-27 | 2003-03-04 | 128d |  |  |  | STEREO | IMPACT | SEP Package | SIT | SIT | UMD |  |
| 198 | 7.1.2.2.1 | Freeze Energy Board Design | 1d | 2002-08-27 A | 2002-08-27 A | 219 | 100% |  | 2002-08-27 | 2002-08-27 | 1d |  |  |  | STEREO | IMPACT | SEP Package | SIT | SIT | UMD |  |
| 199 | 7.1.2.2.2 | Energy Board Final Layout | 5.8d | 2002-08-28 A | 2003-03-04 A | 73 | 100% |  | 2002-08-28 | 2003-03-04 | 5.8d |  |  |  | STEREO | IMPACT | SEP Package | SIT | SIT | UMD |  |
| 200 | 7.1.3 | **Fabrication** | 280.8d | 2002-03-28 A | 2003-05-08 A |  | 100% |  | 2002-03-28 | 2003-05-08 | 280.8d |  |  |  | STEREO | IMPACT | SEP Package | SIT | SIT | UMD |  |
| 201 | 7.1.3.1 | **ETU** | 2d | 2002-03-28 A | 2002-03-29 A |  | 100% |  | 2002-03-28 | 2002-03-29 | 2d |  |  |  | STEREO | IMPACT | SEP Package | SIT | SIT | UMD |  |
| 202 | 7.1.3.1.1 | Receive & Inspect Printed Curcuit Board | 2d | 2002-03-28 A | 2002-03-29 A | 190FS-2d | 100% |  | 2002-03-28 | 2002-03-29 | 2d |  |  | start no earlier than 2002-07-01 | STEREO | IMPACT | SEP Package | SIT | SIT | UMD |  |
| 203 | 7.1.3.2 | **FM 1 & FM 2** | 41.8d | 2003-03-12 A | 2003-05-08 A |  | 100% |  | 2003-03-12 | 2003-05-08 | 41.8d |  |  |  | STEREO | IMPACT | SEP Package | SIT | SIT | UMD |  |
| 204 | 7.1.3.2.1 | **FM 1** | 40.8d | 2003-03-12 A | 2003-05-08 A |  | 100% |  | 2003-03-12 | 2003-05-08 | 40.8d |  |  |  | STEREO | IMPACT | SEP Package | SIT | SIT | UMD |  |
| 205 | 7.1.3.2.1.1 | Fabricate FM 1 Energy Board | 29d | 2003-03-12 A | 2003-05-08 A | 199 | 100% |  | 2003-03-12 | 2003-05-08 | 29d |  |  | start no earlier than 2003-03-01 | STEREO | IMPACT | SEP Package | SIT | SIT | UMD | FM 1 Energy Board Fabricated |
| 206 | 7.1.3.2.2 | **FM 2** | 41.8d | 2003-03-12 A | 2003-05-08 A |  | 100% |  | 2003-03-12 | 2003-05-08 | 41.8d |  |  |  | STEREO | IMPACT | SEP Package | SIT | SIT | UMD |  |
| 207 | 7.1.3.2.2.1 | Fabricate FM 2 Energy Board | 29d | 2003-03-12 A | 2003-05-08 A | 199 | 100% |  | 2003-03-12 | 2003-05-08 | 29d |  |  | start no earlier than 2003-03-01 | STEREO | IMPACT | SEP Package | SIT | SIT | UMD | FM 2 Energy Board Fabricated |
| 208 | 7.1.4 | **Assembly** | 417d | 2002-03-29 A | 2003-11-21 |  | 43% | 238.29d | 2002-03-29 | 2003-06-12 | 304d | 159d |  |  | STEREO | IMPACT | SEP Package | SIT | SIT | UMD |  |
| 209 | 7.1.4.1 | **ETU** | 119d | 2002-03-29 A | 2002-09-16 A |  | 100% |  | 2002-03-29 | 2002-09-16 | 119d |  |  |  | STEREO | IMPACT | SEP Package | SIT | SIT | UMD |  |
| 210 | 7.1.4.1.1 | Assemble Proto Energy Breadboard | 5d | 2002-03-29 A | 2002-04-04 A | 202, 189 | 100% |  | 2002-03-29 | 2002-04-04 | 5d |  |  |  | STEREO | IMPACT | SEP Package | SIT | SIT | UMD |  |
| 211 | 7.1.4.1.2 | Assemble ETU Energy Board | 10d | 2002-09-03 A | 2002-09-16 A | 196 | 100% |  | 2002-09-03 | 2002-09-16 | 10d |  |  | start no earlier than 2002-08-31 | STEREO | IMPACT | SEP Package | SIT | SIT | UMD |  |
| 212 | 7.1.4.2 | **FM 1** | 10d | 2003-11-10 | 2003-11-21 |  |  |  | 2003-06-02 | 2003-06-12 | 9d | 144d |  |  | STEREO | IMPACT | SEP Package | SIT | SIT | UMD |  |
| 213 | 7.1.4.2.1 | Assemble FM 1 Energy Board | 10d | 2003-11-10 | 2003-11-21 | 221 |  |  | 2003-06-02 | 2003-06-12 | 9d | 144d | 0d | start no earlier than 2003-11-10 | STEREO | IMPACT | SEP Package | SIT | SIT | UMD | FM 1 Energy Board Assembled |
| 214 | 7.1.4.3 | **FM 2** | 10d | 2003-11-10 | 2003-11-21 |  |  |  | 2003-06-02 | 2003-06-12 | 9d | 159d |  |  | STEREO | IMPACT | SEP Package | SIT | SIT | UMD |  |
| 215 | 7.1.4.3.1 | Assemble FM 2 Energy Board | 10d | 2003-11-10 | 2003-11-21 | 221 |  |  | 2003-06-02 | 2003-06-12 | 9d | 159d | 15d | start no earlier than 2003-11-10 | STEREO | IMPACT | SEP Package | SIT | SIT | UMD | FM 2 Energy Board Assembled |
| 216 | 7.1.5 | **Test** | 442d | 2002-04-05 A | 2004-01-07 |  | 54% | 204d | 2002-04-05 | 2003-08-12 | 341d | 144d |  |  | STEREO | IMPACT | SEP Package | SIT | SIT | UMD |  |
| 217 | 7.1.5.1 | **ETU** | 124d | 2002-04-05 A | 2002-09-30 A |  | 100% |  | 2002-04-05 | 2002-09-30 | 124d |  |  |  | STEREO | IMPACT | SEP Package | SIT | SIT | UMD |  |
| 218 | 7.1.5.1.1 | Test Energy Breadboard | 10d | 2002-04-05 A | 2002-04-18 A | 210 | 100% |  | 2002-04-05 | 2002-04-18 | 10d |  |  |  | STEREO | IMPACT | SEP Package | SIT | SIT | UMD |  |
| 219 | 7.1.5.1.2 | Test ETU Energy Board | 10d | 2002-09-17 A | 2002-09-30 A | 211 | 100% |  | 2002-09-17 | 2002-09-30 | 10d |  |  |  | STEREO | IMPACT | SEP Package | SIT | SIT | UMD |  |
| 220 | 7.1.5.2 | **FM 1 & FM 2** | 15d | 2003-05-08 A | 2003-05-30 A |  | 100% |  | 2003-05-08 | 2003-05-30 | 15d |  |  |  | STEREO | IMPACT | SEP Package | SIT | SIT | UMD |  |
| 221 | 7.1.5.2.1 | Coupon Testing | 15d | 2003-05-08 A | 2003-05-30 A | 205, 207 | 100% |  | 2003-05-08 | 2003-05-30 | 15d |  |  | start no earlier than 2003-04-30 | STEREO | IMPACT | SEP Package | SIT | SIT | UMD |  |

Notes:
- 211: Check with Peter in regard to 9/30 status, marked this as complete since status report indicates the EngergyBoard/TOF thermal testing was completed
- 213: Parts for this board are expected at Goddard on Friday 11/7/03 ... to be hand carried from UMD by Peter Walpole.
- 215: Parts for this board are expected at Goddard on Friday 11/7/03 ... to be hand carried from UMD by Peter Walpole.
- 219: Check with Peter in regard to 9/30 status, marked this as complete since status report indicates the EngergyBoard/TOF thermal testing was completed

| ID | WBS | Task | Duration | Start | Finish | Predecessors | Complete | Remaining | Baseline start | Baseline finish | Baseline duration | Total slack | Free slack | Constraint | Text11 | Text12 | Text13 | Text14 | Text16 | Text28 | Text23 |
| --- | --- | --- | --- | --- | --- | --- | --- | --- | --- | --- | --- | --- | --- | --- | --- | --- | --- | --- | --- | --- | --- |
| 222 | 7.1.5.3 | **FM 1** | 15d | 2003-11-24 | 2003-12-15 |  |  |  | 2003-07-01 | 2003-07-22 | 15d | 144d |  |  | STEREO | IMPACT | SEP Package | SIT | SIT | UMD |  |
| 223 | 7.1.5.3.1 | Bench Test/Calibration | 10d | 2003-11-24 | 2003-12-08 | 213 |  |  | 2003-07-01 | 2003-07-15 | 10d | 144d | 0d |  | STEREO | IMPACT | SEP Package | SIT | SIT | UMD |  |
| 224 | 7.1.5.3.2 | Thermal | 3d | 2003-12-09 | 2003-12-11 | 223 |  |  | 2003-07-16 | 2003-07-18 | 3d | 144d | 0d |  | STEREO | IMPACT | SEP Package | SIT | SIT | UMD |  |
| 225 | 7.1.5.3.3 | Voltage Margin | 2d | 2003-12-12 | 2003-12-15 | 224 |  |  | 2003-07-21 | 2003-07-22 | 2d | 144d | 0d |  | STEREO | IMPACT | SEP Package | SIT | SIT | UMD | FM 1 Energy Board Tested |
| 226 | 7.1.5.4 | **FM 2** | 15d | 2003-12-16 | 2004-01-07 |  |  |  | 2003-07-23 | 2003-08-12 | 15d | 144d |  |  | STEREO | IMPACT | SEP Package | SIT | SIT | UMD |  |
| 227 | 7.1.5.4.1 | FM 2 Energy Board Functional Test | 15d | 2003-12-16 | 2004-01-07 | 225, 215 |  |  | 2003-07-23 | 2003-08-12 | 15d | 144d |  |  | STEREO | IMPACT | SEP Package | SIT | SIT | UMD | FM 2 Energy Board Tested |
| 228 | 8 | **Logic Board** | 413d | 2002-08-28 A | 2004-04-20 |  | 22% | 323.36d | 2002-08-28 | 2004-02-25 | 373d | 7d |  |  | STEREO | IMPACT | SEP Package | SIT | SIT | UMD |  |
| 229 | 8.1 | **Design, Manufacture, Assembly and Test** | 413d | 2002-08-28 A | 2004-04-20 |  | 22% | 323.36d | 2002-08-28 | 2004-02-25 | 373d | 7d |  |  | STEREO | IMPACT | SEP Package | SIT | SIT | UMD |  |
| 230 | 8.1.1 | **Design** | 309d | 2002-08-28 A | 2003-11-19 |  | 88% | 35.65d | 2002-08-28 | 2003-07-08 | 214.5d | 0d |  |  | STEREO | IMPACT | SEP Package | SIT | SIT | UMD |  |
| 231 | 8.1.1.1 | **ETU** | 45d | 2002-08-28 A | 2002-10-31 A |  | 100% |  | 2002-08-28 | 2002-10-31 | 45d |  |  |  | STEREO | IMPACT | SEP Package | SIT | SIT | UMD |  |
| 232 | 8.1.1.1.1 | ETU Logic Board Layout | 8d | 2002-08-28 A | 2002-10-31 A | 9SS-2d | 100% |  | 2002-08-28 | 2002-10-31 | 8d |  |  | start no earlier than 2002-07-31 | STEREO | IMPACT | SEP Package | SIT | SIT | UMD |  |
| 233 | 8.1.1.2 | **FM 1 & FM 2** | 184d | 2003-03-03 A | 2003-11-19 |  | 83% | 30.67d | 2003-03-03 | 2003-07-08 | 89.5d | 0d |  |  | STEREO | IMPACT | SEP Package | SIT | SIT | UMD |  |
| 234 | 8.1.1.2.1 | Design Logic Board | 1d | 2003-03-03 A | 2003-07-01 A | 10 | 100% |  | 2003-03-03 | 2003-07-01 | 1d |  |  | start no earlier than 2003-03-01 | STEREO | IMPACT | SEP Package | SIT | SIT | UMD |  |
| 235 | 8.1.1.2.2 | Logic Board Schematic | 5d | 2003-03-05 A | 2003-07-02 A | 199, 234SS+1.5d | 100% |  | 2003-03-05 | 2003-07-02 | 5d |  |  |  | STEREO | IMPACT | SEP Package | SIT | SIT | UMD |  |
| 236 | 8.1.1.2.3 | Logic Board Layout | 9d | 2003-03-12 A | 2003-07-08 A | 235SS+5d | 100% |  | 2003-03-12 | 2003-07-08 | 9d |  |  |  | STEREO | IMPACT | SEP Package | SIT | SIT | UMD |  |
| 237 | 8.1.1.2.4 | Layout new Logic Board Design | 3d | 2003-11-17 | 2003-11-19 | 256 |  |  |  |  |  | 0d |  |  | STEREO | IMPACT | SEP Package | SIT | SIT | UMD |  |
| 238 | 8.1.2 | **Fabrication** | 260d | 2002-12-02 A | 2003-12-11 |  | 25% | 195d | 2002-12-02 | 2003-07-29 | 165.5d | 0d |  |  | STEREO | IMPACT | SEP Package | SIT | SIT | UMD |  |
| 239 | 8.1.2.1 | **ETU** | 5d | 2002-12-02 A | 2002-12-06 A |  | 100% |  | 2002-12-02 | 2002-12-06 | 5d |  |  |  | STEREO | IMPACT | SEP Package | SIT | SIT | UMD |  |
| 240 | 8.1.2.1.1 | Fabricate ETU Logic Board | 5d | 2002-12-02 A | 2002-12-06 A | 232 | 100% |  | 2002-12-02 | 2002-12-06 | 5d |  |  | start no earlier than 2002-11-30 | STEREO | IMPACT | SEP Package | SIT | SIT | UMD |  |
| 241 | 8.1.2.2 | **FM 1 & FM 2** | 15d | 2003-11-20 | 2003-12-11 |  |  |  | 2003-07-08 | 2003-07-29 | 15d | 0d |  |  | STEREO | IMPACT | SEP Package | SIT | SIT | UMD |  |
| 242 | 8.1.2.2.1 | FM 1 & FM 2 Logic Board Fabrication | 15d | 2003-11-20 | 2003-12-11 | 237 |  |  | 2003-07-08 | 2003-07-29 | 15d | 0d |  |  | STEREO | IMPACT | SEP Package | SIT | SIT | UMD | Flight Logic Boards Fabricated |
| 243 | 8.1.3 | **Assembly** | 73d | 2004-01-05 | 2004-04-16 |  |  |  | 2003-08-18 | 2004-02-23 | 127.5d | 0d |  |  | STEREO | IMPACT | SEP Package | SIT | SIT | UMD |  |
| 244 | 8.1.3.1 | **FM 1** | 73d | 2004-01-05 | 2004-04-16 |  |  |  | 2003-08-18 | 2004-02-23 | 127.5d | 0d |  |  | STEREO | IMPACT | SEP Package | SIT | SIT | UMD |  |
| 245 | 8.1.3.1.1 | Assemble FM 1 Logic Board with ETU ACTELs | 11d | 2004-01-05 | 2004-01-20 | 258, 12 |  |  | 2003-08-18 | 2003-09-03 | 11d | 0d |  |  | STEREO | IMPACT | SEP Package | SIT | SIT | UMD | FM 1 Logic Board Assembled w/ETU ACTEL |
| 246 | 8.1.3.1.2 | Disassembel FM 1 Logic Board with ETU ACTELs | 1d | 2004-04-13 | 2004-04-13 | 337 |  |  | 2004-02-18 | 2004-02-18 | 1d | 0d |  |  | STEREO | IMPACT | SEP Package | SIT | SIT | UMD |  |
| 247 | 8.1.3.1.3 | Retrofit/Inspect FM 1 Flight ACTELs | 2d | 2004-04-14 | 2004-04-15 | 246, 13, 147 |  |  | 2004-02-19 | 2004-02-20 | 2d | 7d | 0d |  | STEREO | IMPACT | SEP Package | SIT | SIT | UMD |  |
| 248 | 8.1.3.1.4 | Reassemble FM 1 Logic Board with Flight ACTELs | 1d | 2004-04-16 | 2004-04-16 | 247 |  |  | 2004-02-23 | 2004-02-23 | 1d | 7d | 0d |  | STEREO | IMPACT | SEP Package | SIT | SIT | UMD | FM 1 Logic Board Assembled w/Flight ACTEL |

Notes:
- 232: Changed % complete to 30 from 20, check with Peter
- 242: 2003 May Status - Reduced the Fabrication time from 6 wks to 3 wks.

| ID | WBS | Task | Duration | Start | Finish | Predecessors | Complete | Remaining | Baseline start | Baseline finish | Baseline duration | Total slack | Free slack | Constraint | Text11 | Text12 | Text13 | Text14 | Text16 | Text28 | Text23 |
| --- | --- | --- | --- | --- | --- | --- | --- | --- | --- | --- | --- | --- | --- | --- | --- | --- | --- | --- | --- | --- | --- |
| 249 | 8.1.3.2 | **FM 2** | 73d | 2004-01-05 | 2004-04-16 |  |  |  | 2003-08-18 | 2004-02-23 | 127.5d | 0d |  |  | STEREO | IMPACT | SEP Package | SIT | SIT | UMD |  |
| 250 | 8.1.3.2.1 | Assemble FM 2 Logic Board with ETU ACTELS | 11d | 2004-01-05 | 2004-01-20 | 258, 12 |  |  | 2003-08-18 | 2003-09-03 | 11d | 20d | 15d |  | STEREO | IMPACT | SEP Package | SIT | SIT | UMD | FM 2 Logic Board Assembled w/ETU ACTEL |
| 251 | 8.1.3.2.2 | Disassemble FM 2 Logic Boards | 1d | 2004-04-13 | 2004-04-13 | 345, 246SS |  |  | 2004-02-18 | 2004-02-18 | 1d | 0d |  |  | STEREO | IMPACT | SEP Package | SIT | SIT | UMD |  |
| 252 | 8.1.3.2.3 | Retrofit/Inspect Flight ACTELS | 2d | 2004-04-14 | 2004-04-15 | 251, 13, 147 |  |  | 2004-02-19 | 2004-02-20 | 2d | 0d |  |  | STEREO | IMPACT | SEP Package | SIT | SIT | UMD |  |
| 253 | 8.1.3.2.4 | Reassemble FM 2 Logic Boards | 1d | 2004-04-16 | 2004-04-16 | 252 |  |  | 2004-02-23 | 2004-02-23 | 1d | 0d |  |  | STEREO | IMPACT | SEP Package | SIT | SIT | UMD | FM 2 Logic Board Assembled w/Flight ACTEL |
| 254 | 8.1.4 | **Test** | 112d | 2003-11-10 | 2004-04-20 |  |  |  | 2002-12-09 | 2004-02-25 | 304d | 0d |  |  | STEREO | IMPACT | SEP Package | SIT | SIT | UMD |  |
| 255 | 8.1.4.1 | **ETU** | 5d | 2003-11-10 | 2003-11-14 |  |  |  | 2002-12-09 | 2003-09-02 | 185d | 0d |  |  | STEREO | IMPACT | SEP Package | SIT | SIT | UMD |  |
| 256 | 8.1.4.1.1 | Test New ETU Logic Board | 5d | 2003-11-10 | 2003-11-14 | 240 |  |  | 2002-12-09 | 2003-09-02 | 54d | 0d |  | start no earlier than 2003-11-10 | STEREO | IMPACT | SEP Package | SIT | SIT | UMD |  |
| 257 | 8.1.4.2 | **FM1 & FM 2** | 89d | 2003-12-12 | 2004-04-20 |  |  |  | 2003-07-29 | 2004-02-25 | 143.5d | 0d |  |  | STEREO | IMPACT | SEP Package | SIT | SIT | UMD |  |
| 258 | 8.1.4.2.1 | Coupon Testing | 14d | 2003-12-12 | 2004-01-02 | 242 |  |  | 2003-07-29 | 2003-08-18 | 14d | 0d |  |  | STEREO | IMPACT | SEP Package | SIT | SIT | UMD |  |
| 259 | 8.1.4.2.2 | **FM 1** | 64d | 2004-01-21 | 2004-04-20 |  |  |  | 2003-09-03 | 2004-02-25 | 118.5d | 0d |  |  | STEREO | IMPACT | SEP Package | SIT | SIT | UMD |  |
| 260 | 8.1.4.2.2.1 | Functional Test of FM 1 Logic Board w/ETU ACTELS | 15d | 2004-01-21 | 2004-02-10 | 14, 368, 245 |  |  | 2003-09-03 | 2003-09-24 | 15d | 0d |  |  | STEREO | IMPACT | SEP Package | SIT | SIT | UMD | FM 1 Logic Board w/ETU ACTEL Functionally Tested |
| 261 | 8.1.4.2.2.2 | Funtional Test of FM 1 Logic Board w/Flight ACTELS | 2d | 2004-04-19 | 2004-04-20 | 248 |  |  | 2004-02-24 | 2004-02-25 | 2d | 7d | 0d |  | STEREO | IMPACT | SEP Package | SIT | SIT | UMD | FM 1 Logic Board w/Flight ACTEL Functionally Tested |
| 262 | 8.1.4.2.3 | **FM 2** | 49d | 2004-02-11 | 2004-04-20 |  |  |  | 2003-09-24 | 2004-02-25 | 103.5d | 0d |  |  | STEREO | IMPACT | SEP Package | SIT | SIT | UMD |  |
| 263 | 8.1.4.2.3.1 | Functional Test of FM 2 Logic Board w/ETU ACTELS | 15d | 2004-02-11 | 2004-03-03 | 260, 250 |  |  | 2003-09-24 | 2003-10-16 | 15d | 5d | 0d |  | STEREO | IMPACT | SEP Package | SIT | SIT | UMD | FM 2 Logic Board w/ETU ACTEL Functionally Tested |
| 264 | 8.1.4.2.3.2 | Functional Test of FM 2 Logic Board w/Flight ACTELS | 2d | 2004-04-19 | 2004-04-20 | 253 |  |  | 2004-02-24 | 2004-02-25 | 2d | 0d |  |  | STEREO | IMPACT | SEP Package | SIT | SIT | UMD | FM 2 Logic Board w/Flight ACTEL Functionally Tested |
| 265 | 9 | **Mother Board** | 147d | 2003-05-01 A | 2003-11-28 |  | 52% | 71.13d | 2003-05-01 | 2003-08-27 | 83d | 42d |  |  | STEREO | IMPACT | SEP Package | SIT | SIT | UMD |  |
| 266 | 9.1 | **Design, Manufacture, Assembly and Test** | 147d | 2003-05-01 A | 2003-11-28 |  | 52% | 71.13d | 2003-05-01 | 2003-08-27 | 83d | 42d |  |  | STEREO | IMPACT | SEP Package | SIT | SIT | UMD |  |
| 267 | 9.1.1 | **Design** | 133d | 2003-05-01 A | 2003-11-07 |  | 89% | 14.78d | 2003-05-01 | 2003-08-07 | 69d | 42d |  |  | STEREO | IMPACT | SEP Package | SIT | SIT | UMD |  |
| 268 | 9.1.1.1 | **FM 1 & FM 2** | 133d | 2003-05-01 A | 2003-11-07 |  | 89% | 14.78d | 2003-05-01 | 2003-08-07 | 69d | 42d |  |  | STEREO | IMPACT | SEP Package | SIT | SIT | UMD |  |
| 269 | 9.1.1.1.1 | Mother Board Layout | 8d | 2003-05-01 A | 2003-05-12 A | 236SS+5d | 100% |  | 2003-05-01 | 2003-05-12 | 8d |  |  | start no earlier than 2003-04-30 | STEREO | IMPACT | SEP Package | SIT | SIT | UMD |  |
| 270 | 9.1.1.1.2 | Finalize Mother Board Layout (if necessary) | 1d | 2003-11-07 | 2003-11-07 | 284 |  |  | 2003-08-06 | 2003-08-07 | 2d | 42d | 0d | start no earlier than 2003-11-07 | STEREO | IMPACT | SEP Package | SIT | SIT | UMD |  |
| 271 | 9.1.2 | **Fabrication** | 134d | 2003-05-20 A | 2003-11-28 |  | 36% | 85.27d | 2003-05-20 | 2003-08-27 | 70d | 42d |  |  | STEREO | IMPACT | SEP Package | SIT | SIT | UMD |  |
| 272 | 9.1.2.1 | **FM 1 & FM 2** | 134d | 2003-05-20 A | 2003-11-28 |  | 36% | 85.27d | 2003-05-20 | 2003-08-27 | 70d | 42d |  |  | STEREO | IMPACT | SEP Package | SIT | SIT | UMD |  |
| 273 | 9.1.2.1.1 | Fabricate FM 1 & FM 2 Mother Boards | 8d | 2003-05-20 A | 2003-05-30 A | 269 | 100% |  | 2003-05-20 | 2003-05-30 | 8d |  |  |  | STEREO | IMPACT | SEP Package | SIT | SIT | UMD | Flight Mother Boards Fabricated |
| 274 | 9.1.2.1.2 | Fabricate FM 1 & FM 2 Mother Boards (if necessary) | 14d | 2003-11-10 | 2003-11-28 | 270 |  |  | 2003-08-08 | 2003-08-27 | 14d | 42d | 0d |  | STEREO | IMPACT | SEP Package | SIT | SIT | UMD |  |

| ID | WBS | Task | Duration | Start | Finish | Predecessors | Complete | Remaining | Baseline start | Baseline finish | Baseline duration | Total slack | Free slack | Constraint | Text11 | Text12 | Text13 | Text14 | Text16 | Text28 | Text23 |
| --- | --- | --- | --- | --- | --- | --- | --- | --- | --- | --- | --- | --- | --- | --- | --- | --- | --- | --- | --- | --- | --- |
| 275 | 10 | **Assembly** | 122d | 2003-07-01 A | 2003-12-23 |  | 44% | 68.49d | 2003-07-01 | 2003-10-20 | 76.5d | 153d |  |  | STEREO | IMPACT | SEP Package | SIT | SIT | UMD |  |
| 276 | 10.1 | **FM 1 & FM 2** | 122d | 2003-07-01 A | 2003-12-23 |  | 44% | 68.49d | 2003-07-01 | 2003-10-20 | 76.5d | 153d |  |  | STEREO | IMPACT | SEP Package | SIT | SIT | UMD |  |
| 277 | 10.1.1 | Assemble FM 1 & FM 2 Mother Boards (FM 1 only) | 5d | 2003-07-23 A | 2003-07-29 A | 281 | 100% |  | 2003-07-23 | 2003-07-29 | 5d |  |  | start no earlier than 2003-06-30 | STEREO | IMPACT | SEP Package | SIT | SIT | UMD | Flight Mother Boards Assembled |
| 278 | 10.1.2 | Assemble FM 2 Mother Board and (if necessary) new FM 1 | 10d | 2003-12-01 | 2003-12-12 | 274 |  |  | 2003-08-28 | 2003-09-11 | 10d | 42d | 0d |  | STEREO | IMPACT | SEP Package | SIT | SIT | UMD |  |
| 279 | 10.1.3 | **Test** | 122d | 2003-07-01 A | 2003-12-23 |  | 48% | 63.9d | 2003-07-01 | 2003-10-20 | 76.5d | 153d |  |  | STEREO | IMPACT | SEP Package | SIT | SIT | UMD |  |
| 280 | 10.1.3.1 | **FM 1 & FM 2** | 122d | 2003-07-01 A | 2003-12-23 |  | 48% | 63.9d | 2003-07-01 | 2003-10-20 | 76.5d | 153d |  |  | STEREO | IMPACT | SEP Package | SIT | SIT | UMD |  |
| 281 | 10.1.3.1.1 | Coupon Testing of Mother Boards | 15d | 2003-07-01 A | 2003-07-22 A | 273 | 100% |  | 2003-07-01 | 2003-07-22 | 15d |  |  | start no earlier than 2003-06-30 | STEREO | IMPACT | SEP Package | SIT | SIT | UMD |  |
| 282 | 10.1.3.1.2 | Coupon Testing of Mother Boards (if necessary) | 15d | 2003-12-01 | 2003-12-19 | 274 |  |  | 2003-08-28 | 2003-09-18 | 15d | 155d |  |  | STEREO | IMPACT | SEP Package | SIT | SIT | UMD |  |
| 283 | 10.1.3.1.3 | **FM 1** | 100d | 2003-07-30 A | 2003-12-19 |  | 50% | 50d | 2003-07-30 | 2003-09-18 | 36d | 42d |  |  | STEREO | IMPACT | SEP Package | SIT | SIT | UMD |  |
| 284 | 10.1.3.1.3.1 | Functional Test FM 1 Mother Board | 5d | 2003-07-30 A | 2003-08-05 A | 277 | 100% |  | 2003-07-30 | 2003-08-05 | 5d |  |  | start no earlier than 2003-06-30 | STEREO | IMPACT | SEP Package | SIT | SIT | UMD | FM 1 Mother Board Functionally Tested |
| 285 | 10.1.3.1.3.2 | Functional Test remade FM 1 Mother Board (if necessary) | 5d | 2003-12-15 | 2003-12-19 | 278 |  |  | 2003-09-12 | 2003-09-18 | 5d | 42d | 0d |  | STEREO | IMPACT | SEP Package | SIT | SIT | UMD |  |
| 286 | 10.1.3.1.4 | **FM 2** | 2d | 2003-12-22 | 2003-12-23 |  |  |  | 2003-10-16 | 2003-10-20 | 2d | 42d |  |  | STEREO | IMPACT | SEP Package | SIT | SIT | UMD |  |
| 287 | 10.1.3.1.4.1 | Functional Test FM 2 Mother Board | 2d | 2003-12-22 | 2003-12-23 | 285 |  |  | 2003-10-16 | 2003-10-20 | 2d | 42d | 22d |  | STEREO | IMPACT | SEP Package | SIT | SIT | UMD | FM 2 Mother Board Functionally Tested |
| 288 | 11 | **Power** | 335d | 2002-10-02 A | 2004-02-03 |  | 33% | 223.33d | 2002-10-02 | 2003-12-05 | 295d | 20d |  |  | STEREO | IMPACT | SEP Package | SIT | SIT | UMD |  |
| 289 | 11.1 | **Design, Manufacture, Assembly and Test** | 335d | 2002-10-02 A | 2004-02-03 |  | 33% | 223.33d | 2002-10-02 | 2003-12-05 | 295d | 20d |  |  | STEREO | IMPACT | SEP Package | SIT | SIT | UMD |  |
| 290 | 11.1.1 | **Test** | 335d | 2002-10-02 A | 2004-02-03 |  | 33% | 223.33d | 2002-10-02 | 2003-12-05 | 295d | 20d |  |  | STEREO | IMPACT | SEP Package | SIT | SIT | UMD |  |
| 291 | 11.1.1.1 | **ETU** | 5d | 2002-10-02 A | 2002-10-09 A |  | 100% |  | 2002-10-02 | 2002-10-09 | 5d |  |  |  | STEREO | IMPACT | SEP Package | SIT | SIT | UMD |  |
| 292 | 11.1.1.1.1 | Bench Test SIT ETU HVPS | 5d | 2002-10-02 A | 2002-10-09 A | 16, 370 | 100% |  | 2002-10-02 | 2002-10-09 | 5d |  |  | start no earlier than 2002-09-30 | STEREO | IMPACT | SEP Package | SIT | SIT | UMD |  |
| 293 | 11.1.1.2 | **FM 1** | 5d | 2003-12-01 | 2003-12-05 |  |  |  | 2003-09-24 | 2003-09-30 | 5d | 20d |  |  | STEREO | IMPACT | SEP Package | SIT | SIT | UMD |  |
| 294 | 11.1.1.2.1 | Functional Test SIT FM 1 HVPS | 5d | 2003-12-01 | 2003-12-05 | 284, 18 |  |  | 2003-09-24 | 2003-09-30 | 5d | 20d | 0d |  | STEREO | IMPACT | SEP Package | SIT | SIT | UMD | FM 1 HVPS Funtionally Tested |
| 295 | 11.1.1.3 | **FM 2** | 5d | 2004-01-28 | 2004-02-03 |  |  |  | 2003-12-01 | 2003-12-05 | 5d | 20d |  |  | STEREO | IMPACT | SEP Package | SIT | SIT | UMD |  |
| 296 | 11.1.1.3.1 | Functional Test SIT FM 2 HVPS | 5d | 2004-01-28 | 2004-02-03 | 287, 20 |  |  | 2003-12-01 | 2003-12-05 | 5d | 20d | 0d |  | STEREO | IMPACT | SEP Package | SIT | SIT | UMD | FM 2 HVPS Functionally Tested |
| 297 | 12 | **Flight Software** | 309d | 2002-07-02 A | 2003-09-23 |  | 95% | 14.66d | 2002-07-02 | 2003-09-23 | 309d | 216d |  |  | STEREO | IMPACT | SEP Package | SIT | SIT | UMD |  |
| 298 | 12.1 | **Design, Manufacture, Assembly and Test** | 309d | 2002-07-02 A | 2003-09-23 |  | 95% | 14.66d | 2002-07-02 | 2003-09-23 | 309d | 216d |  |  | STEREO | IMPACT | SEP Package | SIT | SIT | UMD |  |
| 299 | 12.1.1 | **Assembly** | 195d | 2002-07-02 A | 2003-04-11 A |  | 100% |  | 2002-07-02 | 2003-04-11 | 195d |  |  |  | STEREO | IMPACT | SEP Package | SIT | SIT | GSFC |  |
| 300 | 12.1.1.1 | **ETU** | 85d | 2002-07-02 A | 2002-10-31 A |  | 100% |  | 2002-07-02 | 2002-10-31 | 85d |  |  |  | STEREO | IMPACT | SEP Package | SIT | SIT | GSFC |  |
| 301 | 12.1.1.1.1 | Code SIT Partical Event Processing With Simulated Data | 30d | 2002-07-02 A | 2002-08-29 A | 8 | 100% |  | 2002-07-02 | 2002-08-29 | 30d |  |  | start no earlier than 2002-07-01 | STEREO | IMPACT | SEP Package | SIT | SIT | GSFC |  |
| 302 | 12.1.1.1.2 | Code SIT Beacon Data Processing With Simulated Data | 22d | 2002-10-01 A | 2002-10-31 A | 8 | 100% |  | 2002-10-01 | 2002-10-31 | 22d |  |  | start no earlier than 2002-09-30 | STEREO | IMPACT | SEP Package | SIT | SIT | GSFC |  |
| 303 | 12.1.1.1.3 | Code SIT Telemetry Formatting With Simulated Data | 22d | 2002-10-01 A | 2002-10-31 A | 8 | 100% |  | 2002-10-01 | 2002-10-31 | 22d |  |  | start no earlier than 2002-09-30 | STEREO | IMPACT | SEP Package | SIT | SIT | GSFC |  |

Notes:
- 302: 100%
- 303: 100%

| ID | WBS | Task | Duration | Start | Finish | Predecessors | Complete | Remaining | Baseline start | Baseline finish | Baseline duration | Total slack | Free slack | Constraint | Text11 | Text12 | Text13 | Text14 | Text16 | Text28 | Text23 |
| --- | --- | --- | --- | --- | --- | --- | --- | --- | --- | --- | --- | --- | --- | --- | --- | --- | --- | --- | --- | --- | --- |
| 304 | 12.1.1.2 | **FM 1 & FM 2** | 30d | 2003-03-03 A | 2003-04-11 A |  | 100% |  | 2003-03-03 | 2003-04-11 | 30d |  |  |  | STEREO | IMPACT | SEP Package | SIT | SIT | UMD |  |
| 305 | 12.1.1.2.1 | Code SIT Data Acquisition | 19d | 2003-03-03 A | 2003-03-27 A |  | 100% |  | 2003-03-03 | 2003-03-27 | 19d |  |  | start no earlier than 2003-03-01 | STEREO | IMPACT | SEP Package | SIT | SIT | GSFC |  |
| 306 | 12.1.1.2.2 | Code SIT Command Processing | 30d | 2003-03-03 A | 2003-04-11 A | 8 | 100% |  | 2003-03-03 | 2003-04-11 | 30d |  |  | start no earlier than 2003-03-01 | STEREO | IMPACT | SEP Package | SIT | SIT | GSFC |  |
| 307 | 12.1.1.2.3 | Code Update For SIT Partical Event Processing | 10d | 2003-03-17 A | 2003-03-28 A | 301, 305SS, 312SS+10d | 100% |  | 2003-03-17 | 2003-03-28 | 10d |  |  | start no earlier than 2003-03-01 | STEREO | IMPACT | SEP Package | SIT | SIT | GSFC |  |
| 308 | 12.1.1.2.4 | Code Update for SIT Beacon Data Processing | 10d | 2003-03-17 A | 2003-03-28 A | 302, 312SS+10d | 100% |  | 2003-03-17 | 2003-03-28 | 10d |  |  | start no earlier than 2003-03-01 | STEREO | IMPACT | SEP Package | SIT | SIT | GSFC |  |
| 309 | 12.1.1.2.5 | Code Update for SIT Telemetry Formatting | 10d | 2003-03-31 A | 2003-04-11 A | 303, 307 | 100% |  | 2003-03-31 | 2003-04-11 | 10d |  |  | start no earlier than 2003-02-01 | STEREO | IMPACT | SEP Package | SIT | SIT | GSFC |  |
| 310 | 12.1.2 | **Test** | 144d | 2003-03-03 A | 2003-09-23 |  | 88% | 17.28d | 2003-03-03 | 2003-09-23 | 144d | 216d |  |  | STEREO | IMPACT | SEP Package | SIT | SIT | GSFC |  |
| 311 | 12.1.2.1 | **ETU** | 20d | 2003-03-03 A | 2003-03-28 A |  | 100% |  | 2003-03-03 | 2003-03-28 | 20d |  |  |  | STEREO | IMPACT | SEP Package | SIT | SIT | UMD |  |
| 312 | 12.1.2.1.1 | SIT Integrated S/W Testing Using Simulated Data | 20d | 2003-03-03 A | 2003-03-28 A | 301, 302, 303 | 100% |  | 2003-03-03 | 2003-03-28 | 20d |  |  | start no earlier than 2003-03-01 | STEREO | IMPACT | SEP Package | SIT | SIT | GSFC |  |
| 313 | 12.1.2.2 | **FM 1 & FM 2** | 80d | 2003-06-02 A | 2003-09-23 |  | 85% | 12d | 2003-06-02 | 2003-09-23 | 80d | 216d |  |  | STEREO | IMPACT | SEP Package | SIT | SIT | GSFC |  |
| 314 | 12.1.2.2.1 | Validate SIT On-Board Code | 80d | 2003-06-02 A | 2003-09-23 | 306, 305, 308, 309, 312 | 85% | 12d | 2003-06-02 | 2003-09-23 | 80d | 216d |  |  | STEREO | IMPACT | SEP Package | SIT | SIT | GSFC | On-board Flight S/W Validated |
| 315 | 13 | **Integration & Test** | 554d | 2002-04-19 A | 2004-06-30 |  | 12% | 485.89d | 2002-04-19 | 2004-03-12 | 476d | 0d |  |  | STEREO | IMPACT | SEP Package | SIT | SIT | UMD |  |
| 316 | 13.1 | **ETU** | 125d | 2002-04-19 A | 2002-10-16 A |  | 100% |  | 2002-04-19 | 2002-10-16 | 125d |  |  |  | STEREO | IMPACT | SEP Package | SIT | SIT | UMD |  |
| 317 | 13.1.1 | Test Energy Breadboard with TOF System | 10d | 2002-04-19 A | 2002-05-02 A | 218, 176 | 100% |  | 2002-04-19 | 2002-05-02 | 10d |  |  |  | STEREO | IMPACT | SEP Package | SIT | SIT | UMD |  |
| 318 | 13.1.2 | Test SIT ETU HVPS with TOF ETU Board and Energy ETU Board | 5d | 2002-10-10 A | 2002-10-16 A | 292, 317 | 100% |  | 2002-10-10 | 2002-10-16 | 5d |  |  | start no earlier than 2002-09-30 | STEREO | IMPACT | SEP Package | SIT | SIT | UMD |  |
| 319 | 13.2 | **FM 1** | 4d | 2004-04-21 | 2004-04-26 |  |  |  | 2004-02-26 | 2004-03-02 | 4d | 7d |  |  | STEREO | IMPACT | SEP Package | SIT | SIT | UMD |  |
| 320 | 13.2.1 | Disassemble SIT FM 1 | 1d | 2004-04-21 | 2004-04-21 | 261 |  |  | 2004-02-26 | 2004-02-26 | 1d | 7d | 0d |  | STEREO | IMPACT | SEP Package | SIT | SIT | UMD |  |
| 321 | 13.2.2 | Conformal Coat SIT FM 1 Boards | 1d | 2004-04-22 | 2004-04-22 | 320 |  |  | 2004-02-27 | 2004-02-27 | 1d | 7d | 0d |  | STEREO | IMPACT | SEP Package | SIT | SIT | UMD |  |
| 322 | 13.2.3 | Reassemble SIT FM 1 | 1d | 2004-04-23 | 2004-04-23 | 321 |  |  | 2004-03-01 | 2004-03-01 | 1d | 7d | 0d |  | STEREO | IMPACT | SEP Package | SIT | SIT | UMD |  |
| 323 | 13.2.4 | Post-Coat Retest SIT FM 1 | 1d | 2004-04-26 | 2004-04-26 | 322 |  |  | 2004-03-02 | 2004-03-02 | 1d | 7d | 0d |  | STEREO | IMPACT | SEP Package | SIT | SIT | UMD | FM 1 Ready for Delivery |
| 324 | 13.3 | **FM 2** | 105d | 2003-12-08 | 2004-05-06 |  |  |  | 2003-10-01 | 2004-03-12 | 111d | 0d |  |  | STEREO | IMPACT | SEP Package | SIT | SIT | UMD |  |
| 325 | 13.3.1 | Disassemble SIT FM 2 | 1d | 2004-04-21 | 2004-04-21 | 264 |  |  | 2004-02-26 | 2004-02-26 | 1d | 0d |  |  | STEREO | IMPACT | SEP Package | SIT | SIT | UMD |  |
| 326 | 13.3.2 | Conformal Coat SIT FM 2 Boards | 1d | 2004-04-22 | 2004-04-22 | 325 |  |  | 2004-02-27 | 2004-02-27 | 1d | 0d |  |  | STEREO | IMPACT | SEP Package | SIT | SIT | UMD |  |
| 327 | 13.3.3 | Reassemble SIT FM 2 | 1d | 2004-04-23 | 2004-04-23 | 326 |  |  | 2004-03-01 | 2004-03-01 | 1d | 0d |  |  | STEREO | IMPACT | SEP Package | SIT | SIT | UMD |  |
| 328 | 13.3.4 | Post-Coat Retest SIT FM 2 | 9d | 2004-04-26 | 2004-05-06 | 327 |  |  | 2004-03-02 | 2004-03-12 | 9d | 0d |  |  | STEREO | IMPACT | SEP Package | SIT | SIT | UMD | FM 2 Ready for Delivery |

| ID | WBS | Task | Duration | Start | Finish | Predecessors | Baseline start | Baseline finish | Baseline duration | Total slack | Free slack | Text11 | Text12 | Text13 | Text14 | Text16 | Text28 | Text23 |
| --- | --- | --- | --- | --- | --- | --- | --- | --- | --- | --- | --- | --- | --- | --- | --- | --- | --- | --- |
| 329 | 13.3.5 | **FM 1** | 87d | 2003-12-08 | 2004-04-12 |  | 2003-10-01 | 2004-02-17 | 93d | 0d |  | STEREO | IMPACT | SEP Package | SIT | SIT | UMD |  |
| 330 | 13.3.5.1 | Integrate SIT FM 1 HVPS and SIT FM 1 Telescope Without Electronics | 3d | 2003-12-08 | 2003-12-10 | 294, 371, 18 | 2003-10-01 | 2003-10-03 | 3d | 39d | 38d | STEREO | IMPACT | SEP Package | SIT | SIT | UMD |  |
| 331 | 13.3.5.2 | Integrate SIT FM 1Telescope | 2d | 2004-02-11 | 2004-02-12 | 260, 284, 182, 103 | 2003-10-09 | 2003-10-10 | 2d | 0d |  | STEREO | IMPACT | SEP Package | SIT | SIT | UMD | FM 1 Integrated |
| 332 | 13.3.5.3 | SIT FM 1 Debug | 5d | 2004-02-13 | 2004-02-20 | 14, 331 | 2003-10-13 | 2003-11-19 | 27d | 0d |  | STEREO | IMPACT | SEP Package | SIT | SIT | UMD |  |
| 333 | 13.3.5.4 | SIT FM 1 Bench Test | 5d | 2004-02-23 | 2004-02-27 | 332 | 2003-11-20 | 2003-12-03 | 9d | 0d |  | STEREO | IMPACT | SEP Package | SIT | SIT | UMD | FM 1 Tested |
| 334 | 13.3.5.5 | SIT FM 1 Alpha TEST | 5d | 2004-03-01 | 2004-03-05 | 333 | 2003-12-04 | 2003-12-17 | 10d | 0d |  | STEREO | IMPACT | SEP Package | SIT | SIT | UMD |  |
| 335 | 13.3.5.6 | SIT FM 1 Noise Removal | 20d | 2004-03-08 | 2004-04-02 | 334 | 2003-12-18 | 2004-01-30 | 29d | 0d |  | STEREO | IMPACT | SEP Package | SIT | SIT | UMD |  |
| 336 | 13.3.5.7 | SIT FM 1 Thermal Test | 5d | 2004-04-05 | 2004-04-09 | 335 | 2004-02-02 | 2004-02-13 | 10d | 0d |  | STEREO | IMPACT | SEP Package | SIT | SIT | UMD | FM 1 Environmentallyl Tested |
| 337 | 13.3.5.8 | SIT FM 1 Functional Test | 1d | 2004-04-12 | 2004-04-12 | 336 | 2004-02-17 | 2004-02-17 | 1d | 0d |  | STEREO | IMPACT | SEP Package | SIT | SIT | UMD |  |
| 338 | 13.3.6 | **FM 2** | 43d | 2004-02-04 | 2004-04-05 |  | 2003-12-08 | 2004-02-17 | 48d | 5d |  | STEREO | IMPACT | SEP Package | SIT | SIT | UMD |  |
| 339 | 13.3.6.1 | Integrate SIT FM 2 HVPS and SIT FM 2 Telescope Without Electronics | 3d | 2004-02-04 | 2004-02-06 | 296, 371 | 2003-12-08 | 2003-12-10 | 3d | 20d | 0d | STEREO | IMPACT | SEP Package | SIT | SIT | UMD |  |
| 340 | 13.3.6.2 | Integrate SIT FM 2 Telescope | 2d | 2004-03-04 | 2004-03-05 | 263, 287, 184, 105 | 2003-12-15 | 2003-12-16 | 2d | 5d | 0d | STEREO | IMPACT | SEP Package | SIT | SIT | UMD | FM 2 Integrated |
| 341 | 13.3.6.3 | SIT FM 2 Debug | 5d | 2004-03-08 | 2004-03-12 | 340 | 2003-12-17 | 2004-01-08 | 15d | 5d | 0d | STEREO | IMPACT | SEP Package | SIT | SIT | UMD |  |
| 342 | 13.3.6.4 | SIT FM 2 Bench Test | 5d | 2004-03-15 | 2004-03-19 | 341 | 2004-01-09 | 2004-01-23 | 10d | 5d | 0d | STEREO | IMPACT | SEP Package | SIT | SIT | UMD | FM 2 Tested |
| 343 | 13.3.6.5 | SIT FM 2 Alpha Test | 5d | 2004-03-22 | 2004-03-26 | 342 | 2004-01-26 | 2004-01-30 | 5d | 5d | 0d | STEREO | IMPACT | SEP Package | SIT | SIT | UMD |  |
| 344 | 13.3.6.6 | SIT FM 2 Thermal Test | 5d | 2004-03-29 | 2004-04-02 | 343 | 2004-02-02 | 2004-02-13 | 10d | 5d | 0d | STEREO | IMPACT | SEP Package | SIT | SIT | UMD | FM 2 Environmentally Tested |
| 345 | 13.3.6.7 | SIT FM 2 Functional Test | 1d | 2004-04-05 | 2004-04-05 | 344 | 2004-02-17 | 2004-02-17 | 1d | 5d |  | STEREO | IMPACT | SEP Package | SIT | SIT | UMD |  |
| 346 | 13.4 | **Environmental Testing at GSFC (FM 1 & FM 2)** | 19d | 2004-06-04 | 2004-06-30 |  |  |  |  | 0d |  | STEREO | IMPACT | SEP Package | SIT | SIT | UMD |  |
| 347 | 13.4.1 | Disassemble SIT Instruments | 2d | 2004-06-04 | 2004-06-07 | 34, 36 |  |  |  | 0d |  | STEREO | IMPACT | SEP Package | SIT | SIT | UMD |  |
| 348 | 13.4.2 | Bake Out | 3d | 2004-06-08 | 2004-06-10 | 347 |  |  |  | 0d |  | STEREO | IMPACT | SEP Package | SIT | SIT | UMD |  |
| 349 | 13.4.3 | Reassemble Instruments | 2d | 2004-06-11 | 2004-06-14 | 348 |  |  |  | 0d |  | STEREO | IMPACT | SEP Package | SIT | SIT | UMD |  |
| 350 | 13.4.4 | Functional Test | 2d | 2004-06-15 | 2004-06-16 | 349 |  |  |  | 0d |  | STEREO | IMPACT | SEP Package | SIT | SIT | UMD |  |
| 351 | 13.4.5 | Acoustic Test | 5d | 2004-06-17 | 2004-06-23 | 350, 91, 95 |  |  |  | 0d |  | STEREO | IMPACT | SEP Package | SIT | SIT | UMD |  |
| 352 | 13.4.6 | Vibration | 3d | 2004-06-24 | 2004-06-28 | 351 |  |  |  | 0d |  | STEREO | IMPACT | SEP Package | SIT | SIT | UMD |  |
| 353 | 13.4.7 | Functional Test | 2d | 2004-06-29 | 2004-06-30 | 352 |  |  |  | 0d |  | STEREO | IMPACT | SEP Package | SIT | SIT | UMD |  |

| ID | WBS | Task | Type | Duration | Start | Finish | Predecessors | Complete | Remaining | Baseline start | Baseline finish | Baseline duration | Total slack | Free slack | Constraint | Text11 | Text12 | Text13 | Text14 | Text16 | Text28 | Text17 |
| --- | --- | --- | --- | --- | --- | --- | --- | --- | --- | --- | --- | --- | --- | --- | --- | --- | --- | --- | --- | --- | --- | --- |
| 354 | 14 | **Emulators/Simulators/GSE** |  | 690d | 2001-11-02 A | 2004-08-02 |  | 55% | 307.3d | 2001-11-02 | 2004-03-02 | 582d | 0d |  |  | STEREO | IMPACT | SEP Package | SIT | SIT | UMD |  |
| 355 | 14.1 | **Simulators** |  | 42d | 2003-10-31 A | 2003-12-31 |  | 58% | 17.64d | 2003-11-06 | 2003-11-20 | 9d | 148d |  |  | STEREO | IMPACT | SEP Package | SIT | SIT | UMD |  |
| 356 | 14.1.1 | CPU Simulator H/W Ready | milestone | 0d | 2003-10-31 A | 2003-10-31 A |  | 100% |  | 2003-11-06 | 2003-11-07 | 2d |  |  | start no earlier than 2003-10-31 | STEREO | IMPACT | SEP Package | SIT | SIT | UMD |  |
| 357 | 14.1.2 | Labview CPU Ready |  | 2d | 2003-12-17 A | 2003-12-18 |  | 90% | 0.2d | 2003-11-06 | 2003-11-07 | 2d | 152d | 0d | start no earlier than 2003-12-17 | STEREO | IMPACT | SEP Package | SIT | SIT | UMD |  |
| 358 | 14.1.3 | Test Simulator |  | 8d | 2003-12-19 A | 2003-12-31 | 357 | 50% | 4d | 2003-11-07 | 2003-11-20 | 8d | 148d |  |  | STEREO | IMPACT | SEP Package | SIT | SIT | UMD |  |
| 359 | 14.2 | **GSE** |  | 690d | 2001-11-02 A | 2004-08-02 |  | 55% | 308.58d | 2001-11-02 | 2004-03-02 | 582d | 0d |  |  | STEREO | IMPACT | SEP Package | SIT | SIT | UMD |  |
| 360 | 14.2.1 | Pulse Generator |  | 60d | 2004-05-07 | 2004-08-02 | 60, 64 |  |  | 2003-12-04 | 2004-03-02 | 60d | 0d |  |  | STEREO | IMPACT | SEP Package | SIT | SIT | UMD |  |
| 361 | 14.2.2 | **TOF Board** |  | 554d | 2001-11-02 A | 2004-01-20 |  | 97% | 14.97d | 2001-11-02 | 2003-08-12 | 445d | 25d |  |  | STEREO | IMPACT | SEP Package | SIT | SIT | UMD |  |
| 362 | 14.2.2.1 | Construct & Test TOF GSE |  | 34d | 2001-11-02 A | 2001-12-21 A |  | 100% |  | 2001-11-02 | 2001-12-21 | 34d |  |  | start no earlier than 2001-11-02 | STEREO | IMPACT | SEP Package | SIT | SIT | UMD |  |
| 363 | 14.2.2.2 | Proto TOF Test Setup |  | 2d | 2002-01-03 A | 2002-01-04 A |  | 100% |  | 2002-01-03 | 2002-01-04 | 2d |  |  | start no earlier than 2002-01-03 | STEREO | IMPACT | SEP Package | SIT | SIT | UMD |  |
| 364 | 14.2.2.3 | Flight TOF Test Setup |  | 1d | 2004-01-20 | 2004-01-20 | 182 |  |  | 2003-08-12 | 2003-08-12 | 1d | 25d | 0d |  | STEREO | IMPACT | SEP Package | SIT | SIT | UMD |  |
| 365 | 14.2.3 | **Energy Board** |  | 5d | 2002-03-29 A | 2002-04-04 A |  | 100% |  | 2002-03-29 | 2002-04-04 | 5d |  |  |  | STEREO | IMPACT | SEP Package | SIT | SIT | UMD |  |
| 366 | 14.2.3.1 | Proto E GSE |  | 5d | 2002-03-29 A | 2002-04-04 A | 190 | 100% |  | 2002-03-29 | 2002-04-04 | 5d |  |  |  | STEREO | IMPACT | SEP Package | SIT | SIT | UMD |  |
| 367 | 14.2.4 | **Energy Board / Logic Board GSE** |  | 2d | 2003-03-03 A | 2003-03-04 A |  | 100% |  | 2003-03-03 | 2003-03-04 | 2d |  |  |  | STEREO | IMPACT | SEP Package | SIT | SIT | UMD |  |
| 368 | 14.2.4.1 | Energy Board/Logic Board Test Setup |  | 2d | 2003-03-03 A | 2003-03-04 A |  | 100% |  | 2003-03-03 | 2003-03-04 | 2d |  |  | start no earlier than 2003-03-01 | STEREO | IMPACT | SEP Package | SIT | SIT | UMD |  |
| 369 | 14.2.5 | **HVPS Setup** |  | 188d | 2002-10-01 A | 2003-07-01 A |  | 100% |  | 2002-10-01 | 2003-07-01 | 188d |  |  |  | STEREO | IMPACT | SEP Package | SIT | SIT | UMD |  |
| 370 | 14.2.5.1 | ETU HVPS Test Setup Available |  | 1d | 2002-10-01 A | 2002-10-01 A |  | 100% |  | 2002-10-01 | 2002-10-01 | 1d |  |  | start no earlier than 2002-09-30 | STEREO | IMPACT | SEP Package | SIT | SIT | UMD |  |
| 371 | 14.2.5.2 | SIT FM 1 & FM 2 HVPS Test Setup Available |  | 2d | 2003-05-30 A | 2003-07-01 A |  | 100% |  | 2003-05-30 | 2003-07-01 | 2d |  |  |  | STEREO | IMPACT | SEP Package | SIT | SIT | UMD |  |
| 372 | 14.2.6 | **Software** |  | 189.6d | 2002-07-17 A | 2003-04-18 A |  | 100% |  | 2002-07-17 | 2003-04-18 | 189.6d |  |  |  | STEREO | IMPACT | SEP Package | SIT | SIT | UMD |  |
| 373 | 8.2.5 | Display HET Housekeeping Data |  | 10d | 2003-04-01 A | 2003-04-14 A |  | 100% |  | 2003-04-01 | 2003-04-14 | 10d |  |  | start no earlier than 2003-03-31 | STEREO | IMPACT | SEP Package | SIT | SIT | GSFC | SIT |
| 374 | 8.2.4 | Display HET Pulse-Height Data |  | 10d | 2002-07-02 A | 2002-08-07 A |  | 100% |  | 2002-07-02 | 2002-08-07 | 10d |  |  | start no earlier than 2002-07-01 | STEREO | IMPACT | SEP Package | SIT | SIT | UMD | SIT |
| 375 | 8.2.3 | Display HET Rates |  | 10d | 2002-07-02 A | 2002-07-16 A |  | 100% |  | 2002-07-02 | 2002-07-16 | 10d |  |  | start no earlier than 2002-07-01 | STEREO | IMPACT | SEP Package | SIT | SIT | UMD | SIT |
| 376 | 14.2.6.4 | Display SIT Rates |  | 9d | 2002-07-17 A | 2003-04-18 A | 373, 374, 375 | 100% |  | 2002-07-17 | 2003-04-18 | 9d |  |  |  | STEREO | IMPACT | SEP Package | SIT | SIT | GSFC |  |
| 377 | 14.2.6.5 | Display SIT Pulse-Height Data |  | 10.4d | 2002-07-30 A | 2002-08-30 A | 376 | 100% |  | 2002-07-30 | 2002-08-30 | 10.4d |  |  |  | STEREO | IMPACT | SEP Package | SIT | SIT | GSFC |  |
| 378 | 14.2.6.6 | Display SIT Housekeeping |  | 10d | 2003-03-03 A | 2003-03-14 A | 377 | 100% |  | 2003-03-03 | 2003-03-14 | 10d |  |  | start no earlier than 2003-03-01 | STEREO | IMPACT | SEP Package | SIT | SIT | GSFC |  |

Notes:
- 360: Not needed until I&T at APL with the S/C.
