# STE - Suprathermal Electron Telescope Detector and SWEA - Solar Wind Electron Analyzer Detector Interfacings

Schedule from MS Project, 2001-03-06 to 2004-07-07, status date 2003-10-31, A marks actual dates.
STE and SWEA Detector I/F Development Schedule
NASA GSFC
Status Date: 10/31/2003 / Baseline Date: 01/31/2003 R1

## Calendars

- Standard w/ 10 Gov't Holidays: Mon-Fri 08:00-12:00, 13:00-17:00; Sat-Sun off. Exceptions (off unless hours are given): 2001-05-28, 2001-07-04, 2001-09-03, 2001-10-08, 2001-11-12, 2001-11-22, 2001-12-25, 2002-01-01, 2002-01-14, 2002-02-18, 2002-05-27, 2002-07-04, 2002-09-02, 2002-10-07, 2002-11-11, 2002-11-28, 2002-12-25, 2003-01-01, 2003-01-13, 2003-02-17, 2003-05-26, 2003-07-04, 2003-09-01, 2003-10-06, 2003-11-10, 2003-11-27, 2003-12-25, 2004-01-01, 2004-01-12, 2004-02-16, 2004-05-31, 2004-07-05.

## Schedule

| ID | WBS | Task | Type | Duration | Start | Finish | Predecessors | Complete | Remaining | Baseline start | Baseline finish | Baseline duration | Total slack | Free slack | Constraint | Text11 | Text12 | Text13 | Text14 | Text16 | Text28 | Text17 |
| --- | --- | --- | --- | --- | --- | --- | --- | --- | --- | --- | --- | --- | --- | --- | --- | --- | --- | --- | --- | --- | --- | --- |
| 1 | 1 | **Management** |  | 829d | 2001-03-06 A | 2004-06-21 |  | 2% | 812.75d | 2001-03-06 | 2004-05-28 | 814d | 0d |  |  | STEREO | IMPACT | Boom Suite | SSI | SWEA/STE-D and STE-U | UC-B |  |
| 2 | 1.1 | **Milestones** |  | 829d | 2001-03-06 A | 2004-06-21 |  | 2% | 812.75d | 2001-03-06 | 2004-05-28 | 814d | 0d |  |  | STEREO | IMPACT | Boom Suite | SSI | SWEA/STE-D and STE-U | UC-B | SWEA/STE-D |
| 3 | 1.1.1 | **Contingency** |  | 117d | 2004-01-06 | 2004-06-21 |  |  |  | 2003-11-20 | 2004-05-28 | 132d | 0d |  |  | STEREO | IMPACT | Boom Suite | SSI | SWEA/STE-D and STE-U | UC-B | SWEA/STE-D |
| 4 | 1.1.1.1 | STE-U FM 1 Interface Delivery for IDPU FM 1 I & T Contingency |  | 10d | 2004-01-06 | 2004-01-20 | 200 |  |  | 2003-11-20 | 2003-12-04 | 10d | 44d | 0d |  | STEREO | IMPACT | Boom Suite | SSI | SWEA/STE-D and STE-U | UC-B | STE-U |
| 5 | 1.1.1.2 | STE-U FM 2 Interface Delivery forIDPU FM 1 I & T Contingency |  | 40d | 2004-01-06 | 2004-03-03 | 210 |  |  | 2003-11-20 | 2004-01-20 | 40d | 53d | 0d |  | STEREO | IMPACT | Boom Suite | SSI | SWEA/STE-D and STE-U | UC-B | STE-U |
| 6 | 1.1.1.3 | SWEA/STE-D FM 1 Delivery for BOOM Suite I & T Contingency | milestone | 0d | 2004-04-02 | 2004-04-02 | 205 |  |  | 2004-03-12 | 2004-03-25 | 10d | 18d | 0d |  | STEREO | IMPACT | Boom Suite | SSI | SWEA/STE-D and STE-U | UC-B | SWEA/STE-D |
| 7 | 1.1.1.4 | SWEA/STE-D FM 2 Delivery for BOOM Suite I & T Contingency | milestone | 0d | 2004-06-21 | 2004-06-21 | 215 |  |  | 2004-05-10 | 2004-05-28 | 15d | 0d |  |  | STEREO | IMPACT | Boom Suite | SSI | SWEA/STE-D and STE-U | UC-B | SWEA/STE-D |
| 8 | 1.1.2 | **Receivables** |  | 386d | 2002-09-25 A | 2004-04-09 |  |  | 386d | 2002-09-25 | 2004-03-02 | 358d | 10d |  |  | STEREO | IMPACT | Boom Suite | SSI | SWEA/STE-D and STE-U | UC-B | SWEA/STE-D |
| 9 | 1.1.3.1 | Deliver SWEA ETU Detectors/Front-End With Calibration Setup to UC-B | milestone | 0d | 2002-09-25 A | 2002-09-25 A |  | 100% |  | 2002-09-25 | 2002-09-25 | 0d |  |  | finish no later than 2002-09-18 | STEREO | IMPACT | Boom Suite | SSI | SWEA/STE-D and STE-U |  |  |
| 10 | 1.1.2.2 | Receive ETU SWEA(CESR) With Calibration Setup From CESR | milestone | 0d | 2002-09-25 A | 2002-09-25 A | 9 | 100% |  | 2002-09-25 | 2002-09-25 | 0d |  |  |  | STEREO | IMPACT | Boom Suite | SSI | SWEA/STE-D and STE-U | UC-B | SWEA |
| 11 | 1.1.3.3 | Deliver SWEA FM 1 Detectors/Front-End to UC-B | milestone | 0d | 2003-12-08 | 2003-12-08 |  |  |  | 2003-11-28 | 2003-11-28 | 0d | 69d | 0d |  | STEREO | IMPACT | Boom Suite | SSI | SWEA/STE-D and STE-U |  |  |
| 12 | 1.1.2.4 | Receive FM 1 SWEA(CESR) With Calibration Setup From CESR | milestone | 0d | 2003-12-08 | 2003-12-08 | 11 |  |  | 2003-11-28 | 2003-11-28 | 0d | 73d | 55d |  | STEREO | IMPACT | Boom Suite | SSI | SWEA/STE-D and STE-U | CESR | SWEA |
| 13 | 1.1.3.5 | Deliver SWEA FM 2 Detectors/Front-End to UC-B | milestone | 0d | 2004-03-30 | 2004-03-30 |  |  |  | 2004-03-02 | 2004-03-02 | 0d | 0d |  |  | STEREO | IMPACT | Boom Suite | SSI | SWEA/STE-D and STE-U |  |  |
| 14 | 1.1.2.6 | Receive FM 2 SWEA(CESR) With Calibration Setup From CESR | milestone | 0d | 2004-03-30 | 2004-03-30 | 13 |  |  | 2004-03-02 | 2004-03-02 | 0d | 18d |  |  | STEREO | IMPACT | Boom Suite | SSI | SWEA/STE-D and STE-U | CESR | SWEA |
| 15 | 1.1.3.3.6 | Deliver SWEA/STE-D ETU LVPS | milestone | 0d | 2003-05-14 A | 2003-05-14 A |  | 100% |  | 2003-05-14 | 2003-05-14 | 0d |  |  | start no earlier than 2003-05-31 | STEREO | IMPACT | Boom Suite | SSI | SWEA/STE-D and STE-U |  |  |
| 16 | 1.1.2.8 | Receive SWEA/STE-D ETU LVPS From UC-B | milestone | 0d | 2003-05-14 A | 2003-05-14 A | 15 | 100% |  | 2003-05-14 | 2003-05-14 | 0d |  |  |  | STEREO | IMPACT | Boom Suite | SSI | SWEA/STE-D and STE-U | UC-B | LVPS |
| 17 | 1.1.3.4.6 | Deliver SWEA/STE-D FM 1 LVPS | milestone | 0d | 2004-02-12 | 2004-02-12 |  |  |  | 2003-12-30 | 2003-12-30 | 0d | 18d | 0d |  | STEREO | IMPACT | Boom Suite | SSI | SWEA/STE-D and STE-U |  |  |
| 18 | 1.1.2.10 | Receive SWEA/STE-D FM 1 LVPS From UC-B | milestone | 0d | 2004-02-12 | 2004-02-12 | 17 |  |  | 2003-12-30 | 2003-12-30 | 0d | 18d | 0d |  | STEREO | IMPACT | Boom Suite | SSI | SWEA/STE-D and STE-U | UC-B | LVPS |
| 19 | 1.1.3.5.6 | Deliver SWEA/STE-D FM 2 LVPS | milestone | 0d | 2004-04-09 | 2004-04-09 |  |  |  | 2004-02-27 | 2004-02-27 | 0d | 0d |  |  | STEREO | IMPACT | Boom Suite | SSI | SWEA/STE-D and STE-U |  |  |
| 20 | 1.1.2.12 | Receive SWEA/STE-D FM 2 LVPS From UC-B | milestone | 0d | 2004-04-09 | 2004-04-09 | 19 |  |  | 2004-02-27 | 2004-02-27 | 0d | 0d |  |  | STEREO | IMPACT | Boom Suite | SSI | SWEA/STE-D and STE-U | UC-B | LVPS |
| 21 | 1.1.5.10 | Deliver IDPU Simulator GSE Hardware for SWEA/STE | milestone | 0d | 2002-08-30 A | 2002-08-30 A |  | 100% |  | 2002-08-30 | 2002-08-30 | 0d |  |  | start no earlier than 2002-05-31 | STEREO | IMPACT | Boom Suite | SSI | SWEA/STE-D and STE-U |  |  |
| 22 | 1.1.2.14 | Receive IDPU Simulator Hardware GSE From UC-B | milestone | 0d | 2002-11-29 A | 2002-11-29 A | 21 | 100% |  | 2002-11-29 | 2002-11-29 | 0d |  |  | start no earlier than 2002-11-30 | STEREO | IMPACT | Boom Suite | SSI | SWEA/STE-D and STE-U | UC-B | IDPU |
| 23 | 1.1.5.12 | Deliver IDPU Simulator Software for SWEA/STE | milestone | 0d | 2002-11-29 A | 2002-11-29 A |  | 100% |  | 2002-11-29 | 2002-11-29 | 0d |  |  | start no earlier than 2002-10-31 | STEREO | IMPACT | Boom Suite | SSI | SWEA/STE-D and STE-U |  |  |
| 24 | 1.1.2.16 | Receive IDPU Simulator Software From UC-B | milestone | 0d | 2002-11-29 A | 2002-11-29 A | 23 | 100% |  | 2002-11-29 | 2002-11-29 | 0d |  |  | start no earlier than 2002-11-30 | STEREO | IMPACT | Boom Suite | SSI | SWEA/STE-D and STE-U | UC-B | IDPU |
| 25 | 1.1.8.1 | Deliver STE-U/D ETU For Interface Testing | milestone | 0d | 2003-06-30 A | 2003-06-30 A |  | 100% |  | 2003-06-30 | 2003-06-30 | 0d |  |  | start no earlier than 2003-06-30 | STEREO | IMPACT | Boom Suite | SSI | SWEA/STE-D and STE-U |  |  |
| 26 | 1.1.2.18 | Receive STE-U/D ETU w/Detectors | milestone | 0d | 2003-06-12 A | 2003-06-12 A | 25 | 100% |  | 2003-06-12 | 2003-06-12 | 0d |  |  |  | STEREO | IMPACT | Boom Suite | SSI | SWEA/STE-D and STE-U | UC-B | SWEA/STE-D |
| 27 | 1.1.8.7 | Deliver STE-D FM 1 For SWEA/STE-D I & T | milestone | 0d | 2004-02-10 | 2004-02-10 |  |  |  | 2004-01-13 | 2004-01-13 | 0d | 30d | 0d |  | STEREO | IMPACT | Boom Suite | SSI | SWEA/STE-D and STE-U |  |  |
| 28 | 1.1.2.20 | Receive STE-D FM 1 w/Detectors | milestone | 0d | 2004-02-10 | 2004-02-10 | 27 |  |  | 2004-01-13 | 2004-01-13 | 0d | 30d | 12d |  | STEREO | IMPACT | Boom Suite | SSI | SWEA/STE-D and STE-U | UC-B | SWEA/STE-D |
| 29 | 1.1.8.9 | Deliver STE-D FM 2 For SWEA/STE-D I & T | milestone | 0d | 2004-02-20 | 2004-02-20 |  |  |  | 2004-01-22 | 2004-01-22 | 0d | 26d | 0d |  | STEREO | IMPACT | Boom Suite | SSI | SWEA/STE-D and STE-U |  |  |
| 30 | 1.1.2.22 | Receive STE-D FM 2 w/Detectors | milestone | 0d | 2004-02-20 | 2004-02-20 | 29 |  |  | 2004-01-22 | 2004-01-22 | 0d | 45d |  |  | STEREO | IMPACT | Boom Suite | SSI | SWEA/STE-D and STE-U | UC-B | SWEA/STE-D |

Notes:
- 4: Removed 269 days of duration 1/9/03
- 5: Removed 296 days of duration 1/9/03

| ID | WBS | Task | Type | Duration | Start | Finish | Predecessors | Complete | Remaining | Baseline start | Baseline finish | Baseline duration | Total slack | Free slack | Constraint | Text11 | Text12 | Text13 | Text14 | Text16 | Text17 | Text28 | Text20 | Text22 | Text23 | Text21 |
| --- | --- | --- | --- | --- | --- | --- | --- | --- | --- | --- | --- | --- | --- | --- | --- | --- | --- | --- | --- | --- | --- | --- | --- | --- | --- | --- |
| 31 | 1.1.3 | **Deliverables** |  | 829d | 2001-03-06 A | 2004-06-21 |  | 99% | 0d | 2001-03-06 | 2004-05-28 | 814d | 0d |  |  | STEREO | IMPACT | Boom Suite | SSI | SWEA/STE-D and STE-U | SWEA/STE-D | UC-B |  |  |  |  |
| 32 | 1.1.3.1 | Deliver SWEA ICD Draft to CESR |  | 1d | 2001-03-06 A | 2001-03-06 A | 54 | 100% |  | 2001-03-06 | 2001-03-06 | 1d |  |  |  | STEREO | IMPACT | Boom Suite | SSI | SWEA/STE-D and STE-U | SWEA | UC-B | SWEA ICD Draft |  |  |  |
| 33 | 1.1.2.2 | Receive SWEA ICD Draft |  | 1d | 2001-03-06 A | 2001-03-06 A | 32 | 100% |  | 2001-03-06 | 2001-03-06 | 1d |  |  |  | STEREO | IMPACT | Boom Suite | SSI | SWEA/STE-D and STE-U |  |  |  |  |  |  |
| 34 | 1.1.3.3 | Deliver SWEA/STE-D FM 1 For FM 1 BOOM Suite I & T | milestone | 0d | 2004-04-02 | 2004-04-02 | 6 |  |  | 2004-03-25 | 2004-03-25 | 0d | 18d | 0d |  | STEREO | IMPACT | Boom Suite | SSI | SWEA/STE-D and STE-U | SWEA/STE-D | UC-B | FM 1 SWEA/STE-D I/F | SWEA - FM 1 Complete | Deliver SWEA/STE-D For Suite I & T |  |
| 35 | 1.2.5.2.8 | Receive SWEA/STE-D FM 1 For BOOM Suite I & T | milestone | 0d | 2004-04-05 | 2004-04-05 | 34FS+1d |  |  | 2004-03-26 | 2004-03-26 | 0d | 18d | 0d |  | STEREO | IMPACT | Boom Suite | SSI | SWEA/STE-D and STE-U |  |  |  |  |  |  |
| 36 | 1.1.3.5 | Deliver SWEA/STE-D ETU For IDPU Interface Test | milestone | 0d | 2003-06-27 A | 2003-06-27 A | 194 | 100% |  | 2003-06-27 | 2003-06-27 | 0d |  |  |  | STEREO | IMPACT | Boom Suite | SSI | SWEA/STE-D and STE-U | SWEA/STE-D | UC-B | ETU SWEA/STE-D I/F | SWEA - ETU Complete | Deliver SWEA/STE-D ETU For IDPU I & T |  |
| 37 | 1.1.4.16 | Receive ETU SWEA/STE-D For ETU IDPU Test | milestone | 0d | 2003-06-27 A | 2003-06-27 A | 36 | 100% |  | 2003-06-27 | 2003-06-27 | 0d |  |  |  | STEREO | IMPACT | Boom Suite | SSI | SWEA/STE-D and STE-U |  |  |  |  |  |  |
| 38 | 1.1.3.7 | Deliver SWEA/STE-D FM 2 For FM 2 BOOM Suite I & T | milestone | 0d | 2004-06-21 | 2004-06-21 | 7 |  |  | 2004-05-28 | 2004-05-28 | 0d | 0d |  |  | STEREO | IMPACT | Boom Suite | SSI | SWEA/STE-D and STE-U | SWEA/STE-D | UC-B | FM 2 SWEA/STE-D I/F | SWEA - FM 2 Complete | Deliver SWEA/STE-D For Suite I & T | FM2 Cmplt. |
| 39 | 1.2.5.3.14 | Receive SWEA/STE-D FM 2 For BOOM Suite I & T | milestone | 0d | 2004-06-21 | 2004-06-21 | 38FF |  |  | 2004-05-28 | 2004-05-28 | 0d | 13d | 0d |  | STEREO | IMPACT | Boom Suite | SSI | SWEA/STE-D and STE-U |  |  |  |  |  |  |
| 40 | 1.1.3.9 | (OBSOLETE) Deliver STE-U ETU Interface for IDPU STE-U Interface Test | milestone | 0d | 2003-06-30 A | 2003-06-30 A | 198 | 100% |  | 2003-06-30 | 2003-06-30 | 0d |  |  | start no earlier than 2003-02-01 | STEREO | IMPACT | Boom Suite | SSI | SWEA/STE-D and STE-U | STE-U | UC-B |  |  |  | ETU I/F Complete |
| 41 | 1.1.4.18 | (OBSOLETE) Receive ETU STE-U For ETU IDPU Test | milestone | 0d | 2003-06-30 A | 2003-06-30 A | 40 | 100% |  | 2003-06-30 | 2003-06-30 | 0d |  |  |  | STEREO | IMPACT | Boom Suite | SSI | SWEA/STE-D and STE-U |  |  |  |  |  |  |
| 42 | 1.1.3.11 | Deliver STE-U FM 1 Interface For IDPU FM 1 I & T | milestone | 0d | 2004-01-20 | 2004-01-20 | 4 |  |  | 2003-12-04 | 2003-12-04 | 0d | 44d | 0d |  | STEREO | IMPACT | Boom Suite | SSI | SWEA/STE-D and STE-U | STE-U | UC-B | FM 1 STE-U I/F | Deliver STE-U FM 1 Interface For IDPU FM 1 I & T | Deliver FM 1 STE-U I/F for I & T |  |
| 43 | 1.1.4.33 | Receive FM 1 STE-U I/F For IDPU/STE-U I/F Testing | milestone | 0d | 2004-01-20 | 2004-01-20 | 42 |  |  | 2003-12-04 | 2003-12-04 | 0d | 44d | 16d |  | STEREO | IMPACT | Boom Suite | SSI | SWEA/STE-D and STE-U |  |  |  |  |  |  |
| 44 | 1.1.3.13 | Deliver SWEA / STE-D ETU Testing Results | milestone | 0d | 2003-07-17 A | 2003-07-17 A | 196 | 100% |  | 2003-07-17 | 2003-07-17 | 0d |  |  |  | STEREO | IMPACT | Boom Suite | SSI | SWEA/STE-D and STE-U | SWEA/STE-D | UC-B |  |  |  |  |
| 45 | 1.1.2.4 | Receive SWEA/STE Interface Test Results | milestone | 0d | 2003-07-17 A | 2003-07-17 A | 44 | 100% |  | 2003-07-17 | 2003-07-17 | 0d |  |  |  | STEREO | IMPACT | Boom Suite | SSI | SWEA/STE-D and STE-U |  |  |  |  |  |  |
| 46 | 1.1.3.15 | Deliver STE-U FM 2 Interface For IDPU FM 2 I & T | milestone | 0d | 2004-03-03 | 2004-03-03 | 5 |  |  | 2004-01-20 | 2004-01-20 | 0d | 53d | 0d |  | STEREO | IMPACT | Boom Suite | SSI | SWEA/STE-D and STE-U | STE-U | UC-B | FM 2 STE-U I/F | Deliver STE-U FM 2 Interface For IDPU FM 2 I & T | Deliver FM 2 STE-U I/F for I & T | FM2 Cmplt. |
| 47 | 1.1.4.36 | Receive FM 2 STE-U I/F For IDPU/STE-U I/F Testing | milestone | 0d | 2004-03-03 | 2004-03-03 | 46 |  |  | 2004-01-20 | 2004-01-20 | 0d | 53d | 26d |  | STEREO | IMPACT | Boom Suite | SSI | SWEA/STE-D and STE-U |  |  |  |  |  |  |
| 48 | 1.1.3.17 | Deliver SWEA/STE-D ETU/SWEA LVPS ETU I/F Test Results | milestone | 0d | 2003-07-02 A | 2003-07-02 A | 195 | 100% |  | 2003-07-02 | 2003-07-02 | 0d |  |  |  | STEREO | IMPACT | Boom Suite | SSI | SWEA/STE-D and STE-U |  |  |  |  |  |  |
| 49 | 1.1.2.8 | Receive SWEA LVPS ETU/SWEA I/F Test Results | milestone | 0d | 2003-07-14 A | 2003-07-14 A | 48 | 100% |  | 2003-07-14 | 2003-07-14 | 0d |  |  |  | STEREO | IMPACT | Boom Suite | SSI | SWEA/STE-D and STE-U |  |  |  |  |  |  |
| 50 | 1.2 | **Documentation** |  | 0d | 2003-11-05 A | 2003-11-05 A |  | 100% |  | 2003-10-01 | 2003-10-01 | 1d |  |  |  | STEREO | IMPACT | Boom Suite | SSI | SWEA/STE-D and STE-U | SWEA/STE-D | UC-B |  |  |  |  |
| 51 | 1.2.1 | STE Weak Source Paperwork | milestone | 0d | 2003-11-05 A | 2003-11-05 A |  | 100% |  | 2003-10-01 | 2003-10-01 | 1d |  |  | start no earlier than 2003-11-05 | STEREO | IMPACT | Boom Suite | SSI | SWEA/STE-D and STE-U | STE | UC-B |  |  | STE Weak Radiation Source Paperwork Processed |  |
| 52 | 2 | **Systems Engineering** |  | 236d | 2001-03-06 A | 2002-02-11 A |  | 100% |  | 2001-03-06 | 2002-02-11 | 236d |  |  |  | STEREO | IMPACT | Boom Suite | SSI | SWEA/STE-D and STE-U | SWEA/STE-D | UC-B |  |  |  |  |
| 53 | 2.1 | **Documentation** |  | 236d | 2001-03-06 A | 2002-02-11 A |  | 100% |  | 2001-03-06 | 2002-02-11 | 236d |  |  |  | STEREO | IMPACT | Boom Suite | SSI | SWEA/STE-D and STE-U | SWEA/STE-D | UC-B |  |  |  |  |
| 54 | 2.1.1 | SWEA ICD Draft |  | 1d | 2001-03-06 A | 2001-03-06 A |  | 100% |  | 2001-03-06 | 2001-03-06 | 1d |  |  | start no earlier than 2001-03-06 | STEREO | IMPACT | Boom Suite | SSI | SWEA/STE-D and STE-U | SWEA | UC-B |  |  |  |  |
| 55 | 2.1.2 | SWEA / STE-D Interface FPGA Specification |  | 28d | 2002-01-02 A | 2002-02-11 A | 71 | 100% |  | 2002-01-02 | 2002-02-11 | 28d |  |  | start no earlier than 2002-01-02 | STEREO | IMPACT | Boom Suite | SSI | SWEA/STE-D and STE-U | SWEA/STE-D | UC-B |  |  |  |  |

Notes:
- 34: March 03 status - since these are all UCB activities dropped deilviery lag of 5 days to 1 day.
- 40: Same as for STE-D only need one board for ETU purposes. The flight boards will need to be built

| ID | WBS | Task | Type | Duration | Start | Finish | Predecessors | Complete | Remaining | Baseline start | Baseline finish | Baseline duration | Total slack | Free slack | Constraint | Text11 | Text12 | Text13 | Text14 | Text16 | Text17 | Text28 | Text23 | Text21 |
| --- | --- | --- | --- | --- | --- | --- | --- | --- | --- | --- | --- | --- | --- | --- | --- | --- | --- | --- | --- | --- | --- | --- | --- | --- |
| 56 | 3 | **SWEA Pedestal** |  | 519d | 2001-10-29 A | 2003-11-21 |  | 92% | 38.96d | 2001-10-29 | 2003-09-10 | 469d | 75d |  |  | STEREO | IMPACT | Boom Suite | SSI | SWEA/STE-D and STE-U | SWEA | UC-B |  |  |
| 57 | 3.1 | **Design, Manufacture, Assembly and Test** |  | 519d | 2001-10-29 A | 2003-11-21 |  | 92% | 38.96d | 2001-10-29 | 2003-09-10 | 469d | 75d |  |  | STEREO | IMPACT | Boom Suite | SSI | SWEA/STE-D and STE-U | SWEA | UC-B |  |  |
| 58 | 3.1.1 | **Design** |  | 173d | 2001-10-29 A | 2002-07-08 A |  | 100% |  | 2001-10-29 | 2002-07-08 | 173d |  |  |  | STEREO | IMPACT | Boom Suite | SSI | SWEA/STE-D and STE-U | SWEA | UC-B |  |  |
| 59 | 3.1.1.1 | SWEA Baseplate Design |  | 173d | 2001-10-29 A | 2002-07-08 A | 70 | 100% |  | 2001-10-29 | 2002-07-08 | 173d |  |  |  | STEREO | IMPACT | Boom Suite | SSI | SWEA/STE-D and STE-U | SWEA | UC-B |  |  |
| 60 | 3.1.2 | **Fabrication** |  | 100d | 2003-07-01 A | 2003-11-21 |  | 86% | 14d | 2003-07-01 | 2003-09-10 | 50d | 75d |  |  | STEREO | IMPACT | Boom Suite | SSI | SWEA/STE-D and STE-U | SWEA | UC-B |  |  |
| 61 | 3.1.2.1 | **FM 1 & FM 2** |  | 100d | 2003-07-01 A | 2003-11-21 |  | 86% | 14d | 2003-07-01 | 2003-09-10 | 50d | 75d |  |  | STEREO | IMPACT | Boom Suite | SSI | SWEA/STE-D and STE-U | SWEA | UC-B |  |  |
| 62 | 3.1.2.1.1 | **FM 1** |  | 100d | 2003-07-01 A | 2003-11-21 |  | 86% | 14d | 2003-07-01 | 2003-09-10 | 50d | 53d |  |  | STEREO | IMPACT | Boom Suite | SSI | SWEA/STE-D and STE-U | SWEA | UC-B |  |  |
| 63 | 3.1.2.1.1.1 | Fabricate SWEA FM 1 Baseplate |  | 100d | 2003-07-01 A | 2003-11-21 | 59, 79 | 86% | 14d | 2003-07-01 | 2003-09-10 | 50d | 53d | 24d | start no earlier than 2003-07-01 | STEREO | IMPACT | Boom Suite | SSI | SWEA/STE-D and STE-U | SWEA | UC-B | FM 1 SWEA Baseplate Fabricated |  |
| 64 | 3.1.2.1.2 | **FM 2** |  | 100d | 2003-07-01 A | 2003-11-21 |  | 86% | 14d | 2003-07-01 | 2003-09-10 | 50d | 75d |  |  | STEREO | IMPACT | Boom Suite | SSI | SWEA/STE-D and STE-U | SWEA | UC-B |  |  |
| 65 | 3.1.2.1.2.1 | Fabricate SWEA FM 2 Baseplate |  | 100d | 2003-07-01 A | 2003-11-21 | 59, 79 | 86% | 14d | 2003-07-01 | 2003-09-10 | 50d | 75d | 24d | start no earlier than 2003-07-01 | STEREO | IMPACT | Boom Suite | SSI | SWEA/STE-D and STE-U | SWEA | UC-B | FM 2 SWEA Baseplate Fabricated |  |
| 66 | 4 | **STE-D Pre-Amp Board** |  | 695d | 2001-03-06 A | 2003-12-09 |  | 90% | 71.43d | 2001-03-06 | 2003-10-21 | 662d | 64d |  |  | STEREO | IMPACT | Boom Suite | SSI | SWEA/STE-D and STE-U | SWEA/STE-D | UC-B |  |  |
| 67 | 4.1 | SWEA / STE Design Complete |  | 1d | 2002-11-13 A | 2002-11-13 A | 72FF-1d | 100% |  | 2002-11-13 | 2002-11-13 | 1d |  |  |  | STEREO | IMPACT | Boom Suite | SSI | SWEA/STE-D and STE-U |  | UC-B |  | Design Complete |
| 68 | 4.2 | **Design, Manufacture, Assembly and Test** |  | 695d | 2001-03-06 A | 2003-12-09 |  | 90% | 71.73d | 2001-03-06 | 2003-10-21 | 662d | 64d |  |  | STEREO | IMPACT | Boom Suite | SSI | SWEA/STE-D and STE-U | SWEA/STE-D | UC-B |  |  |
| 69 | 4.2.1 | **Design** |  | 428d | 2001-03-06 A | 2002-11-14 A |  | 100% |  | 2001-03-06 | 2002-11-14 | 428d |  |  |  | STEREO | IMPACT | Boom Suite | SSI | SWEA/STE-D and STE-U | SWEA/STE-D | UC-B |  |  |
| 70 | 4.2.1.1 | SWEA / STE Printed Wiring Board Form Factor |  | 10d | 2001-10-15 A | 2001-10-26 A | 54 | 100% |  | 2001-10-15 | 2001-10-26 | 10d |  |  | start no earlier than 2001-10-15 | STEREO | IMPACT | Boom Suite | SSI | SWEA/STE-D and STE-U | SWEA/STE-D | UC-B |  |  |
| 71 | 4.2.1.2 | SWEA / STE-D Interface Design |  | 20d | 2001-03-06 A | 2001-04-02 A | 54 | 100% |  | 2001-03-06 | 2001-04-02 | 20d |  |  |  | STEREO | IMPACT | Boom Suite | SSI | SWEA/STE-D and STE-U | SWEA/STE-D | UC-B |  | Begin SWEA/STE I/F Design |
| 72 | 4.2.1.3 | SWEA / STE-D Interface FPGA Design |  | 88.74d | 2002-02-12 A | 2002-11-14 A | 55, 121 | 100% |  | 2002-02-12 | 2002-11-14 | 88.74d |  |  | finish no earlier than 2002-08-08 | STEREO | IMPACT | Boom Suite | SSI | SWEA/STE-D and STE-U | SWEA/STE-D | UC-B |  |  |
| 73 | 4.2.1.4 | Layout STE-D Preamp Printed Wiring Board |  | 15.25d | 2002-04-29 A | 2002-08-01 A | 55, 70 | 100% |  | 2002-04-29 | 2002-08-01 | 15.25d |  |  |  | STEREO | IMPACT | Boom Suite | SSI | SWEA/STE-D and STE-U | SWEA/STE-D | UC-B |  |  |
| 74 | 4.2.2 | **Fabrication** |  | 320d | 2002-08-01 A | 2003-11-07 A |  | 100% |  | 2002-08-01 | 2003-09-22 | 287d |  |  |  | STEREO | IMPACT | Boom Suite | SSI | SWEA/STE-D and STE-U | SWEA/STE-D | UC-B |  |  |
| 75 | 4.2.2.1 | **ETU** |  | 10d | 2002-08-01 A | 2002-08-14 A |  | 100% |  | 2002-08-01 | 2002-08-14 | 10d |  |  |  | STEREO | IMPACT | Boom Suite | SSI | SWEA/STE-D and STE-U | SWEA/STE-D | UC-B |  |  |
| 76 | 4.2.2.1.1 | Fabricate STE-D ETU Preamp Printed Wiring Board |  | 10d | 2002-08-01 A | 2002-08-14 A | 73 | 100% |  | 2002-08-01 | 2002-08-14 | 10d |  |  | start no earlier than 2002-07-31 | STEREO | IMPACT | Boom Suite | SSI | SWEA/STE-D and STE-U | SWEA/STE-D | UC-B |  |  |
| 77 | 4.2.2.2 | **FM 1 & FM 2** |  | 34d | 2003-09-22 A | 2003-11-07 A |  | 100% |  | 2003-09-10 | 2003-09-22 | 9d |  |  |  | STEREO | IMPACT | Boom Suite | SSI | SWEA/STE-D and STE-U | SWEA/STE-D | UC-B |  |  |
| 78 | 4.2.2.2.1 | **FM 1** |  | 34d | 2003-09-22 A | 2003-11-07 A |  | 100% |  | 2003-09-10 | 2003-09-22 | 9d |  |  |  | STEREO | IMPACT | Boom Suite | SSI | SWEA/STE-D and STE-U | SWEA/STE-D | UC-B |  |  |
| 79 | 1.1.11 | Instrument CDR | milestone | 3d | 2002-11-20 A | 2002-11-22 A |  | 100% |  | 2002-11-20 | 2002-11-22 | 3d |  |  | finish no earlier than 2002-11-22 | STEREO | IMPACT | Boom Suite | SSI | SWEA/STE-D and STE-U |  |  |  |  |
| 80 | 4.2.2.2.1.2 | Fabricate STE-D FM 1 Preamp Printed Wiring Board |  | 34d | 2003-09-22 A | 2003-11-07 A | 79, 197 | 100% |  | 2003-09-10 | 2003-09-22 | 9d |  |  | start no earlier than 2003-09-22 | STEREO | IMPACT | Boom Suite | SSI | SWEA/STE-D and STE-U | SWEA/STE-D | UC-B | STE-D FM 1 Preamp PWB Fabricated |  |

| ID | WBS | Task | Duration | Start | Finish | Predecessors | Complete | Remaining | Baseline start | Baseline finish | Baseline duration | Total slack | Free slack | Constraint | Text11 | Text12 | Text13 | Text14 | Text16 | Text17 | Text28 | Text23 |
| --- | --- | --- | --- | --- | --- | --- | --- | --- | --- | --- | --- | --- | --- | --- | --- | --- | --- | --- | --- | --- | --- | --- |
| 81 | 4.2.2.2.2 | **FM 2** | 34d | 2003-09-22 A | 2003-11-07 A |  | 100% |  | 2003-09-10 | 2003-09-22 | 9d |  |  |  | STEREO | IMPACT | Boom Suite | SSI | SWEA/STE-D and STE-U | SWEA/STE-D | UC-B |  |
| 82 | 4.2.2.2.2.1 | Fabricate STE-D FM 2 Preamp Printed Wiring Board | 34d | 2003-09-22 A | 2003-11-07 A | 79, 197 | 100% |  | 2003-09-10 | 2003-09-22 | 9d |  |  | start no earlier than 2003-09-22 | STEREO | IMPACT | Boom Suite | SSI | SWEA/STE-D and STE-U | SWEA/STE-D | UC-B | STE-D FM 2 Preamp PWB Fabricated |
| 83 | 4.2.3 | **Assembly** | 331d | 2002-08-14 A | 2003-12-09 |  | 34% | 217.05d | 2002-08-14 | 2003-10-21 | 298d | 64d |  |  | STEREO | IMPACT | Boom Suite | SSI | SWEA/STE-D and STE-U | SWEA/STE-D | UC-B |  |
| 84 | 4.2.3.1 | **ETU** | 37d | 2002-08-14 A | 2002-10-04 A |  | 100% |  | 2002-08-14 | 2002-10-04 | 37d |  |  |  | STEREO | IMPACT | Boom Suite | SSI | SWEA/STE-D and STE-U | SWEA/STE-D | UC-B |  |
| 85 | 4.2.3.1.1 | Load STE-D ETU Preamp Printed Wiring Board | 5.25d | 2002-08-14 A | 2002-10-04 A | 76 | 100% |  | 2002-08-14 | 2002-10-04 | 5.25d |  |  |  | STEREO | IMPACT | Boom Suite | SSI | SWEA/STE-D and STE-U | SWEA/STE-D | UC-B |  |
| 86 | 4.2.3.2 | **FM 1** | 5d | 2003-12-03 | 2003-12-09 |  |  |  | 2003-10-15 | 2003-10-21 | 5d | 42d |  |  | STEREO | IMPACT | Boom Suite | SSI | SWEA/STE-D and STE-U | SWEA/STE-D | UC-B |  |
| 87 | 4.2.3.2.1 | Load STE-D FM 1 Preamp Printed Wiring Board | 5d | 2003-12-03 | 2003-12-09 | 92 |  |  | 2003-10-15 | 2003-10-21 | 5d | 42d | 13d |  | STEREO | IMPACT | Boom Suite | SSI | SWEA/STE-D and STE-U | SWEA/STE-D | UC-B | STE-D FM 1 Preamp PWB Loaded |
| 88 | 4.2.3.3 | **FM 2** | 5d | 2003-12-03 | 2003-12-09 |  |  |  | 2003-10-15 | 2003-10-21 | 5d | 64d |  |  | STEREO | IMPACT | Boom Suite | SSI | SWEA/STE-D and STE-U | SWEA/STE-D | UC-B |  |
| 89 | 4.2.3.3.1 | Load STE-D FM 2 Preamp Printed Wiring Board | 5d | 2003-12-03 | 2003-12-09 | 92 |  |  | 2003-10-15 | 2003-10-21 | 5d | 64d | 13d |  | STEREO | IMPACT | Boom Suite | SSI | SWEA/STE-D and STE-U | SWEA/STE-D | UC-B | STE-D FM 2 Preamp PWB Loaded |
| 90 | 4.2.4 | **Test** | 15d | 2003-11-11 | 2003-12-02 |  |  |  | 2003-09-23 | 2003-10-14 | 15d | 42d |  |  | STEREO | IMPACT | Boom Suite | SSI | SWEA/STE-D and STE-U | SWEA/STE-D | UC-B |  |
| 91 | 4.2.4.1 | **FM 1 & FM 2** | 15d | 2003-11-11 | 2003-12-02 |  |  |  | 2003-09-23 | 2003-10-14 | 15d | 42d |  |  | STEREO | IMPACT | Boom Suite | SSI | SWEA/STE-D and STE-U | SWEA/STE-D | UC-B |  |
| 92 | 4.2.4.1.1 | Coupon Test STE-U FM 1 & FM 2 Shaper & Interface Printed Wiring Board | 15d | 2003-11-11 | 2003-12-02 | 82, 80 |  |  | 2003-09-23 | 2003-10-14 | 15d | 42d | 0d |  | STEREO | IMPACT | Boom Suite | SSI | SWEA/STE-D and STE-U | SWEA/STE-D | UC-B |  |
| 93 | 5 | **STE-D Shaper Board** | 418d | 2002-04-29 A | 2003-12-26 |  | 41% | 247.75d | 2002-04-29 | 2003-10-28 | 378d | 52d |  |  | STEREO | IMPACT | Boom Suite | SSI | SWEA/STE-D and STE-U | SWEA/STE-D | UC-B |  |
| 94 | 5.1 | **Design, Manufacture, Assembly and Test** | 418d | 2002-04-29 A | 2003-12-26 |  | 41% | 247.75d | 2002-04-29 | 2003-10-28 | 378d | 52d |  |  | STEREO | IMPACT | Boom Suite | SSI | SWEA/STE-D and STE-U | SWEA/STE-D | UC-B |  |
| 95 | 5.1.1 | **Design** | 68d | 2002-04-29 A | 2002-08-02 A |  | 100% |  | 2002-04-29 | 2002-08-02 | 68d |  |  |  | STEREO | IMPACT | Boom Suite | SSI | SWEA/STE-D and STE-U | SWEA/STE-D | UC-B |  |
| 96 | 5.1.1.1 | Layout STE-D ETU Shaper Printed Wiring Board | 14.55d | 2002-04-29 A | 2002-08-02 A | 73 | 100% |  | 2002-04-29 | 2002-08-02 | 14.55d |  |  |  | STEREO | IMPACT | Boom Suite | SSI | SWEA/STE-D and STE-U | SWEA/STE-D | UC-B |  |
| 97 | 5.1.2 | **Fabrication** | 332d | 2002-08-02 A | 2003-11-28 |  | 35% | 214.19d | 2002-08-02 | 2003-09-30 | 292d | 30d |  |  | STEREO | IMPACT | Boom Suite | SSI | SWEA/STE-D and STE-U | SWEA/STE-D | UC-B |  |
| 98 | 5.1.2.1 | **ETU** | 11d | 2002-08-02 A | 2002-08-16 A |  | 100% |  | 2002-08-02 | 2002-08-16 | 11d |  |  |  | STEREO | IMPACT | Boom Suite | SSI | SWEA/STE-D and STE-U | SWEA/STE-D | UC-B |  |
| 99 | 5.1.2.1.1 | Fabricate STE-D ETU Shaper Printed Wiring Board | 11d | 2002-08-02 A | 2002-08-16 A | 96 | 100% |  | 2002-08-02 | 2002-08-16 | 11d |  |  | start no earlier than 2002-07-31 | STEREO | IMPACT | Boom Suite | SSI | SWEA/STE-D and STE-U | SWEA/STE-D | UC-B |  |
| 100 | 5.1.2.2 | **FM 1 & FM 2** | 10d | 2003-11-14 | 2003-11-28 |  |  |  | 2003-09-17 | 2003-09-30 | 10d | 30d |  |  | STEREO | IMPACT | Boom Suite | SSI | SWEA/STE-D and STE-U | SWEA/STE-D | UC-B |  |
| 101 | 5.1.2.2.1 | **FM 1** | 10d | 2003-11-14 | 2003-11-28 |  |  |  | 2003-09-17 | 2003-09-30 | 10d | 30d |  |  | STEREO | IMPACT | Boom Suite | SSI | SWEA/STE-D and STE-U | SWEA/STE-D | UC-B |  |
| 102 | 6.1.2.1.1 | Fabricate STE-D FM 1 Shaper Printed Wiring Board | 10d | 2003-11-14 | 2003-11-28 | 79, 197 |  |  | 2003-09-17 | 2003-09-30 | 10d | 30d | 0d | start no earlier than 2003-11-14 | STEREO | IMPACT | Boom Suite | SSI | SWEA/STE-D and STE-U | SWEA/STE-D | UC-B | STE-D FM 1 Shaper PWB Fabricated |
| 103 | 5.1.2.2.2 | **FM 2** | 10d | 2003-11-14 | 2003-11-28 |  |  |  | 2003-09-17 | 2003-09-30 | 10d | 30d |  |  | STEREO | IMPACT | Boom Suite | SSI | SWEA/STE-D and STE-U | SWEA/STE-D | UC-B |  |
| 104 | 6.1.2.1.1 | Fabricate STE-D FM 2 Shaper Printed Wiring Board | 10d | 2003-11-14 | 2003-11-28 | 79, 197 |  |  | 2003-09-17 | 2003-09-30 | 10d | 30d | 0d | start no earlier than 2003-11-14 | STEREO | IMPACT | Boom Suite | SSI | SWEA/STE-D and STE-U | SWEA/STE-D | UC-B | STE-D FM 2 Shaper PWB Fabricated |

| ID | WBS | Task | Duration | Start | Finish | Predecessors | Complete | Remaining | Baseline start | Baseline finish | Baseline duration | Total slack | Free slack | Constraint | Text11 | Text12 | Text13 | Text14 | Text16 | Text17 | Text28 | Text23 |
| --- | --- | --- | --- | --- | --- | --- | --- | --- | --- | --- | --- | --- | --- | --- | --- | --- | --- | --- | --- | --- | --- | --- |
| 105 | 5.1.3 | **Assembly** | 330d | 2002-09-03 A | 2003-12-26 |  | 33% | 220d | 2002-09-03 | 2003-10-28 | 290d | 52d |  |  | STEREO | IMPACT | Boom Suite | SSI | SWEA/STE-D and STE-U | SWEA/STE-D | UC-B |  |
| 106 | 5.1.3.1 | **ETU** | 23d | 2002-09-03 A | 2002-10-03 A |  | 100% |  | 2002-09-03 | 2002-10-03 | 23d |  |  |  | STEREO | IMPACT | Boom Suite | SSI | SWEA/STE-D and STE-U | SWEA/STE-D | UC-B |  |
| 107 | 5.1.3.1.1 | Load STE-D ETU Shaper Printed Wiring Board | 4d | 2002-09-03 A | 2002-10-03 A | 99 | 100% |  | 2002-09-03 | 2002-10-03 | 4d |  |  | start no earlier than 2002-08-31 | STEREO | IMPACT | Boom Suite | SSI | SWEA/STE-D and STE-U | SWEA/STE-D | UC-B |  |
| 108 | 5.1.3.2 | **FM 1** | 4d | 2003-12-22 | 2003-12-26 |  |  |  | 2003-10-23 | 2003-10-28 | 4d | 30d |  |  | STEREO | IMPACT | Boom Suite | SSI | SWEA/STE-D and STE-U | SWEA/STE-D | UC-B |  |
| 109 | 5.1.3.2.1 | Load STE-D FM 1 Shaper Printed Wiring Board | 4d | 2003-12-22 | 2003-12-26 | 114 |  |  | 2003-10-23 | 2003-10-28 | 4d | 30d | 1d |  | STEREO | IMPACT | Boom Suite | SSI | SWEA/STE-D and STE-U | SWEA/STE-D | UC-B | STE-D FM 1 Shaper PWB Loaded |
| 110 | 5.1.3.3 | **FM 2** | 4d | 2003-12-22 | 2003-12-26 |  |  |  | 2003-10-23 | 2003-10-28 | 4d | 52d |  |  | STEREO | IMPACT | Boom Suite | SSI | SWEA/STE-D and STE-U | SWEA/STE-D | UC-B |  |
| 111 | 5.1.3.3.1 | Load STE-D FM 2 Shaper Printed Wiring Board | 4d | 2003-12-22 | 2003-12-26 | 114 |  |  | 2003-10-23 | 2003-10-28 | 4d | 52d | 1d |  | STEREO | IMPACT | Boom Suite | SSI | SWEA/STE-D and STE-U | SWEA/STE-D | UC-B | STE-D FM 2 Shaper PWB Loaded |
| 112 | 5.1.4 | **Test** | 15d | 2003-12-01 | 2003-12-19 |  |  |  | 2003-10-01 | 2003-10-22 | 15d | 30d |  |  | STEREO | IMPACT | Boom Suite | SSI | SWEA/STE-D and STE-U | SWEA/STE-D | UC-B |  |
| 113 | 5.1.4.1 | **FM 1 & FM 2** | 15d | 2003-12-01 | 2003-12-19 |  |  |  | 2003-10-01 | 2003-10-22 | 15d | 30d |  |  | STEREO | IMPACT | Boom Suite | SSI | SWEA/STE-D and STE-U | SWEA/STE-D | UC-B |  |
| 114 | 5.1.4.1.1 | Coupon Test STE-U FM 1 & FM 2 Shaper & Interface Printed Wiring Board | 15d | 2003-12-01 | 2003-12-19 | 102, 104 |  |  | 2003-10-01 | 2003-10-22 | 15d | 30d | 0d |  | STEREO | IMPACT | Boom Suite | SSI | SWEA/STE-D and STE-U | SWEA/STE-D | UC-B |  |
| 115 | 6 | **STE-D Interface Board** | 419d | 2002-04-29 A | 2003-12-29 |  | 64% | 150.42d | 2002-04-29 | 2003-11-05 | 384d | 51d |  |  | STEREO | IMPACT | Boom Suite | SSI | SWEA/STE-D and STE-U | SWEA/STE-D | UC-B |  |
| 116 | 6.1 | **Design, Manufacture, Assembly and Test** | 419d | 2002-04-29 A | 2003-12-29 |  | 64% | 150.42d | 2002-04-29 | 2003-11-05 | 384d | 51d |  |  | STEREO | IMPACT | Boom Suite | SSI | SWEA/STE-D and STE-U | SWEA/STE-D | UC-B |  |
| 117 | 6.1.1 | **Procurements** | 9d | 2003-01-29 A | 2003-02-10 A |  | 100% |  | 2003-01-29 | 2003-02-10 | 9d |  |  |  | STEREO | IMPACT | Boom Suite | SSI | SWEA/STE-D and STE-U |  |  |  |
| 118 | 6.1.1.1 | Procure DAC Options | 1d | 2003-01-29 A | 2003-01-29 A |  | 100% |  | 2003-01-29 | 2003-01-29 | 1d |  |  |  | STEREO | IMPACT | Boom Suite | SSI | SWEA/STE-D and STE-U |  |  |  |
| 119 | 6.1.1.2 | Procure and Screen Flight DACs | 1d | 2003-02-10 A | 2003-02-10 A | 144FS+1d | 100% |  | 2003-02-10 | 2003-02-10 | 1d |  |  |  | STEREO | IMPACT | Boom Suite | SSI | SWEA/STE-D and STE-U |  |  |  |
| 120 | 6.1.2 | **Design** | 220d | 2002-04-29 A | 2003-03-14 A |  | 100% |  | 2002-04-29 | 2003-03-14 | 220d |  |  |  | STEREO | IMPACT | Boom Suite | SSI | SWEA/STE-D and STE-U | SWEA/STE-D | UC-B |  |
| 121 | 6.1.2.1 | Layout SWEA / STE-D ETU Digital to Analog Converter Printed Wiring Board | 14.85d | 2002-04-29 A | 2002-08-05 A | 96 | 100% |  | 2002-04-29 | 2002-08-05 | 14.85d |  |  |  | STEREO | IMPACT | Boom Suite | SSI | SWEA/STE-D and STE-U | SWEA/STE-D | UC-B |  |
| 122 | 6.1.2.2 | Develop Skematic for SWEA / STE-D ETU Digital to Analog Converter Printed Wiring Board | 5d | 2003-02-03 A | 2003-02-07 A | 118FS+2d | 100% |  | 2003-02-03 | 2003-02-07 | 5d |  |  |  | STEREO | IMPACT | Boom Suite | SSI | SWEA/STE-D and STE-U |  |  |  |
| 123 | 6.1.2.3 | Start Layout SWEA / STE-D ETU Digital to Analog Converter Printed Wiring Board without DAC | 15d | 2003-02-10 A | 2003-03-10 A | 122 | 100% |  | 2003-02-10 | 2003-03-10 | 15d |  |  |  | STEREO | IMPACT | Boom Suite | SSI | SWEA/STE-D and STE-U |  |  |  |
| 124 | 6.1.2.4 | Complete Layout SWEA / STE-D ETU Digital to Analog Converter Printed Wiring Board For Selected DAC | 4d | 2003-03-11 A | 2003-03-14 A | 144, 123 | 100% |  | 2003-03-11 | 2003-03-14 | 4d |  |  |  | STEREO | IMPACT | Boom Suite | SSI | SWEA/STE-D and STE-U |  |  |  |
| 125 | 6.1.3 | **Fabrication** | 331d | 2002-08-05 A | 2003-11-28 |  | 44% | 183.89d | 2002-08-05 | 2003-10-08 | 296d | 29d |  |  | STEREO | IMPACT | Boom Suite | SSI | SWEA/STE-D and STE-U | SWEA/STE-D | UC-B |  |
| 126 | 6.1.3.1 | **ETU** | 168d | 2002-08-05 A | 2003-04-07 A |  | 100% |  | 2002-08-05 | 2003-04-07 | 168d |  |  |  | STEREO | IMPACT | Boom Suite | SSI | SWEA/STE-D and STE-U | SWEA/STE-D | UC-B |  |
| 127 | 6.1.3.1.1 | Fabricate SWEA / STE-D ETU Digital to Analog Converter Printed Wiring Board | 11d | 2002-08-05 A | 2002-08-19 A | 121 | 100% |  | 2002-08-05 | 2002-08-19 | 11d |  |  | start no earlier than 2002-07-31 | STEREO | IMPACT | Boom Suite | SSI | SWEA/STE-D and STE-U | SWEA/STE-D | UC-B |  |
| 128 | 6.1.3.1.2 | Fabricate SWEA / STE-D ETU Digital to Analog Converter Printed Wiring Board (New DAC) | 5d | 2003-04-01 A | 2003-04-07 A | 124 | 100% |  | 2003-04-01 | 2003-04-07 | 5d |  |  | start no earlier than 2003-03-31 | STEREO | IMPACT | Boom Suite | SSI | SWEA/STE-D and STE-U |  |  |  |

| ID | WBS | Task | Duration | Start | Finish | Predecessors | Complete | Remaining | Baseline start | Baseline finish | Baseline duration | Total slack | Free slack | Constraint | Text11 | Text12 | Text13 | Text14 | Text16 | Text17 | Text28 |
| --- | --- | --- | --- | --- | --- | --- | --- | --- | --- | --- | --- | --- | --- | --- | --- | --- | --- | --- | --- | --- | --- |
| 129 | 6.1.3.2 | **FM 1 & FM 2** | 10d | 2003-11-14 | 2003-11-28 |  |  |  | 2003-09-24 | 2003-10-08 | 10d | 29d |  |  | STEREO | IMPACT | Boom Suite | SSI | SWEA/STE-D and STE-U | SWEA/STE-D | UC-B |
| 130 | 6.1.3.2.1 | **FM 1** | 10d | 2003-11-14 | 2003-11-28 |  |  |  | 2003-09-24 | 2003-10-08 | 10d | 29d |  |  | STEREO | IMPACT | Boom Suite | SSI | SWEA/STE-D and STE-U | SWEA/STE-D | UC-B |
| 131 | 6.1.3.2.1.1 | Fabricate SWEA / STE-D FM 1 Digital to Analog Converter Printed Wiring Board | 10d | 2003-11-14 | 2003-11-28 | 79, 197 |  |  | 2003-09-24 | 2003-10-08 | 10d | 29d | 0d | start no earlier than 2003-11-14 | STEREO | IMPACT | Boom Suite | SSI | SWEA/STE-D and STE-U | SWEA/STE-D | UC-B |
| 132 | 6.1.3.2.2 | **FM 2** | 10d | 2003-11-14 | 2003-11-28 |  |  |  | 2003-09-24 | 2003-10-08 | 10d | 29d |  |  | STEREO | IMPACT | Boom Suite | SSI | SWEA/STE-D and STE-U | SWEA/STE-D | UC-B |
| 133 | 6.1.3.2.2.1 | Fabricate SWEA / STE-D FM 2 Digital to Analog Converter Printed Wiring Board | 10d | 2003-11-14 | 2003-11-28 | 79, 197 |  |  | 2003-09-24 | 2003-10-08 | 10d | 29d | 0d | start no earlier than 2003-11-14 | STEREO | IMPACT | Boom Suite | SSI | SWEA/STE-D and STE-U | SWEA/STE-D | UC-B |
| 134 | 6.1.4 | **Assembly** | 331d | 2002-09-03 A | 2003-12-29 |  | 51% | 161.46d | 2002-09-03 | 2003-11-05 | 296d | 51d |  |  | STEREO | IMPACT | Boom Suite | SSI | SWEA/STE-D and STE-U | SWEA/STE-D | UC-B |
| 135 | 6.1.4.1 | **ETU** | 153d | 2002-09-03 A | 2003-04-14 A |  | 100% |  | 2002-09-03 | 2003-04-14 | 153d |  |  |  | STEREO | IMPACT | Boom Suite | SSI | SWEA/STE-D and STE-U | SWEA/STE-D | UC-B |
| 136 | 6.1.4.1.1 | Load SWEA / STE-D ETU Digital to Analog Converter Printed Wiring Board | 5.5d | 2002-09-03 A | 2002-10-01 A | 127 | 100% |  | 2002-09-03 | 2002-10-01 | 5.5d |  |  | start no earlier than 2002-08-31 | STEREO | IMPACT | Boom Suite | SSI | SWEA/STE-D and STE-U | SWEA/STE-D | UC-B |
| 137 | 6.1.4.1.2 | Load SWEA/STE-D ETU Digital to Analog Coverter Printed Wiring Board (New DAC) | 5d | 2003-04-08 A | 2003-04-14 A | 128 | 100% |  | 2003-04-08 | 2003-04-14 | 5d |  |  | start no earlier than 2003-03-31 | STEREO | IMPACT | Boom Suite | SSI | SWEA/STE-D and STE-U |  |  |
| 138 | 6.1.4.2 | **FM 1** | 5d | 2003-12-22 | 2003-12-29 |  |  |  | 2003-10-30 | 2003-11-05 | 5d | 29d |  |  | STEREO | IMPACT | Boom Suite | SSI | SWEA/STE-D and STE-U | SWEA/STE-D | UC-B |
| 139 | 6.1.4.2.1 | Load SWEA / STE-D FM 1 Digital to Analog Converter Printed Wiring Board | 5d | 2003-12-22 | 2003-12-29 | 147, 119FS+145d |  |  | 2003-10-30 | 2003-11-05 | 5d | 29d | 0d |  | STEREO | IMPACT | Boom Suite | SSI | SWEA/STE-D and STE-U | SWEA/STE-D | UC-B |
| 140 | 6.1.4.3 | **FM 2** | 5d | 2003-12-22 | 2003-12-29 |  |  |  | 2003-10-30 | 2003-11-05 | 5d | 51d |  |  | STEREO | IMPACT | Boom Suite | SSI | SWEA/STE-D and STE-U | SWEA/STE-D | UC-B |
| 141 | 6.1.4.3.1 | Load SWEA / STE-D FM 2 Digital to Analog Converter Printed Wiring Board | 5d | 2003-12-22 | 2003-12-29 | 147, 119FS+149d |  |  | 2003-10-30 | 2003-11-05 | 5d | 51d | 0d |  | STEREO | IMPACT | Boom Suite | SSI | SWEA/STE-D and STE-U | SWEA/STE-D | UC-B |
| 142 | 6.1.5 | **Test** | 222d | 2003-02-04 A | 2003-12-19 |  | 46% | 118.93d | 2003-02-04 | 2003-10-29 | 187d | 29d |  |  | STEREO | IMPACT | Boom Suite | SSI | SWEA/STE-D and STE-U | SWEA/STE-D | UC-B |
| 143 | 6.1.5.1 | **ETU** | 66d | 2003-02-04 A | 2003-05-07 A |  | 100% |  | 2003-02-04 | 2003-05-07 | 66d |  |  |  | STEREO | IMPACT | Boom Suite | SSI | SWEA/STE-D and STE-U |  |  |
| 144 | 6.1.5.1.1 | Rad Test DAC Options and Select Option | 3d | 2003-02-04 A | 2003-02-06 A | 118FS+3d | 100% |  | 2003-02-04 | 2003-02-06 | 3d |  |  | finish no earlier than 2003-02-03 | STEREO | IMPACT | Boom Suite | SSI | SWEA/STE-D and STE-U |  |  |
| 145 | 6.1.5.1.2 | Test SWEA / STE-DETU Digital to Analog Converter Printed Wiring Board | 10d | 2003-04-15 A | 2003-05-07 A | 137 | 100% |  | 2003-04-15 | 2003-05-07 | 10d |  |  | start no earlier than 2003-03-31 | STEREO | IMPACT | Boom Suite | SSI | SWEA/STE-D and STE-U |  |  |
| 146 | 6.1.5.2 | **FM 1 & FM 2** | 15d | 2003-12-01 | 2003-12-19 |  |  |  | 2003-10-09 | 2003-10-29 | 15d | 29d |  |  | STEREO | IMPACT | Boom Suite | SSI | SWEA/STE-D and STE-U | SWEA/STE-D | UC-B |
| 147 | 6.1.5.2.1 | Coupon Test STE-U FM 1 & FM 2 Shaper & Interface Printed Wiring Board | 15d | 2003-12-01 | 2003-12-19 | 131, 133 |  |  | 2003-10-09 | 2003-10-29 | 15d | 29d | 0d |  | STEREO | IMPACT | Boom Suite | SSI | SWEA/STE-D and STE-U | SWEA/STE-D | UC-B |
| 148 | 7 | **STE-U Pre-Amp Board** | 318d | 2002-09-03 A | 2003-12-09 |  | 83% | 55.21d | 2002-09-03 | 2003-10-22 | 286d | 65d |  |  | STEREO | IMPACT | Boom Suite | SSI | SWEA/STE-D and STE-U | STE-U | UC-B |
| 149 | 7.1 | **Design, Manufacture, Assembly and Test** | 318d | 2002-09-03 A | 2003-12-09 |  | 83% | 55.21d | 2002-09-03 | 2003-10-22 | 286d | 65d |  |  | STEREO | IMPACT | Boom Suite | SSI | SWEA/STE-D and STE-U | STE-U | UC-B |
| 150 | 7.1.1 | **Design** | 36d | 2002-09-03 A | 2002-10-23 A |  | 100% |  | 2002-09-03 | 2002-10-23 | 36d |  |  |  | STEREO | IMPACT | Boom Suite | SSI | SWEA/STE-D and STE-U | STE-U | UC-B |
| 151 | 7.1.1.1 | Layout STE-U Preamp Printed Wiring Board | 36d | 2002-09-03 A | 2002-10-23 A | 121 | 100% |  | 2002-09-03 | 2002-10-23 | 36d |  |  | start no earlier than 2002-08-31 | STEREO | IMPACT | Boom Suite | SSI | SWEA/STE-D and STE-U | STE-U | UC-B |
| 152 | 7.1.2 | **Fabrication** | 112d | 2003-06-02 A | 2003-11-07 A |  | 100% |  | 2003-06-02 | 2003-09-23 | 80d |  |  |  | STEREO | IMPACT | Boom Suite | SSI | SWEA/STE-D and STE-U | STE-U | UC-B |
| 153 | 7.1.2.1 | **ETU** | 10d | 2003-06-02 A | 2003-06-13 A |  | 100% |  | 2003-06-02 | 2003-06-13 | 10d |  |  |  | STEREO | IMPACT | Boom Suite | SSI | SWEA/STE-D and STE-U | STE-U | UC-B |
| 154 | 7.1.2.1.1 | (OBSOLETE) Fabricate STE-U ETU Preamp Printed Wiring Board | 10d | 2003-06-02 A | 2003-06-13 A | 151 | 100% |  | 2003-06-02 | 2003-06-13 | 10d |  |  | start no earlier than 2003-05-31 | STEREO | IMPACT | Boom Suite | SSI | SWEA/STE-D and STE-U | STE-U | UC-B |

Notes:
- 154: Same as for STE-D only need one board for ETU purposes. The flight boards will need to be built

| ID | WBS | Task | Duration | Start | Finish | Predecessors | Complete | Remaining | Baseline start | Baseline finish | Baseline duration | Total slack | Free slack | Constraint | Text11 | Text12 | Text13 | Text14 | Text16 | Text17 | Text28 |
| --- | --- | --- | --- | --- | --- | --- | --- | --- | --- | --- | --- | --- | --- | --- | --- | --- | --- | --- | --- | --- | --- |
| 155 | 7.1.2.2 | **FM 1 & FM 2** | 34d | 2003-09-22 A | 2003-11-07 A |  | 100% |  | 2003-09-10 | 2003-09-23 | 10d |  |  |  | STEREO | IMPACT | Boom Suite | SSI | SWEA/STE-D and STE-U | STE-U | UC-B |
| 156 | 7.1.2.2.1 | **FM 1** | 34d | 2003-09-22 A | 2003-11-07 A |  | 100% |  | 2003-09-10 | 2003-09-23 | 10d |  |  |  | STEREO | IMPACT | Boom Suite | SSI | SWEA/STE-D and STE-U | STE-U | UC-B |
| 157 | 7.1.2.2.1.1 | Fabricate STE-U FM 1 Preamp Printed Wiring Board | 34d | 2003-09-22 A | 2003-11-07 A | 79, 197 | 100% |  | 2003-09-10 | 2003-09-23 | 10d |  |  | start no earlier than 2003-09-22 | STEREO | IMPACT | Boom Suite | SSI | SWEA/STE-D and STE-U | STE-U | UC-B |
| 158 | 7.1.2.2.2 | **FM 2** | 34d | 2003-09-22 A | 2003-11-07 A |  | 100% |  | 2003-09-10 | 2003-09-23 | 10d |  |  |  | STEREO | IMPACT | Boom Suite | SSI | SWEA/STE-D and STE-U | STE-U | UC-B |
| 159 | 7.1.2.2.2.1 | Fabricate STE-U FM 2 Preamp Printed Wiring Board | 34d | 2003-09-22 A | 2003-11-07 A | 79, 197 | 100% |  | 2003-09-10 | 2003-09-23 | 10d |  |  | start no earlier than 2003-09-22 | STEREO | IMPACT | Boom Suite | SSI | SWEA/STE-D and STE-U | STE-U | UC-B |
| 160 | 7.1.3 | **Assembly** | 122d | 2003-06-16 A | 2003-12-09 |  | 33% | 81.33d | 2003-06-16 | 2003-10-22 | 90d | 65d |  |  | STEREO | IMPACT | Boom Suite | SSI | SWEA/STE-D and STE-U | STE-U | UC-B |
| 161 | 7.1.3.1 | **ETU** | 5d | 2003-06-16 A | 2003-06-20 A |  | 100% |  | 2003-06-16 | 2003-06-20 | 5d |  |  |  | STEREO | IMPACT | Boom Suite | SSI | SWEA/STE-D and STE-U | STE-U | UC-B |
| 162 | 7.1.3.1.1 | (OBSOLETE) Load STE-U ETU Preamp Printed Wiring Board | 5d | 2003-06-16 A | 2003-06-20 A | 154 | 100% |  | 2003-06-16 | 2003-06-20 | 5d |  |  | start no earlier than 2003-05-31 | STEREO | IMPACT | Boom Suite | SSI | SWEA/STE-D and STE-U | STE-U | UC-B |
| 163 | 7.1.3.2 | **FM 1** | 5d | 2003-12-03 | 2003-12-09 |  |  |  | 2003-10-16 | 2003-10-22 | 5d | 56d |  |  | STEREO | IMPACT | Boom Suite | SSI | SWEA/STE-D and STE-U | STE-U | UC-B |
| 164 | 7.1.3.2.1 | Load STE-U FM 1 Preamp Printed Wiring Board | 5d | 2003-12-03 | 2003-12-09 | 169 |  |  | 2003-10-16 | 2003-10-22 | 5d | 56d | 12d |  | STEREO | IMPACT | Boom Suite | SSI | SWEA/STE-D and STE-U | STE-U | UC-B |
| 165 | 7.1.3.3 | **FM 2** | 5d | 2003-12-03 | 2003-12-09 |  |  |  | 2003-10-16 | 2003-10-22 | 5d | 65d |  |  | STEREO | IMPACT | Boom Suite | SSI | SWEA/STE-D and STE-U | STE-U | UC-B |
| 166 | 7.1.3.3.1 | Load STE-U FM 2 Preamp Printed Wiring Board | 5d | 2003-12-03 | 2003-12-09 | 169 |  |  | 2003-10-16 | 2003-10-22 | 5d | 65d | 12d |  | STEREO | IMPACT | Boom Suite | SSI | SWEA/STE-D and STE-U | STE-U | UC-B |
| 167 | 7.1.4 | **Test** | 15d | 2003-11-11 | 2003-12-02 |  |  |  | 2003-09-24 | 2003-10-15 | 15d | 56d |  |  | STEREO | IMPACT | Boom Suite | SSI | SWEA/STE-D and STE-U | STE-U | UC-B |
| 168 | 7.1.4.1 | **FM 1 & FM 2** | 15d | 2003-11-11 | 2003-12-02 |  |  |  | 2003-09-24 | 2003-10-15 | 15d | 56d |  |  | STEREO | IMPACT | Boom Suite | SSI | SWEA/STE-D and STE-U | STE-U | UC-B |
| 169 | 7.1.4.1.1 | Coupon Test STE-U FM 1 & FM 2 Shaper & Interface Printed Wiring Board | 15d | 2003-11-11 | 2003-12-02 | 157, 159 |  |  | 2003-09-24 | 2003-10-15 | 15d | 56d | 0d |  | STEREO | IMPACT | Boom Suite | SSI | SWEA/STE-D and STE-U | STE-U | UC-B |
| 170 | 8 | **STE-U Shaper & Interface Board** | 288d | 2002-11-01 A | 2003-12-26 |  | 40% | 172d | 2002-11-01 | 2003-11-12 | 258d | 53d |  |  | STEREO | IMPACT | Boom Suite | SSI | SWEA/STE-D and STE-U | STE-U | UC-B |
| 171 | 8.1 | **Design, Manufacture, Assembly and Test** | 288d | 2002-11-01 A | 2003-12-26 |  | 40% | 172d | 2002-11-01 | 2003-11-12 | 258d | 53d |  |  | STEREO | IMPACT | Boom Suite | SSI | SWEA/STE-D and STE-U | STE-U | UC-B |
| 172 | 8.1.1 | **Design** | 15d | 2002-11-01 A | 2002-11-22 A |  | 100% |  | 2002-11-01 | 2002-11-22 | 15d |  |  |  | STEREO | IMPACT | Boom Suite | SSI | SWEA/STE-D and STE-U | STE-U | UC-B |
| 173 | 8.1.1.1 | Layout STE-U ETU Shaper & Interface Printed Wiring Board | 15d | 2002-11-01 A | 2002-11-22 A | 121 | 100% |  | 2002-11-01 | 2002-11-22 | 15d |  |  | start no earlier than 2002-10-31 | STEREO | IMPACT | Boom Suite | SSI | SWEA/STE-D and STE-U | STE-U | UC-B |
| 174 | 8.1.2 | **Fabrication** | 125d | 2003-06-02 A | 2003-11-28 |  | 33% | 83.33d | 2003-06-02 | 2003-10-15 | 95d | 44d |  |  | STEREO | IMPACT | Boom Suite | SSI | SWEA/STE-D and STE-U | STE-U | UC-B |
| 175 | 8.1.2.1 | **ETU** | 10d | 2003-06-02 A | 2003-06-13 A |  | 100% |  | 2003-06-02 | 2003-06-13 | 10d |  |  |  | STEREO | IMPACT | Boom Suite | SSI | SWEA/STE-D and STE-U | STE-U | UC-B |
| 176 | 8.1.2.1.1 | Fabricate STE-U ETU Shaper & Interface Printed Wiring Board | 10d | 2003-06-02 A | 2003-06-13 A | 173 | 100% |  | 2003-06-02 | 2003-06-13 | 10d |  |  | start no earlier than 2003-05-31 | STEREO | IMPACT | Boom Suite | SSI | SWEA/STE-D and STE-U | STE-U | UC-B |
| 177 | 8.1.2.2 | **FM 1 & FM 2** | 10d | 2003-11-14 | 2003-11-28 |  |  |  | 2003-10-01 | 2003-10-15 | 10d | 44d |  |  | STEREO | IMPACT | Boom Suite | SSI | SWEA/STE-D and STE-U | STE-U | UC-B |
| 178 | 8.1.2.2.1 | **FM 1** | 10d | 2003-11-14 | 2003-11-28 |  |  |  | 2003-10-01 | 2003-10-15 | 10d | 44d |  |  | STEREO | IMPACT | Boom Suite | SSI | SWEA/STE-D and STE-U | STE-U | UC-B |
| 179 | 8.1.2.2.1.1 | Fabricate STE-U FM 1Shaper & Interface Printed Wiring Board | 10d | 2003-11-14 | 2003-11-28 | 79, 197 |  |  | 2003-10-01 | 2003-10-15 | 10d | 44d | 0d | start no earlier than 2003-11-14 | STEREO | IMPACT | Boom Suite | SSI | SWEA/STE-D and STE-U | STE-U | UC-B |

Notes:
- 162: Same as for STE-D only need one board for ETU purposes. The flight boards will need to be built

| ID | WBS | Task | Type | Duration | Start | Finish | Predecessors | Complete | Remaining | Baseline start | Baseline finish | Baseline duration | Total slack | Free slack | Constraint | Text11 | Text12 | Text13 | Text14 | Text16 | Text17 | Text28 | Text21 |
| --- | --- | --- | --- | --- | --- | --- | --- | --- | --- | --- | --- | --- | --- | --- | --- | --- | --- | --- | --- | --- | --- | --- | --- |
| 180 | 8.1.2.2.2 | **FM 2** |  | 10d | 2003-11-14 | 2003-11-28 |  |  |  | 2003-10-01 | 2003-10-15 | 10d | 44d |  |  | STEREO | IMPACT | Boom Suite | SSI | SWEA/STE-D and STE-U | STE-U | UC-B |  |
| 181 | 8.1.2.2.2.1 | Fabricate STE-U FM 2 Shaper & Interface Printed Wiring Board |  | 10d | 2003-11-14 | 2003-11-28 | 79, 197 |  |  | 2003-10-01 | 2003-10-15 | 10d | 44d | 0d | start no earlier than 2003-11-14 | STEREO | IMPACT | Boom Suite | SSI | SWEA/STE-D and STE-U | STE-U | UC-B |  |
| 182 | 8.1.3 | **Assembly** |  | 134d | 2003-06-16 A | 2003-12-26 |  | 33% | 89.33d | 2003-06-16 | 2003-11-12 | 104d | 53d |  |  | STEREO | IMPACT | Boom Suite | SSI | SWEA/STE-D and STE-U | STE-U | UC-B |  |
| 183 | 8.1.3.1 | **ETU** |  | 4d | 2003-06-16 A | 2003-06-19 A |  | 100% |  | 2003-06-16 | 2003-06-19 | 4d |  |  |  | STEREO | IMPACT | Boom Suite | SSI | SWEA/STE-D and STE-U | STE-U | UC-B |  |
| 184 | 8.1.3.1.1 | Load STE-U ETU Shaper & Interface Printed Wiring Board |  | 4d | 2003-06-16 A | 2003-06-19 A | 176 | 100% |  | 2003-06-16 | 2003-06-19 | 4d |  |  | start no earlier than 2003-05-31 | STEREO | IMPACT | Boom Suite | SSI | SWEA/STE-D and STE-U | STE-U | UC-B |  |
| 185 | 8.1.3.2 | **FM 1** |  | 4d | 2003-12-22 | 2003-12-26 |  |  |  | 2003-11-06 | 2003-11-12 | 4d | 44d |  |  | STEREO | IMPACT | Boom Suite | SSI | SWEA/STE-D and STE-U | STE-U | UC-B |  |
| 186 | 8.1.3.2.1 | Load STE-U FM 1 Shaper & Interface Printed Wiring Board |  | 4d | 2003-12-22 | 2003-12-26 | 191 |  |  | 2003-11-06 | 2003-11-12 | 4d | 44d | 0d |  | STEREO | IMPACT | Boom Suite | SSI | SWEA/STE-D and STE-U | STE-U | UC-B |  |
| 187 | 8.1.3.3 | **FM 2** |  | 4d | 2003-12-22 | 2003-12-26 |  |  |  | 2003-11-06 | 2003-11-12 | 4d | 53d |  |  | STEREO | IMPACT | Boom Suite | SSI | SWEA/STE-D and STE-U | STE-U | UC-B |  |
| 188 | 8.1.3.3.1 | Load STE-U FM 2 Shaper & Interface Printed Wiring Board |  | 4d | 2003-12-22 | 2003-12-26 | 191 |  |  | 2003-11-06 | 2003-11-12 | 4d | 53d | 0d |  | STEREO | IMPACT | Boom Suite | SSI | SWEA/STE-D and STE-U | STE-U | UC-B |  |
| 189 | 8.1.4 | **Test** |  | 15d | 2003-12-01 | 2003-12-19 |  |  |  | 2003-10-16 | 2003-11-05 | 15d | 44d |  |  | STEREO | IMPACT | Boom Suite | SSI | SWEA/STE-D and STE-U | STE-U | UC-B |  |
| 190 | 8.1.4.1 | **FM 1 & FM 2** |  | 15d | 2003-12-01 | 2003-12-19 |  |  |  | 2003-10-16 | 2003-11-05 | 15d | 44d |  |  | STEREO | IMPACT | Boom Suite | SSI | SWEA/STE-D and STE-U | STE-U | UC-B |  |
| 191 | 8.1.4.1.1 | Coupon Test STE-U FM 1 & FM 2 Shaper & Interface Printed Wiring Board |  | 15d | 2003-12-01 | 2003-12-19 | 181, 179 |  |  | 2003-10-16 | 2003-11-05 | 15d | 44d | 0d |  | STEREO | IMPACT | Boom Suite | SSI | SWEA/STE-D and STE-U | STE-U | UC-B |  |
| 192 | 9 | **Integration & Test** |  | 266d | 2003-06-02 A | 2004-06-21 |  | 31% | 184.69d | 2003-06-02 | 2004-05-07 | 236d | 0d |  |  | STEREO | IMPACT | Boom Suite | SSI | SWEA/STE-D and STE-U | SWEA/STE-D | UC-B |  |
| 193 | 9.1 | **ETU** |  | 64d | 2003-06-02 A | 2003-08-29 A |  | 100% |  | 2003-06-02 | 2003-08-29 | 64d |  |  |  | STEREO | IMPACT | Boom Suite | SSI | SWEA/STE-D and STE-U | SWEA/STE-D | UC-B |  |
| 194 | 9.1.1 | Integrate & Test SWEA / STE-D ETU Interface Boards |  | 20d | 2003-06-02 A | 2003-06-27 A | 85, 107, 136, 72, 22, 24, 145 | 100% |  | 2003-06-02 | 2003-06-27 | 20d |  |  | start no earlier than 2003-05-31 | STEREO | IMPACT | Boom Suite | SSI | SWEA/STE-D and STE-U | SWEA/STE-D | UC-B |  |
| 195 | 9.1.2 | Integrate & Test SWEA / STE-D ETU Interface W/ SWEA / STE-D LVPS ETU |  | 3d | 2003-06-30 A | 2003-07-02 A | 194, 16 | 100% |  | 2003-06-30 | 2003-07-02 | 3d |  |  |  | STEREO | IMPACT | Boom Suite | SSI | SWEA/STE-D and STE-U | SWEA/STE-D | UC-B |  |
| 196 | 9.1.3 | Integrate & Test SWEA / STE-D ETU Combined |  | 10d | 2003-07-03 A | 2003-07-17 A | 195, 10, 26 | 100% |  | 2003-07-03 | 2003-07-17 | 10d |  |  |  | STEREO | IMPACT | Boom Suite | SSI | SWEA/STE-D and STE-U | SWEA/STE-D | UC-B |  |
| 197 | 9.1.4 | Calibrate SWEA ETU |  | 31d | 2003-07-18 A | 2003-08-29 A | 196 | 100% |  | 2003-07-18 | 2003-08-29 | 31d |  |  |  | STEREO | IMPACT | Boom Suite | SSI | SWEA/STE-D and STE-U | SWEA | UC-B |  |
| 198 | 9.1.5 | (OBSOLETE) Integrate & Test STE-U ETU Interface |  | 6d | 2003-06-23 A | 2003-06-30 A | 184, 162, 22, 24 | 100% |  | 2003-06-23 | 2003-06-30 | 6d |  |  | start no earlier than 2003-05-31 | STEREO | IMPACT | Boom Suite | SSI | SWEA/STE-D and STE-U | STE-U | UC-B |  |
| 199 | 9.2 | **FM 1** |  | 121d | 2003-12-29 | 2004-06-18 |  |  |  | 2003-11-06 | 2004-03-11 | 85d | 1d |  |  | STEREO | IMPACT | Boom Suite | SSI | SWEA/STE-D and STE-U | SWEA/STE-D | UC-B |  |
| 200 | 9.2.1 | Integrate & Test STE-U FM 1 Interface Boards |  | 5d | 2003-12-29 | 2004-01-05 | 164, 186, 22, 24 |  |  | 2003-11-13 | 2003-11-19 | 5d | 44d | 0d |  | STEREO | IMPACT | Boom Suite | SSI | SWEA/STE-D and STE-U | STE-U | UC-B |  |
| 201 | 9.2.2 | Integrate & Test SWEA / STE-D FM 1 Interface Boards |  | 20d | 2003-12-30 | 2004-01-28 | 87, 109, 139, 63 |  |  | 2003-11-06 | 2003-12-05 | 20d | 29d | 0d |  | STEREO | IMPACT | Boom Suite | SSI | SWEA/STE-D and STE-U | SWEA/STE-D | UC-B |  |
| 202 | 9.2.3 | Integrate & Test SWEA / STE-D FM 1 Interface with SWEA / STE-D FM 1 LVPS |  | 10d | 2004-02-13 | 2004-02-27 | 201, 18 |  |  | 2003-12-31 | 2004-01-15 | 10d | 18d | 0d |  | STEREO | IMPACT | Boom Suite | SSI | SWEA/STE-D and STE-U | SWEA/STE-D | UC-B |  |
| 203 | 9.2.4 | Clean/Coat/Stake SWEA / STE-D Interface |  | 10d | 2004-01-29 | 2004-02-11 | 201 |  |  | 2003-12-08 | 2003-12-19 | 10d | 29d | 11d |  | STEREO | IMPACT | Boom Suite | SSI | SWEA/STE-D and STE-U | SWEA/STE-D | UC-B | FM 1 Complt. |
| 204 | 9.2.5 | Integrate & Test SWEA / STE-D FM 1 Combined |  | 5d | 2004-03-01 | 2004-03-05 | 12SS, 28, 202, 203 |  |  | 2004-01-16 | 2004-01-22 | 5d | 18d | 0d |  | STEREO | IMPACT | Boom Suite | SSI | SWEA/STE-D and STE-U | SWEA/STE-D | UC-B |  |
| 205 | 9.2.6 | Calibrate SWEA FM 1 |  | 20d | 2004-03-08 | 2004-04-02 | 204 |  |  | 2004-01-23 | 2004-02-20 | 20d | 18d | 0d |  | STEREO | IMPACT | Boom Suite | SSI | SWEA/STE-D and STE-U | SWEA | UC-B |  |
| 206 | 1.1.37 | IMPACT Suite FM 1 EMC Testing Complete | milestone | 0d | 2004-05-28 | 2004-05-28 |  |  |  |  |  |  | 0d |  |  | STEREO | IMPACT | Boom Suite | SSI | SWEA/STE-D and STE-U |  |  |  |
| 207 | 9.2.8 | SWEA/STE-D FM 1 Thermal Vac/Thermal Balance |  | 14d | 2004-06-01 | 2004-06-18 | 206 |  |  | 2004-02-23 | 2004-03-11 | 14d | 1d |  |  | STEREO | IMPACT | Boom Suite | SSI | SWEA/STE-D and STE-U |  |  |  |
| 208 | 2.1.4 | BOOM Suite FM 1 Bakeout |  | 5d | 2004-06-30 | 2004-07-07 | 207 |  |  |  |  |  | 18d | 0d |  | STEREO | IMPACT | Boom Suite | SSI | SWEA/STE-D and STE-U |  |  |  |

Notes:
- 198: Reduced Duration 1 day thru 7/31 statusing to get CDR off the Critical Path / Same as for STE-D only need one board for ETU purposes. The flight boards will need to be built

| ID | WBS | Task | Duration | Start | Finish | Predecessors | Baseline start | Baseline finish | Baseline duration | Total slack | Free slack | Text11 | Text12 | Text13 | Text14 | Text16 | Text17 | Text28 |
| --- | --- | --- | --- | --- | --- | --- | --- | --- | --- | --- | --- | --- | --- | --- | --- | --- | --- | --- |
| 209 | 9.3 | **FM 2** | 122d | 2003-12-29 | 2004-06-21 |  | 2003-11-06 | 2004-05-07 | 126d | 0d |  | STEREO | IMPACT | Boom Suite | SSI | SWEA/STE-D and STE-U | SWEA/STE-D | UC-B |
| 210 | 9.3.1 | Integrate & Test STE-U FM 2 Interface Boards | 5d | 2003-12-29 | 2004-01-05 | 166, 188, 22, 24 | 2003-11-13 | 2003-11-19 | 5d | 53d | 0d | STEREO | IMPACT | Boom Suite | SSI | SWEA/STE-D and STE-U | STE-U | UC-B |
| 211 | 9.3.2 | Integrate & Test SWEA / STE-D FM 2 Interface Boards | 20d | 2003-12-30 | 2004-01-28 | 89, 111, 141, 65 | 2003-11-06 | 2003-12-05 | 20d | 51d |  | STEREO | IMPACT | Boom Suite | SSI | SWEA/STE-D and STE-U | SWEA/STE-D | UC-B |
| 212 | 9.3.3 | Integrate & Test SWEA / STE-D FM 2 Interface W/ STE-D LVPS ETU | 10d | 2004-04-12 | 2004-04-23 | 211, 20 | 2004-03-01 | 2004-03-12 | 10d | 0d |  | STEREO | IMPACT | Boom Suite | SSI | SWEA/STE-D and STE-U | SWEA/STE-D | UC-B |
| 213 | 9.3.4 | Integrate & Test SWEA / STE-D FM 2 Combined | 10d | 2004-04-26 | 2004-05-07 | 212, 14, 30 | 2004-03-15 | 2004-03-26 | 10d | 0d |  | STEREO | IMPACT | Boom Suite | SSI | SWEA/STE-D and STE-U | SWEA/STE-D | UC-B |
| 214 | 9.3.5 | Calibrate SWEA FM 2 | 20d | 2004-05-10 | 2004-06-07 | 213 | 2004-03-29 | 2004-04-23 | 20d | 0d |  | STEREO | IMPACT | Boom Suite | SSI | SWEA/STE-D and STE-U | SWEA | UC-B |
| 215 | 9.3.6 | SWEA/STE-D FM 2 Thermal Vac | 10d | 2004-06-08 | 2004-06-21 | 214 | 2004-04-26 | 2004-05-07 | 10d | 0d |  | STEREO | IMPACT | Boom Suite | SSI | SWEA/STE-D and STE-U |  |  |
