# STE - Suprathermal Electron Telescope

Schedule from MS Project, 2000-05-24 to 2004-04-05, status date 2003-10-31, A marks actual dates.
STE Development Schedule
NASA GSFC
Status Date: 10/31/2003 / Baseline Date: 01/31/2003 R1

## Calendars

- Standard w/ 10 Gov't Holidays: Mon-Fri 08:00-12:00, 13:00-17:00; Sat-Sun off. Exceptions (off unless hours are given): 2000-05-29, 2000-07-04, 2000-09-04, 2000-10-09, 2000-11-13, 2000-11-23, 2000-12-25, 2001-01-01, 2001-01-15, 2001-02-19, 2001-05-28, 2001-07-04, 2001-09-03, 2001-10-08, 2001-11-12, 2001-11-22, 2001-12-25, 2002-01-01, 2002-01-14, 2002-02-18, 2002-05-27, 2002-07-04, 2002-09-02, 2002-10-07, 2002-11-11, 2002-11-28, 2002-12-25, 2003-01-01, 2003-01-13, 2003-02-17, 2003-05-26, 2003-07-04, 2003-09-01, 2003-10-06, 2003-11-10, 2003-11-27, 2003-12-25, 2004-01-01, 2004-01-12, 2004-02-16.

## Schedule

| ID | WBS | Task | Type | Duration | Start | Finish | Predecessors | Complete | Remaining | Baseline start | Baseline finish | Baseline duration | Total slack | Free slack | Constraint | Text11 | Text12 | Text13 | Text14 | Text16 | Text17 | Text28 | Text20 | Text21 | Text22 | Text23 |
| --- | --- | --- | --- | --- | --- | --- | --- | --- | --- | --- | --- | --- | --- | --- | --- | --- | --- | --- | --- | --- | --- | --- | --- | --- | --- | --- |
| 1 | 1 | **Management** |  | 904d | 2000-08-18 A | 2004-03-29 |  | 99% | 0d | 2000-08-18 | 2004-04-08 | 912d | 0d |  |  | STEREO | IMPACT | Boom Suite | STE | SWEA/STE-D and STE-U | STE | UC-B |  |  |  |  |
| 2 | 1.1 | **Milestones** |  | 904d | 2000-08-18 A | 2004-03-29 |  | 99% | 0d | 2000-08-18 | 2004-04-08 | 912d | 0d |  |  | STEREO | IMPACT | Boom Suite | STE | SWEA/STE-D and STE-U | STE | UC-B |  |  |  |  |
| 3 | 1.1.1 | STE Box Design Contingency |  | 302d | 2000-08-18 A | 2001-10-31 A | 24 | 100% |  | 2000-08-18 | 2001-10-31 | 302d |  |  |  | STEREO | IMPACT | Boom Suite | STE | SWEA/STE-D and STE-U | STE | UC-B |  |  |  |  |
| 4 | 1.1.2 | STE ETU Detector Printed Wiring Board Layout Contingency |  | 134d | 2001-10-12 A | 2002-04-25 A | 67 | 100% |  | 2001-10-12 | 2002-04-25 | 134d |  |  |  | STEREO | IMPACT | Boom Suite | STE | SWEA/STE-D and STE-U | STE | UC-B |  |  |  |  |
| 5 | 1.1.3 | STE ETU Delivery Contingency | milestone | 0d | 2003-06-30 A | 2003-06-30 A | 78 | 100% |  | 2003-06-30 | 2003-06-30 | 0d |  |  | start no earlier than 2003-06-30 | STEREO | IMPACT | Boom Suite | STE | SWEA/STE-D and STE-U | STE | UC-B |  |  |  |  |
| 6 | 1.1.4 | STE-U FM 1 Delivery Contingency | milestone | 0d | 2004-03-29 | 2004-03-29 | 83 |  |  | 2004-02-12 | 2004-02-12 | 0d | 0d |  |  | STEREO | IMPACT | Boom Suite | STE | SWEA/STE-D and STE-U | STE | UC-B |  |  |  |  |
| 7 | 1.1.5 | STE-U FM 2 Delivery Contingency | milestone | 0d | 2004-03-23 | 2004-03-23 | 88 |  |  | 2004-02-12 | 2004-04-08 | 40d | 4d | 0d |  | STEREO | IMPACT | Boom Suite | STE | SWEA/STE-D and STE-U | STE | UC-B |  |  |  |  |
| 8 | 1.1.6 | STE-D FM 1 Delivery Contingency | milestone | 0d | 2004-02-10 | 2004-02-10 | 81 |  |  | 2004-01-13 | 2004-01-13 | 0d | 30d | 0d |  | STEREO | IMPACT | Boom Suite | STE | SWEA/STE-D and STE-U | STE | UC-B |  |  |  |  |
| 9 | 1.1.7 | STE-D FM 2 Delivery Contingency | milestone | 0d | 2004-02-20 | 2004-02-20 | 86 |  |  | 2004-01-22 | 2004-01-22 | 0d | 26d | 0d |  | STEREO | IMPACT | Boom Suite | STE | SWEA/STE-D and STE-U | STE | UC-B |  |  |  |  |
| 10 | 1.1.8 | **Deliverables** |  | 186d | 2003-06-30 A | 2004-03-29 |  |  | 186d | 2003-06-30 | 2004-04-08 | 194d | 0d |  |  | STEREO | IMPACT | Boom Suite | STE | SWEA/STE-D and STE-U | STE | UC-B |  |  |  |  |
| 11 | 1.1.8.1 | Deliver STE-U/D ETU For Interface Testing | milestone | 0d | 2003-06-30 A | 2003-06-30 A | 5 | 100% |  | 2003-06-30 | 2003-06-30 | 0d |  |  | start no earlier than 2003-06-30 | STEREO | IMPACT | Boom Suite | STE | SWEA/STE-D and STE-U | STE | UC-B | STE ETU | ETU Cmplt | STE -ETU Complete | STE ETU Complete |
| 12 | 1.1.2.18 | Receive STE-U/D ETU w/Detectors | milestone | 0d | 2003-06-12 A | 2003-06-12 A | 11 | 100% |  | 2003-06-12 | 2003-06-12 | 0d |  |  |  | STEREO | IMPACT | Boom Suite | STE | SWEA/STE-D and STE-U | STE | UC-B |  |  |  |  |
| 13 | 1.1.8.3 | Deliver STE-U FM 1 For STE-U BOOM Suite I & T | milestone | 0d | 2004-03-29 | 2004-03-29 | 6 |  |  | 2004-02-12 | 2004-02-12 | 0d | 0d |  |  | STEREO | IMPACT | Boom Suite | STE | SWEA/STE-D and STE-U | STE | UC-B | STE-U FM 1 |  | STE-U - FM 1 Complete | Deliver STE-U FM 1 |
| 14 | 1.2.5.2.6 | Receive STE-U FM 1 For BOOM Suite I & T | milestone | 0d | 2004-04-05 | 2004-04-05 | 13FF+5d |  |  | 2004-02-20 | 2004-02-20 | 0d | 12d | 0d |  | STEREO | IMPACT | Boom Suite | STE | SWEA/STE-D and STE-U | STE | UC-B |  |  |  |  |
| 15 | 1.1.8.5 | Deliver STE-U FM 2 For STE-U BOOM Suite I & T | milestone | 0d | 2004-03-23 | 2004-03-23 | 7 |  |  | 2004-04-08 | 2004-04-08 | 0d | 4d | 0d |  | STEREO | IMPACT | Boom Suite | STE | SWEA/STE-D and STE-U | STE | UC-B | STE-U FM 2 |  | STE-U - FM 2 Complete | Deliver STE-U FM 2 |
| 16 | 1.2.5.3.4 | Receive STE-U FM 2 For BOOM Suite I & T | milestone | 0d | 2004-03-23 | 2004-03-23 | 15FF |  |  | 2004-04-08 | 2004-04-08 | 0d | 60d | 47d |  | STEREO | IMPACT | Boom Suite | STE | SWEA/STE-D and STE-U | STE | UC-B |  |  |  |  |
| 17 | 1.1.8.7 | Deliver STE-D FM 1 For SWEA/STE-D I & T | milestone | 0d | 2004-02-10 | 2004-02-10 | 8 |  |  | 2004-01-13 | 2004-01-13 | 0d | 30d | 0d |  | STEREO | IMPACT | Boom Suite | STE | SWEA/STE-D and STE-U | STE | UC-B | STE-D FM 1 |  | Deliver STE-D FM 1 For SWEA/STE-D I & T | Deliver STE-D FM 1 For SWEA/STE I & T |
| 18 | 1.1.2.20 | Receive STE-D FM 1 w/Detectors | milestone | 0d | 2004-02-10 | 2004-02-10 | 17 |  |  | 2004-01-13 | 2004-01-13 | 0d | 30d | 12d |  | STEREO | IMPACT | Boom Suite | STE | SWEA/STE-D and STE-U | STE | UC-B |  |  |  |  |
| 19 | 1.1.8.9 | Deliver STE-D FM 2 For SWEA/STE-D I & T | milestone | 0d | 2004-02-20 | 2004-02-20 | 9 |  |  | 2004-01-22 | 2004-01-22 | 0d | 26d | 0d |  | STEREO | IMPACT | Boom Suite | STE | SWEA/STE-D and STE-U | STE | UC-B | STE-D FM 2 |  | Deliver STE-D FM 2 For SWEA/STE-D I & T | Deliver STE-D FM 2 For SWEA/STE I & T |
| 20 | 1.1.2.22 | Receive STE-D FM 2 w/Detectors | milestone | 0d | 2004-02-20 | 2004-02-20 | 19 |  |  | 2004-01-22 | 2004-01-22 | 0d | 45d |  |  | STEREO | IMPACT | Boom Suite | STE | SWEA/STE-D and STE-U | STE | UC-B |  |  |  |  |
| 21 | 2 | **STE-U/D Housing** |  | 890d | 2000-05-26 A | 2003-12-12 |  | 82% | 164.31d | 2000-05-26 | 2003-09-26 | 838d | 31d |  |  | STEREO | IMPACT | Boom Suite | STE | SWEA/STE-D and STE-U | STE | UC-B |  |  |  |  |
| 22 | 2.1 | **Design, Manufacture, Assembly and Test** |  | 890d | 2000-05-26 A | 2003-12-12 |  | 82% | 164.31d | 2000-05-26 | 2003-09-26 | 838d | 31d |  |  | STEREO | IMPACT | Boom Suite | STE | SWEA/STE-D and STE-U | STE | UC-B |  |  |  |  |
| 23 | 2.1.1 | **Design** |  | 397d | 2000-05-26 A | 2001-12-26 A |  | 100% |  | 2000-05-26 | 2001-12-26 | 397d |  |  |  | STEREO | IMPACT | Boom Suite | STE | SWEA/STE-D and STE-U | STE | UC-B |  |  |  |  |
| 24 | 2.1.1.1 | STE Aperture Design |  | 58d | 2000-05-26 A | 2000-08-17 A | 38FS+2d | 100% |  | 2000-05-26 | 2000-08-17 | 58d |  |  |  | STEREO | IMPACT | Boom Suite | STE | SWEA/STE-D and STE-U | STE | UC-B |  |  |  |  |
| 25 | 2.1.1.2 | STE Box Design |  | 37d | 2001-11-01 A | 2001-12-26 A | 3 | 100% |  | 2001-11-01 | 2001-12-26 | 37d |  |  |  | STEREO | IMPACT | Boom Suite | STE | SWEA/STE-D and STE-U | STE | UC-B |  |  |  |  |

Notes:
- 6: March 03 Status Removed 5 days of contingency
- 7: March 03 Status removed 13 days of contingency
- 8: March 03 Status removed 6 days of contingency.

| ID | WBS | Task | Type | Duration | Start | Finish | Predecessors | Complete | Remaining | Baseline start | Baseline finish | Baseline duration | Total slack | Free slack | Constraint | Text11 | Text12 | Text13 | Text14 | Text16 | Text17 | Text28 | Text23 |
| --- | --- | --- | --- | --- | --- | --- | --- | --- | --- | --- | --- | --- | --- | --- | --- | --- | --- | --- | --- | --- | --- | --- | --- |
| 26 | 2.1.2 | **Fabrication** |  | 493d | 2001-12-27 A | 2003-12-12 |  | 56% | 219.11d | 2001-12-27 | 2003-09-26 | 441d | 31d |  |  | STEREO | IMPACT | Boom Suite | STE | SWEA/STE-D and STE-U | STE | UC-B |  |
| 27 | 2.1.2.1 | **ETU** |  | 233d | 2001-12-27 A | 2002-11-29 A |  | 100% |  | 2001-12-27 | 2002-11-29 | 233d |  |  |  | STEREO | IMPACT | Boom Suite | STE | SWEA/STE-D and STE-U | STE | UC-B |  |
| 28 | 2.1.2.1.1 | Fabricate STE ETU Box |  | 37.5d | 2001-12-27 A | 2002-11-29 A | 25 | 100% |  | 2001-12-27 | 2002-11-29 | 37.5d |  |  |  | STEREO | IMPACT | Boom Suite | STE | SWEA/STE-D and STE-U | STE | UC-B |  |
| 29 | 2.1.2.2 | **FM 1 & FM 2** |  | 15d | 2003-11-21 | 2003-12-12 |  |  |  | 2003-09-08 | 2003-09-26 | 15d | 12d |  |  | STEREO | IMPACT | Boom Suite | STE | SWEA/STE-D and STE-U | STE | UC-B |  |
| 30 | 2.1.2.2.1 | **FM 1** |  | 15d | 2003-11-21 | 2003-12-12 |  |  |  | 2003-09-08 | 2003-09-26 | 15d | 12d |  |  | STEREO | IMPACT | Boom Suite | STE | SWEA/STE-D and STE-U | STE | UC-B |  |
| 31 | 2.1.2.2.1.1 | Fabricate STE FM 1 Box |  | 15d | 2003-11-21 | 2003-12-12 | 53, 78 |  |  | 2003-09-08 | 2003-09-26 | 15d | 12d | 0d | start no earlier than 2003-11-21 | STEREO | IMPACT | Boom Suite | STE | SWEA/STE-D and STE-U | STE | UC-B |  |
| 32 | 2.1.2.2.2 | **FM 2** |  | 15d | 2003-11-21 | 2003-12-12 |  |  |  | 2003-09-08 | 2003-09-26 | 15d | 31d |  |  | STEREO | IMPACT | Boom Suite | STE | SWEA/STE-D and STE-U | STE | UC-B |  |
| 33 | 2.1.2.2.2.1 | Fabricate STE FM 2 Box |  | 15d | 2003-11-21 | 2003-12-12 | 53, 78 |  |  | 2003-09-08 | 2003-09-26 | 15d | 31d | 19d | start no earlier than 2003-11-21 | STEREO | IMPACT | Boom Suite | STE | SWEA/STE-D and STE-U | STE | UC-B |  |
| 34 | 3 | **STE-U/D Detector Boards** |  | 915d | 2000-05-26 A | 2004-01-21 |  | 95% | 41.59d | 2000-05-26 | 2003-12-19 | 895d | 47d |  |  | STEREO | IMPACT | Boom Suite | STE | SWEA/STE-D and STE-U | STE | UC-B |  |
| 35 | 3.1 | **Design, Manufacture, Assembly and Test** |  | 915d | 2000-05-26 A | 2004-01-21 |  | 95% | 41.59d | 2000-05-26 | 2003-12-19 | 895d | 47d |  |  | STEREO | IMPACT | Boom Suite | STE | SWEA/STE-D and STE-U | STE | UC-B |  |
| 36 | 3.1.1 | **Procurements** |  | 796d | 2000-05-26 A | 2003-07-29 A |  | 100% |  | 2000-05-26 | 2003-07-29 | 796d |  |  |  | STEREO | IMPACT | Boom Suite | STE | SWEA/STE-D and STE-U | STE | UC-B |  |
| 37 | 3.1.1.1 | **ETU** |  | 318d | 2000-05-26 A | 2001-08-30 A |  | 100% |  | 2000-05-26 | 2001-08-30 | 318d |  |  |  | STEREO | IMPACT | Boom Suite | STE | SWEA/STE-D and STE-U | STE | UC-B |  |
| 38 | 1.1.1 | Instrument SRR | milestone | 0d | 2000-05-24 A | 2000-05-24 A |  | 100% |  | 2000-05-24 | 2000-05-24 | 0d |  |  | start no earlier than 2000-05-24 | STEREO | IMPACT | Boom Suite | STE | SWEA/STE-D and STE-U | STE | UC-B |  |
| 39 | 3.1.1.1.2 | Procure STE ETU Detector |  | 318d | 2000-05-26 A | 2001-08-30 A | 38FS+2d | 100% |  | 2000-05-26 | 2001-08-30 | 318d |  |  |  | STEREO | IMPACT | Boom Suite | STE | SWEA/STE-D and STE-U | STE | UC-B |  |
| 40 | 3.1.1.2 | **FM 1 & FM 2** |  | 472d | 2001-09-11 A | 2003-07-29 A |  | 100% |  | 2001-09-11 | 2003-07-29 | 472d |  |  |  | STEREO | IMPACT | Boom Suite | STE | SWEA/STE-D and STE-U | STE | UC-B |  |
| 41 | 1.1.5 | Instrument PDR | milestone | 1d | 2001-09-11 A | 2001-09-11 A |  | 100% |  | 2001-09-11 | 2001-09-11 | 1d |  |  | start no earlier than 2001-09-11 | STEREO | IMPACT | Boom Suite | STE | SWEA/STE-D and STE-U | STE | UC-B |  |
| 42 | 3.1.1.2.2 | Procure STE Long Lead Parts |  | 241d | 2001-09-11 A | 2003-07-29 A | 45, 41 | 100% |  | 2001-09-11 | 2003-07-29 | 241d |  |  |  | STEREO | IMPACT | Boom Suite | STE | SWEA/STE-D and STE-U | STE | UC-B | Long Lead Parts Procured and Screened |
| 43 | 3.1.1.2.3 | (OBSOLETE) Procure STE FM 1 & FM 2 Detectors |  | 21d | 2003-06-02 A | 2003-06-30 A | 41 | 100% |  | 2003-06-02 | 2003-06-30 | 21d |  |  | start no earlier than 2003-05-31 | STEREO | IMPACT | Boom Suite | STE | SWEA/STE-D and STE-U | STE | UC-B | Flight Detectors Received |
| 44 | 3.1.2 | **Design** |  | 552d | 2000-05-26 A | 2002-08-07 A |  | 100% |  | 2000-05-26 | 2002-08-07 | 552d |  |  |  | STEREO | IMPACT | Boom Suite | STE | SWEA/STE-D and STE-U | STE | UC-B |  |
| 45 | 3.1.2.1 | STE Charge Sensitive Amplifier Design |  | 318d | 2000-05-26 A | 2001-08-30 A | 38FS+2d | 100% |  | 2000-05-26 | 2001-08-30 | 318d |  |  |  | STEREO | IMPACT | Boom Suite | STE | SWEA/STE-D and STE-U | STE | UC-B |  |
| 46 | 3.1.2.2 | Layout STE ETU Detector Printed Wiring Board |  | 5d | 2002-08-01 A | 2002-08-07 A | 4 | 100% |  | 2002-08-01 | 2002-08-07 | 5d |  |  | start no earlier than 2002-07-31 | STEREO | IMPACT | Boom Suite | STE | SWEA/STE-D and STE-U | STE | UC-B |  |
| 47 | 3.1.3 | **Fabrication** |  | 294d | 2002-08-08 A | 2003-10-09 A |  | 100% |  | 2002-08-08 | 2003-09-17 | 279d |  |  |  | STEREO | IMPACT | Boom Suite | STE | SWEA/STE-D and STE-U | STE | UC-B |  |
| 48 | 3.1.3.1 | **ETU** |  | 10d | 2002-08-08 A | 2002-08-21 A |  | 100% |  | 2002-08-08 | 2002-08-21 | 10d |  |  |  | STEREO | IMPACT | Boom Suite | STE | SWEA/STE-D and STE-U | STE | UC-B |  |
| 49 | 3.1.3.1.1 | Fabrication STE ETU Detector Printed Wiring Board |  | 10d | 2002-08-08 A | 2002-08-21 A | 46 | 100% |  | 2002-08-08 | 2002-08-21 | 10d |  |  |  | STEREO | IMPACT | Boom Suite | STE | SWEA/STE-D and STE-U | STE | UC-B |  |

Notes:
- 43: 2003-05-31 status: On 6/10 it was determined that there was no need to respin the detectors this activity is now obsolete.

| ID | WBS | Task | Type | Duration | Start | Finish | Predecessors | Complete | Remaining | Baseline start | Baseline finish | Baseline duration | Total slack | Free slack | Constraint | Text11 | Text12 | Text13 | Text14 | Text16 | Text17 | Text28 | Text21 | Text23 |
| --- | --- | --- | --- | --- | --- | --- | --- | --- | --- | --- | --- | --- | --- | --- | --- | --- | --- | --- | --- | --- | --- | --- | --- | --- |
| 50 | 3.1.3.2 | **FM 1 & FM 2** |  | 28d | 2003-08-29 A | 2003-10-09 A |  | 100% |  | 2003-08-29 | 2003-09-17 | 13d |  |  |  | STEREO | IMPACT | Boom Suite | STE | SWEA/STE-D and STE-U | STE | UC-B |  |  |
| 51 | 3.1.3.2.1 | Begin Fabrication STE FM 1and FM 2 | milestone | 0d | 2003-08-29 A | 2003-08-29 A | 54SS | 100% |  | 2003-08-29 | 2003-08-29 | 0d |  |  | start no earlier than 2003-08-29 | STEREO | IMPACT | Boom Suite | STE | SWEA/STE-D and STE-U | STE | UC-B | FM1/2 Fab |  |
| 52 | 3.1.3.2.2 | **FM 1** |  | 28d | 2003-08-29 A | 2003-10-09 A |  | 100% |  | 2003-08-29 | 2003-09-17 | 13d |  |  |  | STEREO | IMPACT | Boom Suite | STE | SWEA/STE-D and STE-U | STE | UC-B |  |  |
| 53 | 1.1.11 | Instrument CDR | milestone | 3d | 2002-11-20 A | 2002-11-22 A |  | 100% |  | 2002-11-20 | 2002-11-22 | 3d |  |  | finish no earlier than 2002-11-22 | STEREO | IMPACT | Boom Suite | STE | SWEA/STE-D and STE-U | STE | UC-B |  |  |
| 54 | 3.1.3.2.2.2 | Fabrication STE FM 1 Detector Printed Wiring Board |  | 28d | 2003-08-29 A | 2003-10-09 A | 53, 78 | 100% |  | 2003-08-29 | 2003-09-17 | 13d |  |  | start no earlier than 2003-08-29 | STEREO | IMPACT | Boom Suite | STE | SWEA/STE-D and STE-U | STE | UC-B |  | FM 1 Detector PWB Fabricated |
| 55 | 3.1.3.2.3 | **FM 2** |  | 28d | 2003-08-29 A | 2003-10-09 A |  | 100% |  | 2003-08-29 | 2003-09-17 | 13d |  |  |  | STEREO | IMPACT | Boom Suite | STE | SWEA/STE-D and STE-U | STE | UC-B |  |  |
| 56 | 3.1.3.2.3.1 | Fabricate STE FM 2 Detector Printed Wiring Board |  | 28d | 2003-08-29 A | 2003-10-09 A | 53, 78 | 100% |  | 2003-08-29 | 2003-09-17 | 13d |  |  | start no earlier than 2003-08-29 | STEREO | IMPACT | Boom Suite | STE | SWEA/STE-D and STE-U | STE | UC-B |  | FM 2 Detector PWB Fabricated |
| 57 | 3.1.4 | **Assembly** |  | 214d | 2003-03-03 A | 2004-01-06 |  | 22% | 167.02d | 2003-03-03 | 2003-12-05 | 194d | 47d |  |  | STEREO | IMPACT | Boom Suite | STE | SWEA/STE-D and STE-U | STE | UC-B |  |  |
| 58 | 3.1.4.1 | **ETU** |  | 25d | 2003-03-03 A | 2003-04-04 A |  | 100% |  | 2003-03-03 | 2003-04-04 | 25d |  |  |  | STEREO | IMPACT | Boom Suite | STE | SWEA/STE-D and STE-U | STE | UC-B |  |  |
| 59 | 3.1.4.1.1 | Load STE ETU Detector Printed Wiring Board |  | 9d | 2003-03-03 A | 2003-04-04 A | 49 | 100% |  | 2003-03-03 | 2003-04-04 | 9d |  |  | start no earlier than 2003-03-01 | STEREO | IMPACT | Boom Suite | STE | SWEA/STE-D and STE-U | STE | UC-B |  | ETU Detector Board Loaded |
| 60 | 3.1.4.2 | **FM 1** |  | 17d | 2003-11-05 | 2003-12-01 |  |  |  | 2003-10-10 | 2003-10-30 | 15d | 12d |  |  | STEREO | IMPACT | Boom Suite | STE | SWEA/STE-D and STE-U | STE | UC-B |  |  |
| 61 | 3.1.4.2.1 | Load STE FM 1 Detector Printed Wiring Board |  | 17d | 2003-11-05 | 2003-12-01 | 42, 71 |  |  | 2003-10-10 | 2003-10-30 | 15d | 12d | 0d |  | STEREO | IMPACT | Boom Suite | STE | SWEA/STE-D and STE-U | STE | UC-B |  | FM 1 Detector Board Loaded |
| 62 | 3.1.4.3 | **FM 2** |  | 15d | 2003-12-15 | 2004-01-06 |  |  |  | 2003-11-14 | 2003-12-05 | 15d | 47d |  |  | STEREO | IMPACT | Boom Suite | STE | SWEA/STE-D and STE-U | STE | UC-B |  |  |
| 63 | 3.1.4.3.1 | Load STE FM 2 Detector Printed Wiring Board |  | 15d | 2003-12-15 | 2004-01-06 | 71, 42, 73 |  |  | 2003-11-14 | 2003-12-05 | 15d | 47d | 0d |  | STEREO | IMPACT | Boom Suite | STE | SWEA/STE-D and STE-U | STE | UC-B |  | FM 2 Detector Board Loaded |
| 64 | 3.1.5 | **Test** |  | 597d | 2001-08-31 A | 2004-01-21 |  | 83% | 101.28d | 2001-08-31 | 2003-12-19 | 577d | 47d |  |  | STEREO | IMPACT | Boom Suite | STE | SWEA/STE-D and STE-U | STE | UC-B |  |  |
| 65 | 3.1.5.1 | **ETU** |  | 408d | 2001-08-31 A | 2003-04-18 A |  | 100% |  | 2001-08-31 | 2003-04-18 | 408d |  |  |  | STEREO | IMPACT | Boom Suite | STE | SWEA/STE-D and STE-U | STE | UC-B |  |  |
| 66 | 3.1.5.1.1 | STE ETU Detector Tests |  | 19d | 2001-08-31 A | 2001-09-27 A | 39 | 100% |  | 2001-08-31 | 2001-09-27 | 19d |  |  |  | STEREO | IMPACT | Boom Suite | STE | SWEA/STE-D and STE-U | STE | UC-B |  |  |
| 67 | 3.1.5.1.2 | STE CSA Breadboard/Test |  | 28d | 2001-08-31 A | 2001-10-11 A | 45 | 100% |  | 2001-08-31 | 2001-10-11 | 28d |  |  |  | STEREO | IMPACT | Boom Suite | STE | SWEA/STE-D and STE-U | STE | UC-B |  |  |
| 68 | 3.1.5.1.3 | STE ETU Detector Printed Wiring Board Test |  | 10d | 2003-04-07 A | 2003-04-18 A | 59 | 100% |  | 2003-04-07 | 2003-04-18 | 10d |  |  | start no earlier than 2003-03-31 | STEREO | IMPACT | Boom Suite | STE | SWEA/STE-D and STE-U | STE | UC-B |  | ETU Detector PWB Tested |
| 69 | 3.1.5.2 | **FM 1 & FM 2** |  | 88d | 2003-07-01 A | 2003-11-04 A |  | 100% |  | 2003-07-01 | 2003-10-09 | 70d |  |  |  | STEREO | IMPACT | Boom Suite | STE | SWEA/STE-D and STE-U | STE | UC-B |  |  |
| 70 | 3.1.5.2.1 | Test STE FM 1 & FM 2 Detectors |  | 18d | 2003-07-01 A | 2003-07-25 A | 43 | 100% |  | 2003-07-01 | 2003-07-25 | 18d |  |  | start no earlier than 2003-04-30 | STEREO | IMPACT | Boom Suite | STE | SWEA/STE-D and STE-U | STE | UC-B |  | Flight Detectors Tested |
| 71 | 3.1.5.2.2 | Coupon Test STE FM 1 & FM 2 Detector Printed Wiring Board |  | 18d | 2003-10-10 A | 2003-11-04 A | 54, 56 | 100% |  | 2003-09-18 | 2003-10-09 | 15d |  |  |  | STEREO | IMPACT | Boom Suite | STE | SWEA/STE-D and STE-U | STE | UC-B |  | Flight Detector PWBs Coupon Tested |
| 72 | 3.1.5.3 | **FM 1** |  | 9d | 2003-12-02 | 2003-12-12 |  |  |  | 2003-10-31 | 2003-11-13 | 9d | 12d |  |  | STEREO | IMPACT | Boom Suite | STE | SWEA/STE-D and STE-U | STE | UC-B |  |  |
| 73 | 3.1.5.3.1 | Test STE FM 1 Detector Printed Wiring Board |  | 9d | 2003-12-02 | 2003-12-12 | 61 |  |  | 2003-10-31 | 2003-11-13 | 9d | 12d | 0d |  | STEREO | IMPACT | Boom Suite | STE | SWEA/STE-D and STE-U | STE | UC-B |  | FM 1 Detector PWB Tested |

| ID | WBS | Task | Duration | Start | Finish | Predecessors | Complete | Remaining | Baseline start | Baseline finish | Baseline duration | Total slack | Free slack | Constraint | Text11 | Text12 | Text13 | Text14 | Text16 | Text17 | Text28 | Text23 | Text21 |
| --- | --- | --- | --- | --- | --- | --- | --- | --- | --- | --- | --- | --- | --- | --- | --- | --- | --- | --- | --- | --- | --- | --- | --- |
| 74 | 3.1.5.4 | **FM 2** | 10d | 2004-01-07 | 2004-01-21 |  |  |  | 2003-12-08 | 2003-12-19 | 10d | 47d |  |  | STEREO | IMPACT | Boom Suite | STE | SWEA/STE-D and STE-U | STE | UC-B |  |  |
| 75 | 3.1.5.4.1 | Test STE FM 2 Detector Printed Wiring Board | 10d | 2004-01-07 | 2004-01-21 | 63 |  |  | 2003-12-08 | 2003-12-19 | 10d | 47d |  |  | STEREO | IMPACT | Boom Suite | STE | SWEA/STE-D and STE-U | STE | UC-B | FM 2 Detector PWB Tested |  |
| 76 | 4 | **Integration & Test** | 228d | 2003-05-01 A | 2004-03-29 |  | 25% | 171d | 2003-05-01 | 2004-02-12 | 197d | 0d |  |  | STEREO | IMPACT | Boom Suite | STE | SWEA/STE-D and STE-U | STE | UC-B |  |  |
| 77 | 4.1 | **ETU** | 30d | 2003-05-01 A | 2003-06-12 A |  | 100% |  | 2003-05-01 | 2003-06-12 | 30d |  |  |  | STEREO | IMPACT | Boom Suite | STE | SWEA/STE-D and STE-U | STE | UC-B |  |  |
| 78 | 4.1.1 | Integrate & Test STE-U/D ETU Detectors W/ ETU Housing | 30d | 2003-05-01 A | 2003-06-12 A | 28, 66, 68 | 100% |  | 2003-05-01 | 2003-06-12 | 30d |  |  | start no earlier than 2003-04-30 | STEREO | IMPACT | Boom Suite | STE | SWEA/STE-D and STE-U | STE | UC-B | ETU I & T Complete |  |
| 79 | 4.2 | **FM 1** | 72d | 2003-12-15 | 2004-03-29 |  |  |  | 2003-11-14 | 2004-02-12 | 61d | 0d |  |  | STEREO | IMPACT | Boom Suite | STE | SWEA/STE-D and STE-U | STE | UC-B |  |  |
| 80 | 4.2.1 | Integrate & Test STE-U/D FM 1 Detectors W/ FM 1 Housings | 19d | 2003-12-15 | 2004-01-13 | 31, 73 |  |  | 2003-11-14 | 2003-12-11 | 19d | 12d | 0d |  | STEREO | IMPACT | Boom Suite | STE | SWEA/STE-D and STE-U | STE | UC-B | FM 1 I & T Complete |  |
| 81 | 4.2.2 | Calibrate STE-U/D FM 1 | 20d | 2004-01-14 | 2004-02-10 | 80 |  |  | 2003-12-12 | 2004-01-13 | 20d | 15d | 0d |  | STEREO | IMPACT | Boom Suite | STE | SWEA/STE-D and STE-U | STE | UC-B | FM 1 Calibrated |  |
| 82 | 5.4.4 | FM 1 Boom Structure Vibration Testing Completed | 4d | 2004-03-04 | 2004-03-09 | 81 |  |  | 2004-01-20 | 2004-01-23 | 4d | 0d |  |  | STEREO | IMPACT | Boom Suite | STE | SWEA/STE-D and STE-U | STE | UC-B |  |  |
| 83 | 4.2.4 | STE-U FM 1 Thermal Vacuum/Balance | 14d | 2004-03-10 | 2004-03-29 | 81, 82 |  |  | 2004-01-26 | 2004-02-12 | 14d | 0d |  |  | STEREO | IMPACT | Boom Suite | STE | SWEA/STE-D and STE-U | STE | UC-B | FM 1 Enviornmental Testing Complete | Begin FM1 TVB TSt / FM1 STE-U Complete |
| 84 | 4.3 | **FM 2** | 49d | 2004-01-14 | 2004-03-23 |  |  |  | 2003-12-12 | 2004-02-11 | 41d | 4d |  |  | STEREO | IMPACT | Boom Suite | STE | SWEA/STE-D and STE-U | STE | UC-B |  |  |
| 85 | 4.3.1 | Integrate & Test STE-U/D FM 2 Detectors W/ FM 2 Housings | 9d | 2004-01-14 | 2004-01-26 | 33, 80 |  |  | 2003-12-12 | 2003-12-24 | 9d | 12d | 0d |  | STEREO | IMPACT | Boom Suite | STE | SWEA/STE-D and STE-U | STE | UC-B | FM 2 I & T Complete |  |
| 86 | 4.3.2 | Calibrate STE-U/D FM 2 | 18d | 2004-01-27 | 2004-02-20 | 85 |  |  | 2003-12-26 | 2004-01-22 | 18d | 12d | 0d |  | STEREO | IMPACT | Boom Suite | STE | SWEA/STE-D and STE-U | STE | UC-B | FM 2 Calibrated |  |
| 87 | 6.4.4 | FM 2 Boom Structure Vibration Test | 4d | 2004-03-04 | 2004-03-09 | 86 |  |  | 2004-01-23 | 2004-01-28 | 4d | 4d | 0d |  | STEREO | IMPACT | Boom Suite | STE | SWEA/STE-D and STE-U | STE | UC-B |  |  |
| 88 | 4.3.4 | STE-U FM 2 Thermal Vacuum | 10d | 2004-03-10 | 2004-03-23 | 86, 87 |  |  | 2004-01-29 | 2004-02-11 | 10d | 4d | 0d |  | STEREO | IMPACT | Boom Suite | STE | SWEA/STE-D and STE-U | STE | UC-B | FM 2 Enviornmental Testing Complete | FM2 TVB Tst |
